# JT Network Upgrades

Schedule from MS Project, 2019-12-02 to 2020-03-19, costs in $.
Java Tucana

## Calendars

- Java Tucana Admin: Mon-Fri 08:00-12:00, 13:00-17:00; Sat-Sun off. Exceptions (off unless hours are given): 2017-07-04 to 2022-07-04 (Jul 4th Holiday, recurring), 2017-11-23 to 2022-11-24 (Thanksgiving, recurring), 2017-12-25 to 2021-12-25 (Christmas, recurring), 2018-01-01 to 2022-01-01 (New Year's Day, recurring).

## Resources

| Resource | Group | Rate |
| --- | --- | --- |
| Charlie Mejia | Admin | 27.4 |
| Ann Chung | IT | 26.92 |
| Ron Sova | Marketing | 25 |
| Rick Herrera | Projects | 25.48 |
| Dorothy Windle | Call Center | 32 |
| Call Center Day Analysts | Call Center | 15 |
| Juan Silva | Internet Sales Center | 32 |
| Internet Sales Day Operators | Internet Sales Center | 15 |
| Maintenance | Maintenance | 40 |
| Network Heroes | Contract |  |
| Extreme Designs | Contract |  |
| Environmental Wizards | Contract |  |
| Joe Student | Projects | 84.13 |

## Schedule

| ID | WBS | Task | Type | Duration | Start | Finish | Predecessors | Total slack | Free slack | Constraint | Resources | Work | Cost |
| --- | --- | --- | --- | --- | --- | --- | --- | --- | --- | --- | --- | --- | --- |
| 1 | 1 | **Project Status Meetings** |  | 73.12d | 2019-12-05 08:00 | 2020-03-19 09:00 |  | 0.12d |  |  |  |  |  |
| 2 | 1.1 | Project Status Meetings 1 |  | 1h | 2019-12-05 08:00 | 2019-12-05 09:00 |  | 73.12d |  | start no earlier than 2019-12-05 08:00 |  |  |  |
| 3 | 1.2 | Project Status Meetings 2 |  | 1h | 2019-12-12 08:00 | 2019-12-12 09:00 |  | 68.12d |  | start no earlier than 2019-12-12 08:00 |  |  |  |
| 4 | 1.3 | Project Status Meetings 3 |  | 1h | 2019-12-19 08:00 | 2019-12-19 09:00 |  | 63.12d |  | start no earlier than 2019-12-19 08:00 |  |  |  |
| 5 | 1.4 | Project Status Meetings 4 |  | 1h | 2019-12-26 08:00 | 2019-12-26 09:00 |  | 59.12d |  | start no earlier than 2019-12-26 08:00 |  |  |  |
| 6 | 1.5 | Project Status Meetings 5 |  | 1h | 2020-01-02 08:00 | 2020-01-02 09:00 |  | 55.12d |  | start no earlier than 2020-01-02 08:00 |  |  |  |
| 7 | 1.6 | Project Status Meetings 6 |  | 1h | 2020-01-09 08:00 | 2020-01-09 09:00 |  | 50.12d |  | start no earlier than 2020-01-09 08:00 |  |  |  |
| 8 | 1.7 | Project Status Meetings 7 |  | 1h | 2020-01-16 08:00 | 2020-01-16 09:00 |  | 45.12d |  | start no earlier than 2020-01-16 08:00 |  |  |  |
| 9 | 1.8 | Project Status Meetings 8 |  | 1h | 2020-01-23 08:00 | 2020-01-23 09:00 |  | 40.12d |  | start no earlier than 2020-01-23 08:00 |  |  |  |
| 10 | 1.9 | Project Status Meetings 9 |  | 1h | 2020-01-30 08:00 | 2020-01-30 09:00 |  | 35.12d |  | start no earlier than 2020-01-30 08:00 |  |  |  |
| 11 | 1.10 | Project Status Meetings 10 |  | 1h | 2020-02-06 08:00 | 2020-02-06 09:00 |  | 30.12d |  | start no earlier than 2020-02-06 08:00 |  |  |  |
| 12 | 1.11 | Project Status Meetings 11 |  | 1h | 2020-02-13 08:00 | 2020-02-13 09:00 |  | 25.12d |  | start no earlier than 2020-02-13 08:00 |  |  |  |
| 13 | 1.12 | Project Status Meetings 12 |  | 1h | 2020-02-20 08:00 | 2020-02-20 09:00 |  | 20.12d |  | start no earlier than 2020-02-20 08:00 |  |  |  |
| 14 | 1.13 | Project Status Meetings 13 |  | 1h | 2020-02-27 08:00 | 2020-02-27 09:00 |  | 15.12d |  | start no earlier than 2020-02-27 08:00 |  |  |  |
| 15 | 1.14 | Project Status Meetings 14 |  | 1h | 2020-03-05 08:00 | 2020-03-05 09:00 |  | 10.12d |  | start no earlier than 2020-03-05 08:00 |  |  |  |
| 16 | 1.15 | Project Status Meetings 15 |  | 1h | 2020-03-12 08:00 | 2020-03-12 09:00 |  | 5.12d |  | start no earlier than 2020-03-12 08:00 |  |  |  |
| 17 | 1.16 | Project Status Meetings 16 |  | 1h | 2020-03-19 08:00 | 2020-03-19 09:00 |  | 0.12d |  | start no earlier than 2020-03-19 08:00 |  |  |  |
| 18 | 2 | **Planning Phase** |  | 36.5d | 2019-12-02 08:00 | 2020-01-23 12:00 |  | 7.38d |  |  |  | 376h | 10,390.77 |
| 19 | 2.1 | Document Current Environment |  | 4d | 2019-12-02 08:00 | 2019-12-05 17:00 |  | 7.38d | 0d |  | Ann Chung | 32h | 861.54 |
| 20 | 2.2 | Conduct Needs Analysis |  | 2w | 2019-12-06 08:00 | 2019-12-19 17:00 | 19 | 7.38d | 0d |  | Rick Herrera; Dorothy Windle | 160h | 4,598.46 |
| 21 | 2.3 | Identify Hardware, Software,Equipment, and Supplies Required |  | 4h | 2019-12-20 08:00 | 2019-12-20 12:00 | 20 | 7.38d | 0d |  | Ann Chung; Network Heroes | 8h | 107.69 |
| 22 | 2.4 | Create Request for Proposal and Timeline |  | 4d | 2019-12-20 13:00 | 2019-12-27 12:00 | 21 | 7.38d | 0d |  | Charlie Mejia | 32h | 876.92 |
| 23 | 2.5 | Gather Vendor Bids |  | 2w | 2019-12-27 13:00 | 2020-01-13 12:00 | 22 | 7.38d | 0d |  | Charlie Mejia | 80h | 2,192.31 |
| 24 | 2.6 | Choose Vendors |  | 1w | 2020-01-13 13:00 | 2020-01-20 12:00 | 23 | 7.38d | 0d |  | Charlie Mejia | 40h | 1,096.15 |
| 25 | 2.7 | Sign Contracts |  | 3d | 2020-01-20 13:00 | 2020-01-23 12:00 | 24 | 7.38d | 0d |  | Charlie Mejia | 24h | 657.69 |
| 26 | 2.8 | Planning Phase Complete | milestone | 0d | 2020-01-23 12:00 | 2020-01-23 12:00 | 25 | 7.38d | 0d |  |  |  |  |

| ID | WBS | Task | Type | Duration | Start | Finish | Predecessors | Total slack | Free slack | Constraint | Resources | Work | Cost |
| --- | --- | --- | --- | --- | --- | --- | --- | --- | --- | --- | --- | --- | --- |
| 27 | 3 | **Procurement Phase** |  | 8d | 2020-01-23 13:00 | 2020-02-04 12:00 |  | 7.38d |  |  |  | 64h | 4,926.92 |
| 28 | 3.1 | Order Hardware Components |  | 3d | 2020-01-23 13:00 | 2020-01-28 12:00 | 26 | 7.38d | 0d |  | Joe Student | 24h | 2,019.23 |
| 29 | 3.2 | Order Infustructure Components |  | 3d | 2020-01-28 13:00 | 2020-01-31 12:00 | 28 | 7.38d | 0d |  | Joe Student | 24h | 2,019.23 |
| 30 | 3.3 | Purchase Software Licenses |  | 1d | 2020-01-31 13:00 | 2020-02-03 12:00 | 29 | 7.38d | 0d |  | Joe Student | 8h | 673.08 |
| 31 | 3.4 | Identify Additional Needed Components and Order |  | 1d | 2020-02-03 13:00 | 2020-02-04 12:00 | 30 | 7.38d | 0d |  | Ann Chung | 8h | 215.38 |
| 32 | 3.5 | Procurement Phase Complete | milestone | 0d | 2020-02-04 12:00 | 2020-02-04 12:00 | 31 | 7.38d | 0.5d |  |  |  |  |
| 33 | 4 | **Installation and Testing Phase** |  | 17d | 2020-02-10 08:00 | 2020-03-03 17:00 |  | 0d |  |  |  | 136h |  |
| 34 | 4.1 | Install Cabling |  | 2w | 2020-02-10 08:00 | 2020-02-21 17:00 | 32FS+5ed | 6.88d | 2.88d |  | Network Heroes | 80h |  |
| 35 | 4.2 | Install Hardware |  | 1w | 2020-02-14 08:00 | 2020-02-20 17:00 | 34SS+5e% | 4d | 0d | start no earlier than 2020-02-14 08:00 | Network Heroes | 40h |  |
| 36 | 4.3 | Install Software |  | 3d | 2020-02-20 08:00 | 2020-02-24 17:00 | 35FS-5e% | 4d |  |  |  |  |  |
| 37 | 4.4 | Test Network |  | 2d | 2020-03-02 08:00 | 2020-03-03 17:00 | 36 | 0d |  | start no earlier than 2020-03-02 08:00 | Network Heroes | 16h |  |
| 38 | 4.5 | Installation and Testing Phase Complete | milestone | 0d | 2020-03-03 17:00 | 2020-03-03 17:00 | 37 | 0d |  |  |  |  |  |
| 39 | 5 | **Training and Communication Phase** |  | 6.38d | 2020-03-04 08:00 | 2020-03-12 11:00 |  | 0d |  |  |  | 51.5h | 1,623.5 |
| 40 | 5.1 | Communicate Information Updates |  | 3h | 2020-03-04 08:00 | 2020-03-04 11:00 | 38 | 0d |  |  | Ron Sova | 3h | 75 |
| 41 | 5.2 | Communicate "Go Live" Date |  | 0.5h | 2020-03-04 11:00 | 2020-03-04 11:30 | 40 | 0d |  |  | Ron Sova | 0.5h | 12.5 |
| 42 | 5.3 | Train Management |  | 3d | 2020-03-04 11:00 | 2020-03-09 11:00 | 41SS | 0d |  |  | Juan Silva | 24h | 768 |
| 43 | 5.4 | Train Users |  | 3d | 2020-03-09 11:00 | 2020-03-12 11:00 | 42 | 0d |  |  | Juan Silva | 24h | 768 |
| 44 | 5.5 | Traning and Communication Phase Complete | milestone | 0d | 2020-03-12 11:00 | 2020-03-12 11:00 | 43 | 0d |  |  |  |  |  |
| 45 | 6 | **Evaluation and Close Out Phase** |  | 4.88d | 2020-03-12 11:00 | 2020-03-19 10:00 |  | 0d |  |  |  | 41h | 1,195.73 |
| 46 | 6.1 | Assess Project Success |  | 4d | 2020-03-12 11:00 | 2020-03-18 11:00 | 44 | 0d |  |  | Charlie Mejia | 32h | 876.92 |
| 47 | 6.2 | Establish Maintenance Schedule |  | 5h | 2020-03-18 11:00 | 2020-03-18 17:00 | 46 | 0d |  |  | Maintenance | 5h | 200 |
| 48 | 6.3 | Review Meeting - Successes and Improvements Needed |  | 2h | 2020-03-19 08:00 | 2020-03-19 10:00 | 47 | 0d |  |  | Charlie Mejia; Dorothy Windle | 4h | 118.81 |
| 49 | 6.4 | Evaluation and Closeout Phase Complete | milestone | 0d | 2020-03-19 10:00 | 2020-03-19 10:00 | 48 | 0d |  |  |  |  |  |
| 50 | 7 | JT Network Upgrades Complete | milestone | 0d | 2020-03-19 10:00 | 2020-03-19 10:00 | 49 | 0d |  | finish no later than 2020-03-20 08:00 |  |  |  |
