# JT Corporate Move

Schedule from MS Project, 2019-07-02 to 2019-12-06, A marks actual dates.
Refurbish New Offices and Move
Java Tucana

## Calendars

- Java Tucana Admin: Mon-Fri 08:00-12:00, 13:00-17:00; Sat-Sun off. Exceptions (off unless hours are given): 2017-07-04 to 2022-07-04 (Jul 4th Holiday, recurring).

## Resources

| Resource | Group | Rate |
| --- | --- | --- |
| Charlie Mejia | Admin | 27.4 |
| Ann Chung | IT | 26.92 |
| Ron Sova | Marketing | 25 |
| Rick Herrera | Projects | 25.48 |
| Dorothy Windle | Call Center | 32 |
| Call Center Day Analysts | Call Center | 15 |
| Jaun Silva | Internet Sales Center | 32 |
| Internet Sales Day Operators | Internet Sales Center | 15 |
| Maintenance | Maintenance | 40 |
| Network Heroes | Contract |  |
| Extreme Designs | Contract |  |

## Schedule

| ID | WBS | Task | Duration | Start | Finish | Baseline start | Baseline finish | Baseline duration | Total slack | Constraint |
| --- | --- | --- | --- | --- | --- | --- | --- | --- | --- | --- |
| 1 | 1 | **JT Move Status Meetings** | 110.12d | 2019-07-05 08:00 | 2019-12-06 09:00 | 2019-07-05 08:00 | 2019-12-06 09:00 | 110.12d | 0d |  |
| 2 | 1.1 | JT Move Status Meetings 1 | 1h | 2019-07-05 08:00 | 2019-07-05 09:00 | 2019-07-05 08:00 | 2019-07-05 09:00 | 1h | 110d | start no earlier than 2019-07-05 08:00 |
| 3 | 1.2 | JT Move Status Meetings 2 | 1h | 2019-07-12 08:00 | 2019-07-12 09:00 | 2019-07-12 08:00 | 2019-07-12 09:00 | 1h | 105d | start no earlier than 2019-07-12 08:00 |
| 4 | 1.3 | JT Move Status Meetings 3 | 1h | 2019-07-19 08:00 | 2019-07-19 09:00 | 2019-07-19 08:00 | 2019-07-19 09:00 | 1h | 100d | start no earlier than 2019-07-19 08:00 |
| 5 | 1.4 | JT Move Status Meetings 4 | 1h | 2019-07-26 08:00 | 2019-07-26 09:00 | 2019-07-26 08:00 | 2019-07-26 09:00 | 1h | 95d | start no earlier than 2019-07-26 08:00 |
| 6 | 1.5 | JT Move Status Meetings 5 | 1h | 2019-08-02 08:00 | 2019-08-02 09:00 | 2019-08-02 08:00 | 2019-08-02 09:00 | 1h | 90d | start no earlier than 2019-08-02 08:00 |
| 7 | 1.6 | JT Move Status Meetings 6 | 1h | 2019-08-09 08:00 | 2019-08-09 09:00 | 2019-08-09 08:00 | 2019-08-09 09:00 | 1h | 85d | start no earlier than 2019-08-09 08:00 |
| 8 | 1.7 | JT Move Status Meetings 7 | 1h | 2019-08-16 08:00 | 2019-08-16 09:00 | 2019-08-16 08:00 | 2019-08-16 09:00 | 1h | 80d | start no earlier than 2019-08-16 08:00 |
| 9 | 1.8 | JT Move Status Meetings 8 | 1h | 2019-08-23 08:00 | 2019-08-23 09:00 | 2019-08-23 08:00 | 2019-08-23 09:00 | 1h | 75d | start no earlier than 2019-08-23 08:00 |
| 10 | 1.9 | JT Move Status Meetings 9 | 1h | 2019-08-30 08:00 | 2019-08-30 09:00 | 2019-08-30 08:00 | 2019-08-30 09:00 | 1h | 70d | start no earlier than 2019-08-30 08:00 |
| 11 | 1.10 | JT Move Status Meetings 10 | 1h | 2019-09-06 08:00 | 2019-09-06 09:00 | 2019-09-06 08:00 | 2019-09-06 09:00 | 1h | 65d | start no earlier than 2019-09-06 08:00 |
| 12 | 1.11 | JT Move Status Meetings 11 | 1h | 2019-09-13 08:00 | 2019-09-13 09:00 | 2019-09-13 08:00 | 2019-09-13 09:00 | 1h | 60d | start no earlier than 2019-09-13 08:00 |
| 13 | 1.12 | JT Move Status Meetings 12 | 1h | 2019-09-20 08:00 | 2019-09-20 09:00 | 2019-09-20 08:00 | 2019-09-20 09:00 | 1h | 55d | start no earlier than 2019-09-20 08:00 |
| 14 | 1.13 | JT Move Status Meetings 13 | 1h | 2019-09-27 08:00 | 2019-09-27 09:00 | 2019-09-27 08:00 | 2019-09-27 09:00 | 1h | 50d | start no earlier than 2019-09-27 08:00 |
| 15 | 1.14 | JT Move Status Meetings 14 | 1h | 2019-10-04 08:00 | 2019-10-04 09:00 | 2019-10-04 08:00 | 2019-10-04 09:00 | 1h | 45d | start no earlier than 2019-10-04 08:00 |
| 16 | 1.15 | JT Move Status Meetings 15 | 1h | 2019-10-11 08:00 | 2019-10-11 09:00 | 2019-10-11 08:00 | 2019-10-11 09:00 | 1h | 40d | start no earlier than 2019-10-11 08:00 |
| 17 | 1.16 | JT Move Status Meetings 16 | 1h | 2019-10-18 08:00 | 2019-10-18 09:00 | 2019-10-18 08:00 | 2019-10-18 09:00 | 1h | 35d | start no earlier than 2019-10-18 08:00 |
| 18 | 1.17 | JT Move Status Meetings 17 | 1h | 2019-10-25 08:00 | 2019-10-25 09:00 | 2019-10-25 08:00 | 2019-10-25 09:00 | 1h | 30d | start no earlier than 2019-10-25 08:00 |
| 19 | 1.18 | JT Move Status Meetings 18 | 1h | 2019-11-01 08:00 | 2019-11-01 09:00 | 2019-11-01 08:00 | 2019-11-01 09:00 | 1h | 25d | start no earlier than 2019-11-01 08:00 |
| 20 | 1.19 | JT Move Status Meetings 19 | 1h | 2019-11-08 08:00 | 2019-11-08 09:00 | 2019-11-08 08:00 | 2019-11-08 09:00 | 1h | 20d | start no earlier than 2019-11-08 08:00 |
| 21 | 1.20 | JT Move Status Meetings 20 | 1h | 2019-11-15 08:00 | 2019-11-15 09:00 | 2019-11-15 08:00 | 2019-11-15 09:00 | 1h | 15d | start no earlier than 2019-11-15 08:00 |
| 22 | 1.21 | JT Move Status Meetings 21 | 1h | 2019-11-22 08:00 | 2019-11-22 09:00 | 2019-11-22 08:00 | 2019-11-22 09:00 | 1h | 10d | start no earlier than 2019-11-22 08:00 |
| 23 | 1.22 | JT Move Status Meetings 22 | 1h | 2019-11-29 08:00 | 2019-11-29 09:00 | 2019-11-29 08:00 | 2019-11-29 09:00 | 1h | 5d | start no earlier than 2019-11-29 08:00 |
| 24 | 1.23 | JT Move Status Meetings 23 | 1h | 2019-12-06 08:00 | 2019-12-06 09:00 | 2019-12-06 08:00 | 2019-12-06 09:00 | 1h | 0d | start no earlier than 2019-12-06 08:00 |

| ID | WBS | Task | Type | Duration | Start | Finish | Predecessors | Complete | Remaining | Baseline start | Baseline finish | Baseline duration | Total slack | Free slack | Work |
| --- | --- | --- | --- | --- | --- | --- | --- | --- | --- | --- | --- | --- | --- | --- | --- |
| 25 | 2 | **Planning the Move** |  | 48.5d | 2019-07-02 08:00 A | 2019-09-09 12:00 |  | 91% | 4.14d | 2019-07-02 08:00 | 2019-09-09 12:00 | 48.5d | 5.12d |  |  |
| 26 | 2.1 | Identify Move Team Members |  | 2d | 2019-07-02 08:00 A | 2019-07-03 17:00 A |  | 100% |  | 2019-07-02 08:00 | 2019-07-03 17:00 | 2d |  |  |  |
| 27 | 2.2 | Plan Infastructure Upgrades |  | 2w | 2019-07-05 08:00 A | 2019-07-18 17:00 A | 26 | 100% |  | 2019-07-05 08:00 | 2019-07-18 17:00 | 2w |  |  |  |
| 28 | 2.3 | Plan IT Move |  | 2w | 2019-07-19 08:00 A | 2019-08-01 17:00 A | 27 | 100% |  | 2019-07-19 08:00 | 2019-08-01 17:00 | 2w |  |  |  |
| 29 | 2.4 | Plan Physical Move |  | 2w | 2019-07-23 13:00 A | 2019-08-06 12:00 A | 28FS-7.5% | 100% |  | 2019-07-23 13:00 | 2019-08-06 12:00 | 2w |  |  |  |
| 30 | 2.5 | Plan for Continous Operations During the Move |  | 4d | 2019-08-06 13:00 A | 2019-08-12 12:00 A | 29 | 100% |  | 2019-08-06 13:00 | 2019-08-12 12:00 | 4d |  |  |  |
| 31 | 2.6 | Obtain Estimates from Moving Services |  | 1w | 2019-08-12 08:00 A | 2019-08-16 17:00 A | 30 | 100% |  | 2019-08-12 08:00 | 2019-08-16 17:00 | 1w |  |  |  |
| 32 | 2.7 | Interview and Select Movers |  | 1.5w | 2019-08-15 08:00 A | 2019-08-26 12:00 A | 31 | 100% |  | 2019-08-15 08:00 | 2019-08-26 12:00 | 1.5w |  |  |  |
| 33 | 2.8 | Obtain Estimates from IT Installation Companies |  | 1w | 2019-08-19 08:00 A | 2019-08-23 17:00 A | 31 | 100% |  | 2019-08-19 08:00 | 2019-08-23 17:00 | 1w |  |  |  |
| 34 | 2.9 | Interview and Select IT Installation Company |  | 1w | 2019-08-26 08:00 A | 2019-08-30 17:00 A | 33, 32 | 100% |  | 2019-08-26 08:00 | 2019-08-30 17:00 | 1w |  |  |  |
| 35 | 2.10 | Order Boxes and Materials needed for the Move |  | 3h | 2019-09-02 08:00 A | 2019-09-02 11:00 A | 34 | 100% |  | 2019-09-02 08:00 | 2019-09-02 11:00 | 3h |  |  |  |
| 36 | 2.11 | Planning the Move Complete | milestone | 0d | 2019-09-02 08:00 A | 2019-09-02 08:00 A | 35 | 100% |  | 2019-09-02 08:00 | 2019-09-02 08:00 | 0d |  |  |  |
| 37 | 2.12 | **Communications** |  | 5.5d | 2019-09-02 08:00 | 2019-09-09 12:00 |  |  |  | 2019-09-02 08:00 | 2019-09-09 12:00 | 5.5d | 5.12d |  |  |
| 38 | 2.12.1 | Communicate Move Plan to Employees |  | 3d | 2019-09-02 08:00 | 2019-09-04 17:00 | 36 |  |  | 2019-09-02 08:00 | 2019-09-04 17:00 | 3d | 5.12d | 0d |  |
| 39 | 2.12.2 | Gather Feedback From Employees |  | 2d | 2019-09-05 08:00 | 2019-09-06 17:00 | 38 |  |  | 2019-09-05 08:00 | 2019-09-06 17:00 | 2d | 5.12d | 0d |  |
| 40 | 2.12.3 | Communicate Move Information to Suppliers |  | 2h | 2019-09-09 08:00 | 2019-09-09 10:00 | 39 |  |  | 2019-09-09 08:00 | 2019-09-09 10:00 | 2h | 5.12d | 0d |  |
| 41 | 2.12.4 | Communicate Move Information to Customers |  | 2h | 2019-09-09 10:00 | 2019-09-09 12:00 | 40 |  |  | 2019-09-09 10:00 | 2019-09-09 12:00 | 2h | 5.12d | 0d |  |
| 42 | 2.12.5 | Communications Complete | milestone | 0d | 2019-09-09 12:00 | 2019-09-09 12:00 | 41 |  |  | 2019-09-09 12:00 | 2019-09-09 12:00 | 0d | 5.12d | 0d |  |
| 43 | 3 | **JT Corporate Center Preparation** |  | 24d | 2019-09-09 13:00 | 2019-10-11 12:00 |  |  |  | 2019-09-09 13:00 | 2019-10-11 12:00 | 24d | 5.12d |  | 16h |
| 44 | 3.1 | **JT Call Center Refurbishing New Location** |  | 22d | 2019-09-09 13:00 | 2019-10-09 12:00 |  |  |  | 2019-09-09 13:00 | 2019-10-09 12:00 | 22d | 5.12d |  | 16h |
| 45 | 3.1.1 | Install Network Cables |  | 3d | 2019-09-09 13:00 | 2019-09-12 12:00 | 42 |  |  | 2019-09-09 13:00 | 2019-09-12 12:00 | 3d | 5.12d | 0d |  |
| 46 | 3.1.2 | Install TeleCommunication Lines |  | 1w | 2019-09-12 13:00 | 2019-09-19 12:00 | 45 |  |  | 2019-09-12 13:00 | 2019-09-19 12:00 | 1w | 7.12d | 0d |  |
| 47 | 3.1.3 | Paint the walls |  | 2d | 2019-09-19 13:00 | 2019-09-23 12:00 | 46 |  |  | 2019-09-19 13:00 | 2019-09-23 12:00 | 2d | 7.12d | 0d | 16h |
| 48 | 3.1.4 | Lay Carpet |  | 2d | 2019-09-24 13:00 | 2019-09-26 12:00 | 47FS+1ed |  |  | 2019-09-24 13:00 | 2019-09-26 12:00 | 2d | 7.12d | 0d |  |
| 49 | 3.1.5 | Install Partitions |  | 1d | 2019-09-26 13:00 | 2019-09-27 12:00 | 48 |  |  | 2019-09-26 13:00 | 2019-09-27 12:00 | 1d | 7.12d | 0d |  |
| 50 | 3.1.6 | Prepare Offices |  | 5d | 2019-09-27 13:00 | 2019-10-04 12:00 | 49 |  |  | 2019-09-27 13:00 | 2019-10-04 12:00 | 5d | 7.12d | 0d |  |
| 51 | 3.1.7 | Assemble Furniture |  | 2d | 2019-10-04 13:00 | 2019-10-08 12:00 | 50 |  |  | 2019-10-04 13:00 | 2019-10-08 12:00 | 2d | 7.12d | 0d |  |
| 52 | 3.1.8 | Hook up Computers |  | 1d | 2019-10-08 13:00 | 2019-10-09 12:00 | 51 |  |  | 2019-10-08 13:00 | 2019-10-09 12:00 | 1d | 7.12d | 0d |  |
| 53 | 3.1.9 | Hook up Phones |  | 1d | 2019-10-08 13:00 | 2019-10-09 12:00 | 52FF |  |  | 2019-10-08 13:00 | 2019-10-09 12:00 | 1d | 7.12d | 0d |  |
| 54 | 3.1.10 | JT Call Center Complete | milestone | 0d | 2019-10-09 12:00 | 2019-10-09 12:00 | 53 |  |  | 2019-10-09 12:00 | 2019-10-09 12:00 | 0d | 7.12d | 2d |  |

| ID | WBS | Task | Type | Duration | Start | Finish | Predecessors | Baseline start | Baseline finish | Baseline duration | Total slack | Free slack |
| --- | --- | --- | --- | --- | --- | --- | --- | --- | --- | --- | --- | --- |
| 55 | 3.2 | **JT Internet Sales Center Refurbishing New Location** |  | 24d | 2019-09-09 13:00 | 2019-10-11 12:00 |  | 2019-09-09 13:00 | 2019-10-11 12:00 | 24d | 5.12d |  |
| 56 | 3.2.1 | Install Network Cables |  | 3d | 2019-09-09 13:00 | 2019-09-12 12:00 | 45SS | 2019-09-09 13:00 | 2019-09-12 12:00 | 3d | 5.12d | 0d |
| 57 | 3.2.2 | Install TeleCommunication Lines |  | 1w | 2019-09-12 13:00 | 2019-09-19 12:00 | 56 | 2019-09-12 13:00 | 2019-09-19 12:00 | 1w | 5.12d | 0d |
| 58 | 3.2.3 | Paint the walls |  | 2d | 2019-09-19 13:00 | 2019-09-23 12:00 | 57 | 2019-09-19 13:00 | 2019-09-23 12:00 | 2d | 5.12d | 0d |
| 59 | 3.2.4 | Lay Carpet |  | 2d | 2019-09-24 13:00 | 2019-09-26 12:00 | 58FS+1ed | 2019-09-24 13:00 | 2019-09-26 12:00 | 2d | 5.12d | 0d |
| 60 | 3.2.5 | Install Partitions |  | 1d | 2019-09-26 13:00 | 2019-09-27 12:00 | 59 | 2019-09-26 13:00 | 2019-09-27 12:00 | 1d | 5.12d | 0d |
| 61 | 3.2.6 | Prepare Offices |  | 5d | 2019-09-27 13:00 | 2019-10-04 12:00 | 60 | 2019-09-27 13:00 | 2019-10-04 12:00 | 5d | 5.12d | 0d |
| 62 | 3.2.7 | Assemble Furniture |  | 2d | 2019-10-04 13:00 | 2019-10-08 12:00 | 61 | 2019-10-04 13:00 | 2019-10-08 12:00 | 2d | 5.12d | 0d |
| 63 | 3.2.8 | Hook up Computers |  | 1d | 2019-10-08 13:00 | 2019-10-09 12:00 | 62 | 2019-10-08 13:00 | 2019-10-09 12:00 | 1d | 5.12d | 0d |
| 64 | 3.2.9 | Hook up Phones |  | 1d | 2019-10-08 13:00 | 2019-10-09 12:00 | 63FF | 2019-10-08 13:00 | 2019-10-09 12:00 | 1d | 5.12d | 0d |
| 65 | 3.2.10 | Move in Belongings |  | 2d | 2019-10-09 13:00 | 2019-10-11 12:00 | 64 | 2019-10-09 13:00 | 2019-10-11 12:00 | 2d | 5.12d | 0d |
| 66 | 3.2.11 | JT Internet Sales Center Complete | milestone | 0d | 2019-10-11 12:00 | 2019-10-11 12:00 | 65 | 2019-10-11 12:00 | 2019-10-11 12:00 | 0d | 5.12d | 0d |
| 67 | 3.3 | **JT Administration Offices Refurbishing New Location** |  | 24d | 2019-09-09 13:00 | 2019-10-11 12:00 |  | 2019-09-09 13:00 | 2019-10-11 12:00 | 24d | 5.12d |  |
| 68 | 3.3.1 | Install Network Cables |  | 3d | 2019-09-09 13:00 | 2019-09-12 12:00 | 56SS | 2019-09-09 13:00 | 2019-09-12 12:00 | 3d | 5.12d | 0d |
| 69 | 3.3.2 | Install TeleCommunication Lines |  | 1w | 2019-09-12 13:00 | 2019-09-19 12:00 | 68 | 2019-09-12 13:00 | 2019-09-19 12:00 | 1w | 5.12d | 0d |
| 70 | 3.3.3 | Paint the walls |  | 2d | 2019-09-19 13:00 | 2019-09-23 12:00 | 69 | 2019-09-19 13:00 | 2019-09-23 12:00 | 2d | 5.12d | 0d |
| 71 | 3.3.4 | Lay Carpet |  | 2d | 2019-09-24 13:00 | 2019-09-26 12:00 | 70FS+1ed | 2019-09-24 13:00 | 2019-09-26 12:00 | 2d | 5.12d | 0d |
| 72 | 3.3.5 | Install Partitions |  | 1d | 2019-09-26 13:00 | 2019-09-27 12:00 | 71 | 2019-09-26 13:00 | 2019-09-27 12:00 | 1d | 5.12d | 0d |
| 73 | 3.3.6 | Prepare Offices |  | 5d | 2019-09-27 13:00 | 2019-10-04 12:00 | 72 | 2019-09-27 13:00 | 2019-10-04 12:00 | 5d | 5.12d | 0d |
| 74 | 3.3.7 | Assemble Furniture |  | 2d | 2019-10-04 13:00 | 2019-10-08 12:00 | 73 | 2019-10-04 13:00 | 2019-10-08 12:00 | 2d | 5.12d | 0d |
| 75 | 3.3.8 | Hook up Computers |  | 1d | 2019-10-08 13:00 | 2019-10-09 12:00 | 74 | 2019-10-08 13:00 | 2019-10-09 12:00 | 1d | 5.12d | 0d |
| 76 | 3.3.9 | Hook up Phones |  | 1d | 2019-10-08 13:00 | 2019-10-09 12:00 | 75FF | 2019-10-08 13:00 | 2019-10-09 12:00 | 1d | 5.12d | 0d |
| 77 | 3.3.10 | Move in Belongings |  | 2d | 2019-10-09 13:00 | 2019-10-11 12:00 | 76 | 2019-10-09 13:00 | 2019-10-11 12:00 | 2d | 5.12d | 0d |
| 78 | 3.3.11 | JT Administrative Offices Complete | milestone | 0d | 2019-10-11 12:00 | 2019-10-11 12:00 | 77 | 2019-10-11 12:00 | 2019-10-11 12:00 | 0d | 5.12d | 0d |
| 79 | 3.3.12 | JT Offices Refurbishing Complete | milestone | 0d | 2019-10-11 12:00 | 2019-10-11 12:00 | 54, 66, 78 | 2019-10-11 12:00 | 2019-10-11 12:00 | 0d | 5.12d | 2.5d |

| ID | WBS | Task | Type | Duration | Start | Finish | Predecessors | Baseline start | Baseline finish | Baseline duration | Total slack | Free slack | Constraint |
| --- | --- | --- | --- | --- | --- | --- | --- | --- | --- | --- | --- | --- | --- |
| 80 | 4 | **Moving** |  | 32.25d | 2019-10-16 08:00 | 2019-11-29 10:00 |  | 2019-10-16 08:00 | 2019-11-29 10:00 | 32.25d | 2.62d |  |  |
| 81 | 4.1 | **Packing** |  | 25.25d | 2019-10-16 08:00 | 2019-11-20 10:00 |  | 2019-10-16 08:00 | 2019-11-20 10:00 | 25.25d | 2.62d |  |  |
| 82 | 4.1.1 | Distribute Boxes to Employees |  | 3d | 2019-10-16 08:00 | 2019-10-18 17:00 | 79 | 2019-10-16 08:00 | 2019-10-18 17:00 | 3d | 2.62d | 0d | start no earlier than 2019-10-16 08:00 |
| 83 | 4.1.2 | Communicate Timetable and Packing Requirements to Employees |  | 1d | 2019-10-21 08:00 | 2019-10-21 17:00 | 82 | 2019-10-21 08:00 | 2019-10-21 17:00 | 1d | 2.62d | 0d |  |
| 84 | 4.1.3 | Tag Furniture and Equipment to Identify New Area Staging |  | 2w | 2019-10-22 08:00 | 2019-11-04 17:00 | 83 | 2019-10-22 08:00 | 2019-11-04 17:00 | 2w | 2.62d | 0d |  |
| 85 | 4.1.4 | Tag Computer Equipment to Identify New Are Staging |  | 2w | 2019-11-05 08:00 | 2019-11-18 17:00 | 84 | 2019-11-05 08:00 | 2019-11-18 17:00 | 2w | 2.62d | 0d |  |
| 86 | 4.1.5 | Packing Complete | milestone | 0d | 2019-11-18 17:00 | 2019-11-18 17:00 | 85 | 2019-11-18 17:00 | 2019-11-18 17:00 | 0d | 2.62d | 0d |  |
| 87 | 4.1.6 | **Final Moving Preperations** |  | 1.25d | 2019-11-19 08:00 | 2019-11-20 10:00 |  | 2019-11-19 08:00 | 2019-11-20 10:00 | 1.25d | 2.62d |  |  |
| 88 | 4.1.6.1 | Communicate Rotation Schedule to Insure Continous Operations |  | 3h | 2019-11-19 08:00 | 2019-11-19 11:00 | 86 | 2019-11-19 08:00 | 2019-11-19 11:00 | 3h | 2.62d | 0d |  |
| 89 | 4.1.6.2 | Walk-through to Double Chjeck Tagging of All Furniture and Equipment |  | 2h | 2019-11-19 11:00 | 2019-11-19 14:00 | 88 | 2019-11-19 11:00 | 2019-11-19 14:00 | 2h | 2.62d | 0d |  |
| 90 | 4.1.6.3 | Review Move Schedule with Team Leaders |  | 3h | 2019-11-19 14:00 | 2019-11-19 17:00 | 89 | 2019-11-19 14:00 | 2019-11-19 17:00 | 3h | 2.62d | 0d |  |
| 91 | 4.1.6.4 | Review Move Schedule with Movers |  | 2h | 2019-11-20 08:00 | 2019-11-20 10:00 | 90 | 2019-11-20 08:00 | 2019-11-20 10:00 | 2h | 2.62d | 0d |  |
| 92 | 4.1.6.5 | Final Moving Preperations Complete | milestone | 0d | 2019-11-20 10:00 | 2019-11-20 10:00 | 91 | 2019-11-20 10:00 | 2019-11-20 10:00 | 0d | 2.62d | 0d |  |
| 93 | 4.2 | **Move Furniture and Equipment** |  | 7d | 2019-11-20 10:00 | 2019-11-29 10:00 |  | 2019-11-20 10:00 | 2019-11-29 10:00 | 7d | 2.62d |  |  |
| 94 | 4.2.1 | Move JT Administrative Offices |  | 2d | 2019-11-20 10:00 | 2019-11-22 10:00 | 92 | 2019-11-20 10:00 | 2019-11-22 10:00 | 2d | 2.62d | 0d |  |
| 95 | 4.2.2 | Move First Wave JT Call Center |  | 1d | 2019-11-22 10:00 | 2019-11-25 10:00 | 94 | 2019-11-22 10:00 | 2019-11-25 10:00 | 1d | 2.62d | 0d |  |
| 96 | 4.2.3 | Move First Wave JT Internet Sales Center |  | 1d | 2019-11-25 10:00 | 2019-11-26 10:00 | 95 | 2019-11-25 10:00 | 2019-11-26 10:00 | 1d | 2.62d | 0d |  |
| 97 | 4.2.4 | Setup New JT Call Center for Operations |  | 0.5d | 2019-11-26 10:00 | 2019-11-26 15:00 | 96 | 2019-11-26 10:00 | 2019-11-26 15:00 | 0.5d | 2.62d | 0d |  |
| 98 | 4.2.5 | Setup New JT Internet Sales Center for Operations |  | 0.5d | 2019-11-26 15:00 | 2019-11-27 10:00 | 97 | 2019-11-26 15:00 | 2019-11-27 10:00 | 0.5d | 2.62d | 0d |  |
| 99 | 4.2.6 | New JT Call Center Operational | milestone | 0d | 2019-11-27 10:00 | 2019-11-27 10:00 | 98 | 2019-11-27 10:00 | 2019-11-27 10:00 | 0d | 2.62d | 0d |  |
| 100 | 4.2.7 | New JT Internet Sales Center Operational | milestone | 0d | 2019-11-27 10:00 | 2019-11-27 10:00 | 99 | 2019-11-27 10:00 | 2019-11-27 10:00 | 0d | 2.62d | 0d |  |
| 101 | 4.2.8 | Move Final Group JT Call Center |  | 1d | 2019-11-27 10:00 | 2019-11-28 10:00 | 100 | 2019-11-27 10:00 | 2019-11-28 10:00 | 1d | 2.62d | 0d |  |
| 102 | 4.2.9 | Move Final Group JT Internet Sales Center |  | 1d | 2019-11-28 10:00 | 2019-11-29 10:00 | 101 | 2019-11-28 10:00 | 2019-11-29 10:00 | 1d | 2.62d | 0d |  |
| 103 | 4.2.10 | Move Furniture and Equipment Complete | milestone | 0d | 2019-11-29 10:00 | 2019-11-29 10:00 | 102 | 2019-11-29 10:00 | 2019-11-29 10:00 | 0d | 2.62d | 0d |  |
| 104 | 4.3 | Move Complete | milestone | 0d | 2019-11-29 10:00 | 2019-11-29 10:00 | 103 | 2019-11-29 10:00 | 2019-11-29 10:00 | 0d | 2.62d | 0d |  |

| ID | WBS | Task | Type | Duration | Start | Finish | Predecessors | Baseline start | Baseline finish | Baseline duration | Total slack | Free slack | Constraint |
| --- | --- | --- | --- | --- | --- | --- | --- | --- | --- | --- | --- | --- | --- |
| 105 | 5 | **JT Corporate Move Closeout** |  | 2.25d | 2019-11-29 10:00 | 2019-12-03 12:00 |  | 2019-11-29 10:00 | 2019-12-03 12:00 | 2.25d | 2.62d |  |  |
| 106 | 5.1 | Unpacking all areas |  | 2d | 2019-11-29 10:00 | 2019-12-03 10:00 | 104 | 2019-11-29 10:00 | 2019-12-03 10:00 | 2d | 2.62d | 0d |  |
| 107 | 5.2 | Company-Wide Meeting |  | 2h | 2019-12-03 10:00 | 2019-12-03 12:00 | 106 | 2019-12-03 10:00 | 2019-12-03 12:00 | 2h | 2.62d | 0d |  |
| 108 | 5.3 | Move Evaluation |  | 0.5d | 2019-12-02 15:00 | 2019-12-03 10:00 | 107SF | 2019-12-02 15:00 | 2019-12-03 10:00 | 0.5d | 2.62d | 0d |  |
| 109 | 5.4 | Pay Movers |  | 1h | 2019-12-03 10:00 | 2019-12-03 11:00 | 108 | 2019-12-03 10:00 | 2019-12-03 11:00 | 1h | 2.62d | 0d |  |
| 110 | 5.5 | JT Corporate Move Closeout Complete | milestone | 0d | 2019-12-03 11:00 | 2019-12-03 11:00 | 109 | 2019-12-03 11:00 | 2019-12-03 11:00 | 0d | 2.62d | 0d |  |
| 111 | 6 | JT Corporate Move Complete | milestone | 0d | 2019-12-03 11:00 | 2019-12-03 11:00 | 110 | 2019-12-03 11:00 | 2019-12-03 11:00 | 0d | 2.62d |  | finish no later than 2019-12-05 17:00 |
