# JT Corporate Move

Schedule from MS Project, 2019-07-01 to 2019-12-03.
Refurbish New Offices and Move
Java Tucana

## Calendars

- Java Tucana Admin: Mon-Fri 08:00-12:00, 13:00-17:00; Sat-Sun off. Exceptions (off unless hours are given): 2017-07-04 to 2022-07-04 (Jul 4th Holiday, recurring).

## Resources

| Resource | Group | Rate |
| --- | --- | --- |
| Charlie Mejia | Admin | 27.4 |
| Ann Chung | IT | 26.92 |
| Ron Sova | Marketing | 25 |
| Rick Herrera | Projects | 25.48 |
| Dorothy Windle | Call Center | 32 |
| Call Center Day Analysts | Call Center | 15 |
| Jaun Silva | Internet Sales Center | 32 |
| Internet Sales Day Operators | Internet Sales Center | 15 |
| Maintenance | Maintenance | 40 |
| Network Heroes | Contract |  |
| Extreme Designs | Contract |  |

## Schedule

| ID | WBS | Task | Type | Duration | Start | Finish | Predecessors | Baseline start | Baseline finish | Baseline duration | Total slack | Free slack | Constraint | Work |
| --- | --- | --- | --- | --- | --- | --- | --- | --- | --- | --- | --- | --- | --- | --- |
| 1 | 1 | **JT Move Status Meetings** |  | 10.12d | 2019-07-05 | 2019-07-19 |  | 2019-07-05 | 2019-07-19 | 10.12d | 97.38d |  |  |  |
| 2 | 1.1 | JT Move Status Meetings 1 |  | 1h | 2019-07-05 | 2019-07-05 |  | 2019-07-05 | 2019-07-05 | 1h | 107.38d |  | start no earlier than 2019-07-05 |  |
| 3 | 1.2 | JT Move Status Meetings 2 |  | 1h | 2019-07-12 | 2019-07-12 |  | 2019-07-12 | 2019-07-12 | 1h | 102.38d |  | start no earlier than 2019-07-12 |  |
| 4 | 1.3 | JT Move Status Meetings 3 |  | 1h | 2019-07-19 | 2019-07-19 |  | 2019-07-19 | 2019-07-19 | 1h | 97.38d |  | start no earlier than 2019-07-19 |  |
| 5 | 2 | **Planning the Move** |  | 49.38d | 2019-07-01 | 2019-09-09 |  | 2019-07-01 | 2019-09-09 | 49.38d | 2.62d |  |  |  |
| 6 | 2.1 | Identify Move Team Members |  | 2d | 2019-07-01 | 2019-07-02 |  | 2019-07-01 | 2019-07-02 | 2d | 2.62d | 0d |  |  |
| 7 | 2.2 | Plan Infastructure Upgrades |  | 2w | 2019-07-03 | 2019-07-17 | 6 | 2019-07-03 | 2019-07-17 | 2w | 2.62d | 0d |  |  |
| 8 | 2.3 | Plan IT Move |  | 2w | 2019-07-18 | 2019-07-31 | 7 | 2019-07-18 | 2019-07-31 | 2w | 2.62d | 0d |  |  |
| 9 | 2.4 | Plan Physical Move |  | 2w | 2019-07-22 | 2019-08-05 | 8FS-7.5% | 2019-07-22 | 2019-08-05 | 2w | 2.62d | 0d |  |  |
| 10 | 2.5 | Plan for Continous Operations During the Move |  | 4d | 2019-08-05 | 2019-08-09 | 9 | 2019-08-05 | 2019-08-09 | 4d | 2.62d | 0d |  |  |
| 11 | 2.6 | Obtain Estimates from Moving Services |  | 1w | 2019-08-09 | 2019-08-16 | 10 | 2019-08-09 | 2019-08-16 | 1w | 2.62d | 0d |  |  |
| 12 | 2.7 | Interview and Select Movers |  | 1w | 2019-08-16 | 2019-08-23 | 11 | 2019-08-16 | 2019-08-23 | 1w | 2.62d | 0d |  |  |
| 13 | 2.8 | Obtain Estimates from IT Installation Companies |  | 1w | 2019-08-16 | 2019-08-23 | 11 | 2019-08-16 | 2019-08-23 | 1w | 2.62d | 0d |  |  |
| 14 | 2.9 | Interview and Select IT Installation Company |  | 1w | 2019-08-23 | 2019-08-30 | 13, 12 | 2019-08-23 | 2019-08-30 | 1w | 2.62d | 0d |  |  |
| 15 | 2.10 | Order Boxes and Materials needed for the Move |  | 3h | 2019-08-30 | 2019-08-30 | 14 | 2019-08-30 | 2019-08-30 | 3h | 2.62d | 0d |  |  |
| 16 | 2.11 | Planning the Move Complete | milestone | 0d | 2019-08-30 | 2019-08-30 | 15 | 2019-08-30 | 2019-08-30 | 0d | 2.62d | 0d |  |  |
| 17 | 2.12 | **Communications** |  | 5.5d | 2019-08-30 | 2019-09-09 |  | 2019-08-30 | 2019-09-09 | 5.5d | 2.62d |  |  |  |
| 18 | 2.12.1 | Communicate Move Plan to Employees |  | 3d | 2019-08-30 | 2019-09-04 | 16 | 2019-08-30 | 2019-09-04 | 3d | 2.62d | 0d |  |  |
| 19 | 2.12.2 | Gather Feedback From Employees |  | 2d | 2019-09-04 | 2019-09-06 | 18 | 2019-09-04 | 2019-09-06 | 2d | 2.62d | 0d |  |  |
| 20 | 2.12.3 | Communicate Move Information to Suppliers |  | 2h | 2019-09-06 | 2019-09-09 | 19 | 2019-09-06 | 2019-09-09 | 2h | 2.62d | 0d |  |  |
| 21 | 2.12.4 | Communicate Move Information to Customers |  | 2h | 2019-09-09 | 2019-09-09 | 20 | 2019-09-09 | 2019-09-09 | 2h | 2.62d | 0d |  |  |
| 22 | 2.12.5 | Communications Complete | milestone | 0d | 2019-09-09 | 2019-09-09 | 21 | 2019-09-09 | 2019-09-09 | 0d | 2.62d | 0d |  |  |
| 23 | 3 | **JT Corporate Center Preparation** |  | 24d | 2019-09-09 | 2019-10-11 |  | 2019-09-09 | 2019-10-11 | 24d | 2.62d |  |  | 16h |
| 24 | 3.1 | **JT Call Center Refurbishing New Location** |  | 22d | 2019-09-09 | 2019-10-09 |  | 2019-09-09 | 2019-10-09 | 22d | 2.62d |  |  | 16h |
| 25 | 3.1.1 | Install Network Cables |  | 3d | 2019-09-09 | 2019-09-12 | 22 | 2019-09-09 | 2019-09-12 | 3d | 2.62d | 0d |  |  |
| 26 | 3.1.2 | Install TeleCommunication Lines |  | 1w | 2019-09-12 | 2019-09-19 | 25 | 2019-09-12 | 2019-09-19 | 1w | 4.62d | 0d |  |  |
| 27 | 3.1.3 | Paint the walls |  | 2d | 2019-09-19 | 2019-09-23 | 26 | 2019-09-19 | 2019-09-23 | 2d | 4.62d | 0d |  | 16h |
| 28 | 3.1.4 | Lay Carpet |  | 2d | 2019-09-24 | 2019-09-26 | 27FS+1ed | 2019-09-24 | 2019-09-26 | 2d | 4.62d | 0d |  |  |
| 29 | 3.1.5 | Install Partitions |  | 1d | 2019-09-26 | 2019-09-27 | 28 | 2019-09-26 | 2019-09-27 | 1d | 4.62d | 0d |  |  |
| 30 | 3.1.6 | Prepare Offices |  | 5d | 2019-09-27 | 2019-10-04 | 29 | 2019-09-27 | 2019-10-04 | 5d | 4.62d | 0d |  |  |
| 31 | 3.1.7 | Assemble Furniture |  | 2d | 2019-10-04 | 2019-10-08 | 30 | 2019-10-04 | 2019-10-08 | 2d | 4.62d | 0d |  |  |
| 32 | 3.1.8 | Hook up Computers |  | 1d | 2019-10-08 | 2019-10-09 | 31 | 2019-10-08 | 2019-10-09 | 1d | 4.62d | 0d |  |  |
| 33 | 3.1.9 | Hook up Phones |  | 1d | 2019-10-08 | 2019-10-09 | 32FF | 2019-10-08 | 2019-10-09 | 1d | 4.62d | 0d |  |  |
| 34 | 3.1.10 | JT Call Center Complete | milestone | 0d | 2019-10-09 | 2019-10-09 | 33 | 2019-10-09 | 2019-10-09 | 0d | 4.62d | 2d |  |  |

| ID | WBS | Task | Type | Duration | Start | Finish | Predecessors | Baseline start | Baseline finish | Baseline duration | Total slack | Free slack |
| --- | --- | --- | --- | --- | --- | --- | --- | --- | --- | --- | --- | --- |
| 35 | 3.2 | **JT Internet Sales Center Refurbishing New Location** |  | 24d | 2019-09-09 | 2019-10-11 |  | 2019-09-09 | 2019-10-11 | 24d | 2.62d |  |
| 36 | 3.2.1 | Install Network Cables |  | 3d | 2019-09-09 | 2019-09-12 | 25SS | 2019-09-09 | 2019-09-12 | 3d | 2.62d | 0d |
| 37 | 3.2.2 | Install TeleCommunication Lines |  | 1w | 2019-09-12 | 2019-09-19 | 36 | 2019-09-12 | 2019-09-19 | 1w | 2.62d | 0d |
| 38 | 3.2.3 | Paint the walls |  | 2d | 2019-09-19 | 2019-09-23 | 37 | 2019-09-19 | 2019-09-23 | 2d | 2.62d | 0d |
| 39 | 3.2.4 | Lay Carpet |  | 2d | 2019-09-24 | 2019-09-26 | 38FS+1ed | 2019-09-24 | 2019-09-26 | 2d | 2.62d | 0d |
| 40 | 3.2.5 | Install Partitions |  | 1d | 2019-09-26 | 2019-09-27 | 39 | 2019-09-26 | 2019-09-27 | 1d | 2.62d | 0d |
| 41 | 3.2.6 | Prepare Offices |  | 5d | 2019-09-27 | 2019-10-04 | 40 | 2019-09-27 | 2019-10-04 | 5d | 2.62d | 0d |
| 42 | 3.2.7 | Assemble Furniture |  | 2d | 2019-10-04 | 2019-10-08 | 41 | 2019-10-04 | 2019-10-08 | 2d | 2.62d | 0d |
| 43 | 3.2.8 | Hook up Computers |  | 1d | 2019-10-08 | 2019-10-09 | 42 | 2019-10-08 | 2019-10-09 | 1d | 2.62d | 0d |
| 44 | 3.2.9 | Hook up Phones |  | 1d | 2019-10-08 | 2019-10-09 | 43FF | 2019-10-08 | 2019-10-09 | 1d | 2.62d | 0d |
| 45 | 3.2.10 | Move in Belongings |  | 2d | 2019-10-09 | 2019-10-11 | 44 | 2019-10-09 | 2019-10-11 | 2d | 2.62d | 0d |
| 46 | 3.2.11 | JT Internet Sales Center Complete | milestone | 0d | 2019-10-11 | 2019-10-11 | 45 | 2019-10-11 | 2019-10-11 | 0d | 2.62d | 0d |
| 47 | 3.3 | **JT Administration Offices Refurbishing New Location** |  | 24d | 2019-09-09 | 2019-10-11 |  | 2019-09-09 | 2019-10-11 | 24d | 2.62d |  |
| 48 | 3.3.1 | Install Network Cables |  | 3d | 2019-09-09 | 2019-09-12 | 36SS | 2019-09-09 | 2019-09-12 | 3d | 2.62d | 0d |
| 49 | 3.3.2 | Install TeleCommunication Lines |  | 1w | 2019-09-12 | 2019-09-19 | 48 | 2019-09-12 | 2019-09-19 | 1w | 2.62d | 0d |
| 50 | 3.3.3 | Paint the walls |  | 2d | 2019-09-19 | 2019-09-23 | 49 | 2019-09-19 | 2019-09-23 | 2d | 2.62d | 0d |
| 51 | 3.3.4 | Lay Carpet |  | 2d | 2019-09-24 | 2019-09-26 | 50FS+1ed | 2019-09-24 | 2019-09-26 | 2d | 2.62d | 0d |
| 52 | 3.3.5 | Install Partitions |  | 1d | 2019-09-26 | 2019-09-27 | 51 | 2019-09-26 | 2019-09-27 | 1d | 2.62d | 0d |
| 53 | 3.3.6 | Prepare Offices |  | 5d | 2019-09-27 | 2019-10-04 | 52 | 2019-09-27 | 2019-10-04 | 5d | 2.62d | 0d |
| 54 | 3.3.7 | Assemble Furniture |  | 2d | 2019-10-04 | 2019-10-08 | 53 | 2019-10-04 | 2019-10-08 | 2d | 2.62d | 0d |
| 55 | 3.3.8 | Hook up Computers |  | 1d | 2019-10-08 | 2019-10-09 | 54 | 2019-10-08 | 2019-10-09 | 1d | 2.62d | 0d |
| 56 | 3.3.9 | Hook up Phones |  | 1d | 2019-10-08 | 2019-10-09 | 55FF | 2019-10-08 | 2019-10-09 | 1d | 2.62d | 0d |
| 57 | 3.3.10 | Move in Belongings |  | 2d | 2019-10-09 | 2019-10-11 | 56 | 2019-10-09 | 2019-10-11 | 2d | 2.62d | 0d |
| 58 | 3.3.11 | JT Administrative Offices Complete | milestone | 0d | 2019-10-11 | 2019-10-11 | 57 | 2019-10-11 | 2019-10-11 | 0d | 2.62d | 0d |
| 59 | 3.3.12 | JT Offices Refurbishing Complete | milestone | 0d | 2019-10-11 | 2019-10-11 | 34, 46, 58 | 2019-10-11 | 2019-10-11 | 0d | 2.62d |  |

| ID | WBS | Task | Type | Duration | Start | Finish | Predecessors | Baseline start | Baseline finish | Baseline duration | Total slack | Constraint |
| --- | --- | --- | --- | --- | --- | --- | --- | --- | --- | --- | --- | --- |
| 60 | 4 | **Moving** |  | 32.25d | 2019-10-16 | 2019-11-29 |  | 2019-10-16 | 2019-11-29 | 32.25d | 0d |  |
| 61 | 4.1 | **Packing** |  | 25.25d | 2019-10-16 | 2019-11-20 |  | 2019-10-16 | 2019-11-20 | 25.25d | 0d |  |
| 62 | 4.1.1 | Distribute Boxes to Employees |  | 3d | 2019-10-16 | 2019-10-18 | 59 | 2019-10-16 | 2019-10-18 | 3d | 0d | start no earlier than 2019-10-16 |
| 63 | 4.1.2 | Communicate Timetable and Packing Requirements to Employees |  | 1d | 2019-10-21 | 2019-10-21 | 62 | 2019-10-21 | 2019-10-21 | 1d | 0d |  |
| 64 | 4.1.3 | Tag Furniture and Equipment to Identify New Area Staging |  | 2w | 2019-10-22 | 2019-11-04 | 63 | 2019-10-22 | 2019-11-04 | 2w | 0d |  |
| 65 | 4.1.4 | Tag Computer Equipment to Identify New Are Staging |  | 2w | 2019-11-05 | 2019-11-18 | 64 | 2019-11-05 | 2019-11-18 | 2w | 0d |  |
| 66 | 4.1.5 | Packing Complete | milestone | 0d | 2019-11-18 | 2019-11-18 | 65 | 2019-11-18 | 2019-11-18 | 0d | 0d |  |
| 67 | 4.1.6 | **Final Moving Preperations** |  | 1.25d | 2019-11-19 | 2019-11-20 |  | 2019-11-19 | 2019-11-20 | 1.25d | 0d |  |
| 68 | 4.1.6.1 | Communicate Rotation Schedule to Insure Continous Operations |  | 3h | 2019-11-19 | 2019-11-19 | 66 | 2019-11-19 | 2019-11-19 | 3h | 0d |  |
| 69 | 4.1.6.2 | Walk-through to Double Chjeck Tagging of All Furniture and Equipment |  | 2h | 2019-11-19 | 2019-11-19 | 68 | 2019-11-19 | 2019-11-19 | 2h | 0d |  |
| 70 | 4.1.6.3 | Review Move Schedule with Team Leaders |  | 3h | 2019-11-19 | 2019-11-19 | 69 | 2019-11-19 | 2019-11-19 | 3h | 0d |  |
| 71 | 4.1.6.4 | Review Move Schedule with Movers |  | 2h | 2019-11-20 | 2019-11-20 | 70 | 2019-11-20 | 2019-11-20 | 2h | 0d |  |
| 72 | 4.1.6.5 | Final Moving Preperations Complete | milestone | 0d | 2019-11-20 | 2019-11-20 | 71 | 2019-11-20 | 2019-11-20 | 0d | 0d |  |
| 73 | 4.2 | **Move Furniture and Equipment** |  | 7d | 2019-11-20 | 2019-11-29 |  | 2019-11-20 | 2019-11-29 | 7d | 0d |  |
| 74 | 4.2.1 | Move JT Administrative Offices |  | 2d | 2019-11-20 | 2019-11-22 | 72 | 2019-11-20 | 2019-11-22 | 2d | 0d |  |
| 75 | 4.2.2 | Move First Wave JT Call Center |  | 1d | 2019-11-22 | 2019-11-25 | 74 | 2019-11-22 | 2019-11-25 | 1d | 0d |  |
| 76 | 4.2.3 | Move First Wave JT Internet Sales Center |  | 1d | 2019-11-25 | 2019-11-26 | 75 | 2019-11-25 | 2019-11-26 | 1d | 0d |  |
| 77 | 4.2.4 | Setup New JT Call Center for Operations |  | 0.5d | 2019-11-26 | 2019-11-26 | 76 | 2019-11-26 | 2019-11-26 | 0.5d | 0d |  |
| 78 | 4.2.5 | Setup New JT Internet Sales Center for Operations |  | 0.5d | 2019-11-26 | 2019-11-27 | 77 | 2019-11-26 | 2019-11-27 | 0.5d | 0d |  |
| 79 | 4.2.6 | New JT Call Center Operational | milestone | 0d | 2019-11-27 | 2019-11-27 | 78 | 2019-11-27 | 2019-11-27 | 0d | 0d |  |
| 80 | 4.2.7 | New JT Internet Sales Center Operational | milestone | 0d | 2019-11-27 | 2019-11-27 | 79 | 2019-11-27 | 2019-11-27 | 0d | 0d |  |
| 81 | 4.2.8 | Move Final Group JT Call Center |  | 1d | 2019-11-27 | 2019-11-28 | 80 | 2019-11-27 | 2019-11-28 | 1d | 0d |  |
| 82 | 4.2.9 | Move Final Group JT Internet Sales Center |  | 1d | 2019-11-28 | 2019-11-29 | 81 | 2019-11-28 | 2019-11-29 | 1d | 0d |  |
| 83 | 4.2.10 | Move Furniture and Equipment Complete | milestone | 0d | 2019-11-29 | 2019-11-29 | 82 | 2019-11-29 | 2019-11-29 | 0d | 0d |  |
| 84 | 4.3 | Move Complete | milestone | 0d | 2019-11-29 | 2019-11-29 | 83 | 2019-11-29 | 2019-11-29 | 0d | 0d |  |

| ID | WBS | Task | Type | Duration | Start | Finish | Predecessors | Baseline start | Baseline finish | Baseline duration | Total slack | Free slack | Constraint |
| --- | --- | --- | --- | --- | --- | --- | --- | --- | --- | --- | --- | --- | --- |
| 85 | 5 | **JT Corporate Move Closeout** |  | 2.25d | 2019-11-29 | 2019-12-03 |  | 2019-11-29 | 2019-12-03 | 2.25d | 0d |  |  |
| 86 | 5.1 | Unpacking all areas |  | 2d | 2019-11-29 | 2019-12-03 | 84 | 2019-11-29 | 2019-12-03 | 2d | 0d |  |  |
| 87 | 5.2 | Company-Wide Meeting |  | 2h | 2019-12-03 | 2019-12-03 | 86 | 2019-12-03 | 2019-12-03 | 2h | 0d |  |  |
| 88 | 5.3 | Move Evaluation |  | 0.5d | 2019-12-02 | 2019-12-03 | 87SF | 2019-12-02 | 2019-12-03 | 0.5d | 0.12d | 0d |  |
| 89 | 5.4 | Pay Movers |  | 1h | 2019-12-03 | 2019-12-03 | 88 | 2019-12-03 | 2019-12-03 | 1h | 0.12d | 0d |  |
| 90 | 5.5 | JT Corporate Move Closeout Complete | milestone | 0d | 2019-12-03 | 2019-12-03 | 89 | 2019-12-03 | 2019-12-03 | 0d | 0.12d | 0d |  |
| 91 | 6 | JT Corporate Move Complete | milestone | 0d | 2019-12-03 | 2019-12-03 | 90 | 2019-12-03 | 2019-12-03 | 0d | 0.12d |  | finish no later than 2019-12-05 |
