# Asbestos Abatement Encapsulation JT Processing Facilities

Schedule from MS Project, 2019-11-01 to 2020-07-23, costs in $.
Java Tucana

## Calendars

- Java Tucana Admin: Mon-Fri 08:00-12:00, 13:00-17:00; Sat-Sun off. Exceptions (off unless hours are given): 2017-07-04 to 2022-07-04 (Jul 4th Holiday, recurring).

## Resources

| Resource | Group | Unit | Rate |
| --- | --- | --- | --- |
| Charlie Mejia | Admin |  | 27.4 |
| Ann Chung | IT |  | 26.92 |
| Ron Sova | Marketing |  | 25 |
| Rick Herrera | Projects |  | 25.48 |
| Dorothy Windle | Call Center |  | 32 |
| Call Center Day Analysts | Call Center |  | 15 |
| Juan Silva | Internet Sales Center |  | 32 |
| Internet Sales Day Operators | Internet Sales Center |  | 15 |
| Maintenance | Maintenance |  | 40 |
| Network Heroes | Contract |  |  |
| Extreme Designs | Contract |  |  |
| Environmental Wizards | Contract |  |  |
| Asbestos Abatement Budget Cost | Cost |  |  |
| Asbestos Abatement Budget Work | Cost |  |  |
| Asbestos Abatement Plastic Sheeting | Cost | Per Yard |  |

## Schedule

| ID | WBS | Task | Type | Duration | Start | Finish | Predecessors | Total slack | Free slack | Deadline | Resources | Work | Cost | Text1 | Text2 |
| --- | --- | --- | --- | --- | --- | --- | --- | --- | --- | --- | --- | --- | --- | --- | --- |
| 1 | 1 | Notice to Proceed from JT CEO, JT CFO |  | 5d | 2019-11-01 | 2019-11-07 |  | 179d | 0d |  | Charlie Mejia | 40h | 1,096.15 | Z1010.01 | 01.01.01 |
| 2 | 2 | Project Award to High (best) Bid Contractor | milestone | 0d | 2019-11-07 | 2019-11-07 | 1 | 179d | 0d |  | Charlie Mejia |  |  | Z1010.01 | 01.01.01 |
| 3 | 3 | **General Requirements (Start-up)** |  | 63d | 2019-11-01 | 2020-01-28 |  | 0d |  |  |  | 1264h | 43,187.69 |  |  |
| 4 | 3.1 | General Requirements (Start-up) Insurance & Bonds |  | 1d | 2019-11-08 | 2019-11-08 | 2 | 179d | 0d |  | Ann Chung; Charlie Mejia | 16h | 434.62 | Z1050.02, .03 | 01.01.01 |
| 5 | 2.1 | Post Award Site Survey |  | 5d | 2019-11-11 | 2019-11-15 | 4 | 179d | 19d |  | Dorothy Windle; Charlie Mejia | 80h | 6,376.15 |  |  |
| 6 | 2.2 | DRAFT Work Plan |  | 30d | 2019-11-01 | 2019-12-12 | 5FF | 160d |  |  | Juan Silva; Dorothy Windle | 480h | 15,360 |  |  |
| 7 | 2.4 | EPA Review |  | 14d | 2019-11-01 | 2019-11-20 |  | 0d |  |  | Rick Herrera | 112h | 2,853.85 |  |  |
| 8 | 2.5 | Finalize Final Work Plan |  | 14d | 2019-11-18 | 2019-12-05 | 7FS-3d | 0d |  |  | Charlie Mejia; Rick Herrera | 224h | 5,923.08 |  |  |
| 9 | 2.6 | Submit Final Work Plan |  | 1d | 2019-12-06 | 2019-12-06 | 8 | 0d |  | 2019-12-06 | Ron Sova | 8h | 200 |  |  |
| 10 | 2.7 | EPA Approval |  | 10d | 2019-12-09 | 2019-12-20 | 9 | 0d |  |  |  |  |  |  |  |
| 11 | 2.12 | Local Government Review/Approval of Local Submittals |  | 10d | 2019-12-23 | 2020-01-03 | 10 | 0d |  |  | Ron Sova; Charlie Mejia | 160h | 4,192.31 |  |  |
| 12 | 3 | Procure/Fabrication/Transportation/Arrival of Local Equipment |  | 10d | 2020-01-06 | 2020-01-17 | 11 | 0d |  |  | Maintenance | 80h | 3,200 |  |  |
| 13 | 3.10 | General Requirements (Start-up) Administration Complete | milestone | 0d | 2020-01-17 | 2020-01-17 | 12 | 0d |  |  |  |  |  |  | 01.02.02 |
| 14 | 3.11 | **General Requirements (Start-up) Temporary Facilities & Mobilization** |  | 7d | 2020-01-20 | 2020-01-28 |  | 0d |  |  |  | 104h | 4,647.69 |  | 01.01.02 |
| 15 | 3.11.1 | Temporary Staging Facilities/Laydown Yard |  | 4d | 2020-01-20 | 2020-01-23 | 13 | 0d |  |  | Environmental Wizards | 32h | 2,000 | Z1030.02 | 01.01.02 |
| 16 | 3.11.2 | Temporary Site Access & Parking |  | 2d | 2020-01-20 | 2020-01-21 | 15SS | 0d |  |  | Rick Herrera | 16h | 407.69 | Z1030.04 | 01.01.02 |
| 17 | 3.11.3 | General Requirements (Start-up) Permits |  | 7d | 2020-01-20 | 2020-01-28 | 16SS | 0d |  |  | Maintenance | 56h | 2,240 | Z1050.01 | 01.01.02 |
| 18 | 3.11.4 | General Requirements (Start-up) Temporary Facilities & Mobilization Complete | milestone | 0d | 2020-01-28 | 2020-01-28 | 17 | 0d |  |  |  |  |  |  | 01.01.02 |
| 19 | 3.12 | General Requirements (Start-up) Complete | milestone | 0d | 2020-01-28 | 2020-01-28 | 18 | 0d |  |  |  |  |  |  |  |
| 20 | 4 | Field Project Management & Supervision |  | 124d | 2020-01-24 | 2020-07-15 | 15 | 6d |  |  |  |  |  | Z1010.02 | 01.01.03 |
| 21 | 5 | **Field Work- Asbestos Inspection, Abatement and Encapsulation** |  | 85d | 2020-01-29 | 2020-05-26 |  | 0d |  |  |  | 680h | 27,000 |  |  |
| 22 | 5.1 | Abate and Encapsulate Processing Facility 1 |  | 30d | 2020-01-29 | 2020-03-10 | 19 | 0d |  |  | Environmental Wizards | 240h | 27,000 |  |  |
| 23 | 5.2 | Mobilization to Processing Facility 2 |  | 5d | 2020-03-11 | 2020-03-17 | 22 | 0d |  |  | Environmental Wizards | 40h |  |  |  |
| 24 | 5.3 | Abate and Encapsulate Processing Facility 2 |  | 50d | 2020-03-18 | 2020-05-26 | 23 | 0d |  |  | Environmental Wizards | 400h |  |  |  |
| 25 | 5.4 | Field Work- Asbestos Inspection, Abatement and Encapsulation Complete | milestone | 0d | 2020-05-26 | 2020-05-26 | 24 | 0d |  |  |  |  |  |  |  |

| ID | WBS | Task | Type | Duration | Start | Finish | Predecessors | Total slack | Resources | Work | Cost |
| --- | --- | --- | --- | --- | --- | --- | --- | --- | --- | --- | --- |
| 26 | 6 | **Project Closeout** |  | 42d | 2020-05-27 | 2020-07-23 |  | 0d |  | 336h | 16,276.92 |
| 27 | 6.1 | Demobilization/Cleanup/Restoration |  | 2d | 2020-05-27 | 2020-05-28 | 25 | 0d | Environmental Wizards | 16h | 6,500 |
| 28 | 6.2 | Post Fieldwork Inspection / Documentation |  | 10d | 2020-05-29 | 2020-06-11 | 27 | 0d | Maintenance | 80h | 3,200 |
| 29 | 6.3 | Final Report |  | 30d | 2020-06-12 | 2020-07-23 | 28 | 0d | Charlie Mejia | 240h | 6,576.92 |
| 30 | 6.4 | Closeout Complete | milestone | 0d | 2020-07-23 | 2020-07-23 | 29 | 0d |  |  |  |
| 31 | 6.5 | Asbestos Abatement Encapsulation JT Processing Facilities Complete | milestone | 0d | 2020-07-23 | 2020-07-23 | 30, 20 | 0d |  |  |  |
