# Asbestos Abatement Encapsulation JT Processing Facilities

Schedule from MS Project, 2019-11-01 to 2020-07-31, status date 2019-12-18, costs in $, A marks actual dates.
Java Tucana

## Calendars

- Java Tucana Admin: Mon-Fri 08:00-12:00, 13:00-17:00; Sat-Sun off. Exceptions (off unless hours are given): 2017-07-04 to 2022-07-04 (Jul 4th Holiday, recurring).

## Resources

| Resource | Group | Unit | Rate |
| --- | --- | --- | --- |
| Charlie Mejia | Admin |  | 27.4 |
| Ann Chung | IT |  | 26.92 |
| Ron Sova | Marketing |  | 25 |
| Rick Herrera | Projects |  | 25.48 |
| Dorothy Windle | Call Center |  | 32 |
| Call Center Day Analysts | Call Center |  | 15 |
| Juan Silva | Internet Sales Center |  | 32 |
| Internet Sales Day Operators | Internet Sales Center |  | 15 |
| Maintenance | Maintenance |  | 40 |
| Network Heroes | Contract |  |  |
| Extreme Designs | Contract |  |  |
| Environmental Wizards | Contract |  |  |
| Asbestos Abatement Budget Cost | Cost |  |  |
| Asbestos Abatement Budget Work | Cost |  |  |
| Asbestos Abatement Plastic Sheeting | Cost | Per Yard |  |

## Schedule

| ID | WBS | Task | Type | Duration | Start | Finish | Predecessors | Complete | Remaining | Baseline start | Baseline finish | Baseline duration | Baseline 1 start | Baseline 1 finish | Total slack | Free slack | Deadline | Resources | Work | Actual work | Cost | Baseline cost | Actual cost | Text1 | Text2 |
| --- | --- | --- | --- | --- | --- | --- | --- | --- | --- | --- | --- | --- | --- | --- | --- | --- | --- | --- | --- | --- | --- | --- | --- | --- | --- |
| 1 | 1 | Notice to Proceed from JT CEO, JT CFO |  | 5d | 2019-11-01 A | 2019-11-07 A |  | 100% |  | 2019-11-01 | 2019-11-07 | 5d | 2018-11-01 | 2018-11-07 |  |  |  | Charlie Mejia | 40h | 40h | 1,096.15 | 1,096.15 | 1,096.15 | Z1010.01 | 01.01.01 |
| 2 | 2 | Project Award to High (best) Bid Contractor | milestone | 0d | 2019-11-08 A | 2019-11-08 A | 1 | 100% |  | 2019-11-08 | 2019-11-08 | 0d | 2018-11-07 | 2018-11-07 |  |  |  | Charlie Mejia |  |  |  |  |  | Z1010.01 | 01.01.01 |
| 3 | 3 | **General Requirements (Start-up)** |  | 69d | 2019-11-01 A | 2020-02-05 |  | 61% | 26.77d | 2019-11-01 | 2020-02-05 | 69d | 2018-11-01 | 2019-01-28 | 127d |  |  |  | 1264h | 904h | 43,187.69 | 43,187.69 | 30,691.69 |  |  |
| 4 | 3.1 | General Requirements (Start-up) Insurance & Bonds |  | 1d | 2019-11-08 A | 2019-11-08 A | 2 | 100% |  | 2019-11-08 | 2019-11-08 | 1d | 2018-11-08 | 2018-11-08 |  |  |  | Ann Chung; Charlie Mejia | 16h | 16h | 434.62 | 434.62 | 434.62 | Z1050.02, .03 | 01.01.01 |
| 5 | 2.1 | Post Award Site Survey |  | 5d | 2019-11-11 A | 2019-11-15 A | 4 | 100% |  | 2019-11-11 | 2019-11-15 | 5d | 2018-11-09 | 2018-11-15 |  |  |  | Dorothy Windle; Charlie Mejia | 80h | 80h | 6,376.15 | 6,376.15 | 6,376.15 |  |  |
| 6 | 2.2 | DRAFT Work Plan |  | 35d | 2019-11-01 A | 2019-12-19 | 5FF | 97% | 1d | 2019-11-01 | 2019-12-19 | 35d | 2018-11-01 | 2018-12-12 | 161d |  |  | Juan Silva; Dorothy Windle | 480h | 472h | 15,360 | 15,360 | 15,104 |  |  |
| 7 | 2.4 | EPA Review |  | 14d | 2019-11-01 A | 2019-11-20 A |  | 100% |  | 2019-11-01 | 2019-11-20 | 14d | 2018-11-01 | 2018-11-20 |  |  |  | Rick Herrera | 112h | 112h | 2,853.85 | 2,853.85 | 2,853.85 |  |  |
| 8 | 2.5 | Finalize Final Work Plan |  | 17d | 2019-11-18 A | 2019-12-10 A | 7FS-3d | 100% |  | 2019-11-18 | 2019-12-10 | 17d | 2018-11-16 | 2018-12-05 |  |  |  | Charlie Mejia; Rick Herrera | 224h | 224h | 5,923.08 | 5,923.08 | 5,923.08 |  |  |
| 9 | 2.6 | Submit Final Work Plan |  | 1d | 2019-12-11 | 2019-12-11 | 8 |  |  | 2019-12-11 | 2019-12-11 | 1d | 2018-12-06 | 2018-12-06 | -3d | 0d | 2019-12-06 | Ron Sova | 8h |  | 200 | 200 |  |  |  |
| 10 | 2.7 | EPA Approval |  | 10d | 2019-12-17 | 2019-12-30 | 9 |  |  | 2019-12-17 | 2019-12-30 | 10d | 2018-12-07 | 2018-12-20 | 0d |  |  |  |  |  |  |  |  |  |  |
| 11 | 2.12 | Local Government Review/Approval of Local Submittals |  | 10d | 2019-12-31 | 2020-01-13 | 10 |  |  | 2019-12-31 | 2020-01-13 | 10d | 2018-12-21 | 2019-01-03 | 0d |  |  | Ron Sova; Charlie Mejia | 160h |  | 4,192.31 | 4,192.31 |  |  |  |
| 12 | 3 | Procure/Fabrication/Transportation/Arrival of Local Equipment |  | 10d | 2020-01-14 | 2020-01-27 | 11 |  |  | 2020-01-14 | 2020-01-27 | 10d | 2019-01-04 | 2019-01-17 | 0d |  |  | Maintenance | 80h |  | 3,200 | 3,200 |  |  |  |
| 13 | 3.10 | General Requirements (Start-up) Administration Complete | milestone | 0d | 2020-01-27 | 2020-01-27 | 12 |  |  | 2020-01-27 | 2020-01-27 | 0d | 2019-01-17 | 2019-01-17 | 0d |  |  |  |  |  |  |  |  |  | 01.02.02 |
| 14 | 3.11 | **General Requirements (Start-up) Temporary Facilities & Mobilization** |  | 7d | 2020-01-28 | 2020-02-05 |  |  |  | 2020-01-28 | 2020-02-05 | 7d | 2019-01-18 | 2019-01-28 | 0d |  |  |  | 104h |  | 4,647.69 | 4,647.69 |  |  | 01.01.02 |
| 15 | 3.11.1 | Temporary Staging Facilities/Laydown Yard |  | 4d | 2020-01-28 | 2020-01-31 | 13 |  |  | 2020-01-28 | 2020-01-31 | 4d | 2019-01-18 | 2019-01-23 | 0d |  |  | Environmental Wizards | 32h |  | 2,000 | 2,000 |  | Z1030.02 | 01.01.02 |
| 16 | 3.11.2 | Temporary Site Access & Parking |  | 2d | 2020-01-28 | 2020-01-29 | 15SS |  |  | 2020-01-28 | 2020-01-29 | 2d | 2019-01-18 | 2019-01-21 | 0d |  |  | Rick Herrera | 16h |  | 407.69 | 407.69 |  | Z1030.04 | 01.01.02 |
| 17 | 3.11.3 | General Requirements (Start-up) Permits |  | 7d | 2020-01-28 | 2020-02-05 | 16SS |  |  | 2020-01-28 | 2020-02-05 | 7d | 2019-01-18 | 2019-01-28 | 0d |  |  | Maintenance | 56h |  | 2,240 | 2,240 |  | Z1050.01 | 01.01.02 |
| 18 | 3.11.4 | General Requirements (Start-up) Temporary Facilities & Mobilization Complete | milestone | 0d | 2020-02-05 | 2020-02-05 | 17 |  |  | 2020-02-05 | 2020-02-05 | 0d | 2019-01-28 | 2019-01-28 | 0d |  |  |  |  |  |  |  |  |  | 01.01.02 |
| 19 | 3.12 | General Requirements (Start-up) Complete | milestone | 0d | 2020-02-05 | 2020-02-05 | 18 |  |  | 2020-02-05 | 2020-02-05 | 0d | 2019-01-28 | 2019-01-28 | 0d |  |  |  |  |  |  |  |  |  |  |
| 20 | 4 | Field Project Management & Supervision |  | 124d | 2020-02-03 | 2020-07-23 | 15 |  |  | 2020-02-03 | 2020-07-23 | 124d | 2019-01-24 | 2019-07-17 | 6d |  |  |  |  |  |  |  |  | Z1010.02 | 01.01.03 |
| 21 | 5 | **Field Work- Asbestos Inspection, Abatement and Encapsulation** |  | 85d | 2020-02-06 | 2020-06-03 |  |  |  | 2020-02-06 | 2020-06-03 | 85d | 2019-01-29 | 2019-05-27 | 0d |  |  |  | 680h |  | 27,000 | 27,000 |  |  |  |
| 22 | 5.1 | Abate and Encapsulate Processing Facility 1 |  | 30d | 2020-02-06 | 2020-03-18 | 19 |  |  | 2020-02-06 | 2020-03-18 | 30d | 2019-01-29 | 2019-03-11 | 0d |  |  | Environmental Wizards | 240h |  | 27,000 | 27,000 |  |  |  |
| 23 | 5.2 | Mobilization to Processing Facility 2 |  | 5d | 2020-03-19 | 2020-03-25 | 22 |  |  | 2020-03-19 | 2020-03-25 | 5d | 2019-03-12 | 2019-03-18 | 0d |  |  | Environmental Wizards | 40h |  |  |  |  |  |  |
| 24 | 5.3 | Abate and Encapsulate Processing Facility 2 |  | 50d | 2020-03-26 | 2020-06-03 | 23 |  |  | 2020-03-26 | 2020-06-03 | 50d | 2019-03-19 | 2019-05-27 | 0d |  |  | Environmental Wizards | 400h |  |  |  |  |  |  |
| 25 | 5.4 | Field Work- Asbestos Inspection, Abatement and Encapsulation Complete | milestone | 0d | 2020-06-03 | 2020-06-03 | 24 |  |  | 2020-06-03 | 2020-06-03 | 0d | 2019-05-27 | 2019-05-27 | 0d |  |  |  |  |  |  |  |  |  |  |

| ID | WBS | Task | Type | Duration | Start | Finish | Predecessors | Baseline start | Baseline finish | Baseline duration | Baseline 1 start | Baseline 1 finish | Total slack | Resources | Work | Cost | Baseline cost |
| --- | --- | --- | --- | --- | --- | --- | --- | --- | --- | --- | --- | --- | --- | --- | --- | --- | --- |
| 26 | 6 | **Project Closeout** |  | 42d | 2020-06-04 | 2020-07-31 |  | 2020-06-04 | 2020-07-31 | 42d | 2019-05-28 | 2019-07-25 | 0d |  | 336h | 16,276.92 | 16,276.92 |
| 27 | 6.1 | Demobilization/Cleanup/Restoration |  | 2d | 2020-06-04 | 2020-06-05 | 25 | 2020-06-04 | 2020-06-05 | 2d | 2019-05-28 | 2019-05-29 | 0d | Environmental Wizards | 16h | 6,500 | 6,500 |
| 28 | 6.2 | Post Fieldwork Inspection / Documentation |  | 10d | 2020-06-08 | 2020-06-19 | 27 | 2020-06-08 | 2020-06-19 | 10d | 2019-05-30 | 2019-06-12 | 0d | Maintenance | 80h | 3,200 | 3,200 |
| 29 | 6.3 | Final Report |  | 30d | 2020-06-22 | 2020-07-31 | 28 | 2020-06-22 | 2020-07-31 | 30d | 2019-06-13 | 2019-07-25 | 0d | Charlie Mejia | 240h | 6,576.92 | 6,576.92 |
| 30 | 6.4 | Closeout Complete | milestone | 0d | 2020-07-31 | 2020-07-31 | 29 | 2020-07-31 | 2020-07-31 | 0d | 2019-07-25 | 2019-07-25 | 0d |  |  |  |  |
| 31 | 6.5 | Asbestos Abatement Encapsulation JT Processing Facilities Complete | milestone | 0d | 2020-07-31 | 2020-07-31 | 30, 20 | 2020-07-31 | 2020-07-31 | 0d | 2019-07-25 | 2019-07-25 | 0d |  |  |  |  |
