# JT Network Upgrades

Schedule from MS Project, 2019-12-02 to 2020-03-19, costs in $, A marks actual dates.
Java Tucana

## Calendars

- Java Tucana Admin: Mon-Fri 08:00-12:00, 13:00-17:00; Sat-Sun off. Exceptions (off unless hours are given): 2017-07-04 to 2022-07-04 (Jul 4th Holiday, recurring), 2017-11-23 to 2022-11-24 (Thanksgiving, recurring), 2017-12-25 to 2021-12-25 (Christmas, recurring), 2018-01-01 to 2022-01-01 (New Year's Day, recurring).

## Resources

| Resource | Group | Rate |
| --- | --- | --- |
| Charlie Mejia | Admin | 27.4 |
| Ann Chung | IT | 26.92 |
| Ron Sova | Marketing | 25 |
| Rick Herrera | Projects | 25.48 |
| Dorothy Windle | Call Center | 32 |
| Call Center Day Analysts | Call Center | 15 |
| Juan Silva | Internet Sales Center | 32 |
| Internet Sales Day Operators | Internet Sales Center | 15 |
| Maintenance | Maintenance | 40 |
| Network Heroes | Contract |  |
| Extreme Designs | Contract |  |
| Environmental Wizards | Contract |  |
| Joe Student | Projects | 84.13 |

## Schedule

| ID | WBS | Task | Type | Duration | Start | Finish | Predecessors | Complete | Remaining | Baseline start | Baseline finish | Baseline duration | Total slack | Free slack | Constraint | Resources | Work | Actual work | Cost | Baseline cost | Actual cost |
| --- | --- | --- | --- | --- | --- | --- | --- | --- | --- | --- | --- | --- | --- | --- | --- | --- | --- | --- | --- | --- | --- |
| 1 | 1 | **Project Status Meetings** |  | 73.12d | 2019-12-05 08:00 | 2020-03-19 09:00 |  |  |  | 2019-11-18 08:00 | 2020-03-02 09:00 | 72.12d | 0.12d |  |  |  |  |  |  |  |  |
| 2 | 1.1 | Project Status Meetings 1 |  | 1h | 2019-12-05 08:00 | 2019-12-05 09:00 |  |  |  | 2019-11-18 08:00 | 2019-11-18 09:00 | 1h | 73.12d |  | start no earlier than 2019-12-05 08:00 |  |  |  |  |  |  |
| 3 | 1.2 | Project Status Meetings 2 |  | 1h | 2019-12-12 08:00 | 2019-12-12 09:00 |  |  |  | 2019-11-25 08:00 | 2019-11-25 09:00 | 1h | 68.12d |  | start no earlier than 2019-12-12 08:00 |  |  |  |  |  |  |
| 4 | 1.3 | Project Status Meetings 3 |  | 1h | 2019-12-19 08:00 | 2019-12-19 09:00 |  |  |  | 2019-12-02 08:00 | 2019-12-02 09:00 | 1h | 63.12d |  | start no earlier than 2019-12-19 08:00 |  |  |  |  |  |  |
| 5 | 1.4 | Project Status Meetings 4 |  | 1h | 2019-12-26 08:00 | 2019-12-26 09:00 |  |  |  | 2019-12-09 08:00 | 2019-12-09 09:00 | 1h | 59.12d |  | start no earlier than 2019-12-26 08:00 |  |  |  |  |  |  |
| 6 | 1.5 | Project Status Meetings 5 |  | 1h | 2020-01-02 08:00 | 2020-01-02 09:00 |  |  |  | 2019-12-16 08:00 | 2019-12-16 09:00 | 1h | 55.12d |  | start no earlier than 2020-01-02 08:00 |  |  |  |  |  |  |
| 7 | 1.6 | Project Status Meetings 6 |  | 1h | 2020-01-09 08:00 | 2020-01-09 09:00 |  |  |  | 2019-12-23 08:00 | 2019-12-23 09:00 | 1h | 50.12d |  | start no earlier than 2020-01-09 08:00 |  |  |  |  |  |  |
| 8 | 1.7 | Project Status Meetings 7 |  | 1h | 2020-01-16 08:00 | 2020-01-16 09:00 |  |  |  | 2019-12-30 08:00 | 2019-12-30 09:00 | 1h | 45.12d |  | start no earlier than 2020-01-16 08:00 |  |  |  |  |  |  |
| 9 | 1.8 | Project Status Meetings 8 |  | 1h | 2020-01-23 08:00 | 2020-01-23 09:00 |  |  |  | 2020-01-06 08:00 | 2020-01-06 09:00 | 1h | 40.12d |  | start no earlier than 2020-01-23 08:00 |  |  |  |  |  |  |
| 10 | 1.9 | Project Status Meetings 9 |  | 1h | 2020-01-30 08:00 | 2020-01-30 09:00 |  |  |  | 2020-01-13 08:00 | 2020-01-13 09:00 | 1h | 35.12d |  | start no earlier than 2020-01-30 08:00 |  |  |  |  |  |  |
| 11 | 1.10 | Project Status Meetings 10 |  | 1h | 2020-02-06 08:00 | 2020-02-06 09:00 |  |  |  | 2020-01-20 08:00 | 2020-01-20 09:00 | 1h | 30.12d |  | start no earlier than 2020-02-06 08:00 |  |  |  |  |  |  |
| 12 | 1.11 | Project Status Meetings 11 |  | 1h | 2020-02-13 08:00 | 2020-02-13 09:00 |  |  |  | 2020-01-27 08:00 | 2020-01-27 09:00 | 1h | 25.12d |  | start no earlier than 2020-02-13 08:00 |  |  |  |  |  |  |
| 13 | 1.12 | Project Status Meetings 12 |  | 1h | 2020-02-20 08:00 | 2020-02-20 09:00 |  |  |  | 2020-02-03 08:00 | 2020-02-03 09:00 | 1h | 20.12d |  | start no earlier than 2020-02-20 08:00 |  |  |  |  |  |  |
| 14 | 1.13 | Project Status Meetings 13 |  | 1h | 2020-02-27 08:00 | 2020-02-27 09:00 |  |  |  | 2020-02-10 08:00 | 2020-02-10 09:00 | 1h | 15.12d |  | start no earlier than 2020-02-27 08:00 |  |  |  |  |  |  |
| 15 | 1.14 | Project Status Meetings 14 |  | 1h | 2020-03-05 08:00 | 2020-03-05 09:00 |  |  |  | 2020-02-17 08:00 | 2020-02-17 09:00 | 1h | 10.12d |  | start no earlier than 2020-03-05 08:00 |  |  |  |  |  |  |
| 16 | 1.15 | Project Status Meetings 15 |  | 1h | 2020-03-12 08:00 | 2020-03-12 09:00 |  |  |  | 2020-02-24 08:00 | 2020-02-24 09:00 | 1h | 5.12d |  | start no earlier than 2020-03-12 08:00 |  |  |  |  |  |  |
| 17 | 1.16 | Project Status Meetings 16 |  | 1h | 2020-03-19 08:00 | 2020-03-19 09:00 |  |  |  | 2020-03-02 08:00 | 2020-03-02 09:00 | 1h | 0.12d |  | start no earlier than 2020-03-19 08:00 |  |  |  |  |  |  |
| 18 | 2 | **Planning Phase** |  | 40.5d | 2019-12-02 08:00 A | 2020-01-29 12:00 |  | 64% | 14.42d | 2019-11-15 08:00 | 2020-01-13 12:00 | 38.5d | 3.38d |  |  |  | 376h | 272h | 10,390.77 | 10,390.77 | 7,540.77 |
| 19 | 2.1 | Document Current Environment |  | 4d | 2019-12-02 08:00 A | 2019-12-05 17:00 A |  | 100% |  | 2019-11-15 08:00 | 2019-11-20 17:00 | 4d |  |  |  | Ann Chung | 32h | 32h | 861.54 | 861.54 | 861.54 |
| 20 | 2.2 | Conduct Needs Analysis |  | 2w | 2019-12-09 08:00 A | 2019-12-20 17:00 A | 19 | 100% |  | 2019-11-21 08:00 | 2019-12-05 17:00 | 2w |  |  |  | Rick Herrera; Dorothy Windle | 160h | 160h | 4,598.46 | 4,598.46 | 4,598.46 |
| 21 | 2.3 | Identify Hardware, Software,Equipment, and Supplies Required |  | 4h | 2019-12-23 08:00 A | 2019-12-23 12:00 A | 20 | 100% |  | 2019-12-06 08:00 | 2019-12-06 12:00 | 4h |  |  |  | Ann Chung; Network Heroes | 8h | 8h | 107.69 | 107.69 | 107.69 |
| 22 | 2.4 | Create Request for Proposal and Timeline |  | 4d | 2019-12-23 13:00 A | 2019-12-30 12:00 A | 21 | 100% |  | 2019-12-06 13:00 | 2019-12-16 12:00 | 4d |  |  |  | Charlie Mejia | 32h | 32h | 876.92 | 876.92 | 876.92 |
| 23 | 2.5 | Gather Vendor Bids |  | 2w | 2020-01-02 13:00 A | 2020-01-16 12:00 | 22 | 50% | 1w | 2019-12-16 13:00 | 2019-12-31 12:00 | 2w | 3.38d | 0d |  | Charlie Mejia | 80h | 40h | 2,192.31 | 2,192.31 | 1,096.15 |
| 24 | 2.6 | Choose Vendors |  | 1w | 2020-01-16 13:00 | 2020-01-24 12:00 | 23 |  |  | 2019-12-31 13:00 | 2020-01-08 12:00 | 1w | 3.38d | 0d |  | Charlie Mejia | 40h |  | 1,096.15 | 1,096.15 |  |
| 25 | 2.7 | Sign Contracts |  | 3d | 2020-01-24 13:00 | 2020-01-29 12:00 | 24 |  |  | 2020-01-08 13:00 | 2020-01-13 12:00 | 3d | 3.38d | 0d |  | Charlie Mejia | 24h |  | 657.69 | 657.69 |  |
| 26 | 2.8 | Planning Phase Complete | milestone | 0d | 2020-01-29 12:00 | 2020-01-29 12:00 | 25 |  |  | 2020-01-13 12:00 | 2020-01-13 12:00 | 0d | 3.38d | 0d |  |  |  |  |  |  |  |

| ID | WBS | Task | Type | Duration | Start | Finish | Predecessors | Baseline start | Baseline finish | Baseline duration | Total slack | Free slack | Constraint | Resources | Work | Cost | Baseline cost |
| --- | --- | --- | --- | --- | --- | --- | --- | --- | --- | --- | --- | --- | --- | --- | --- | --- | --- |
| 27 | 3 | **Procurement Phase** |  | 8d | 2020-01-29 13:00 | 2020-02-10 12:00 |  | 2020-01-13 13:00 | 2020-01-23 12:00 | 8d | 3.38d |  |  |  | 64h | 4,926.92 | 4,926.92 |
| 28 | 3.1 | Order Hardware Components |  | 3d | 2020-01-29 13:00 | 2020-02-03 12:00 | 26 | 2020-01-13 13:00 | 2020-01-16 12:00 | 3d | 3.38d | 0d |  | Joe Student | 24h | 2,019.23 | 2,019.23 |
| 29 | 3.2 | Order Infustructure Components |  | 3d | 2020-02-03 13:00 | 2020-02-06 12:00 | 28 | 2020-01-16 13:00 | 2020-01-21 12:00 | 3d | 3.38d | 0d |  | Joe Student | 24h | 2,019.23 | 2,019.23 |
| 30 | 3.3 | Purchase Software Licenses |  | 1d | 2020-02-06 13:00 | 2020-02-07 12:00 | 29 | 2020-01-21 13:00 | 2020-01-22 12:00 | 1d | 3.38d | 0d |  | Joe Student | 8h | 673.08 | 673.08 |
| 31 | 3.4 | Identify Additional Needed Components and Order |  | 1d | 2020-02-07 13:00 | 2020-02-10 12:00 | 30 | 2020-01-22 13:00 | 2020-01-23 12:00 | 1d | 3.38d | 0d |  | Ann Chung | 8h | 215.38 | 215.38 |
| 32 | 3.5 | Procurement Phase Complete | milestone | 0d | 2020-02-10 12:00 | 2020-02-10 12:00 | 31 | 2020-01-23 12:00 | 2020-01-23 12:00 | 0d | 3.38d | 1.5d |  |  |  |  |  |
| 33 | 4 | **Installation and Testing Phase** |  | 12d | 2020-02-17 08:00 | 2020-03-03 17:00 |  | 2020-01-28 13:00 | 2020-02-14 17:00 | 13.5d | 0d |  |  |  | 136h |  |  |
| 34 | 4.1 | Install Cabling |  | 2w | 2020-02-17 08:00 | 2020-02-28 17:00 | 32FS+5ed | 2020-01-28 13:00 | 2020-02-11 12:00 | 2w | 1.88d | 0.88d |  | Network Heroes | 80h |  |  |
| 35 | 4.2 | Install Hardware |  | 1w | 2020-02-19 08:00 | 2020-02-25 17:00 | 34SS+5e% | 2020-01-30 08:00 | 2020-02-05 17:00 | 1w | 1d | 0d | start no earlier than 2020-02-13 08:00 | Network Heroes | 40h |  |  |
| 36 | 4.3 | Install Software |  | 3d | 2020-02-25 08:00 | 2020-02-27 17:00 | 35FS-5e% | 2020-02-05 08:00 | 2020-02-07 17:00 | 3d | 1d |  |  |  |  |  |  |
| 37 | 4.4 | Test Network |  | 2d | 2020-03-02 08:00 | 2020-03-03 17:00 | 36 | 2020-02-13 08:00 | 2020-02-14 17:00 | 2d | 0d |  | start no earlier than 2020-03-02 08:00 | Network Heroes | 16h |  |  |
| 38 | 4.5 | Installation and Testing Phase Complete | milestone | 0d | 2020-03-03 17:00 | 2020-03-03 17:00 | 37 | 2020-02-14 17:00 | 2020-02-14 17:00 | 0d | 0d |  |  |  |  |  |  |
| 39 | 5 | **Training and Communication Phase** |  | 6.38d | 2020-03-04 08:00 | 2020-03-12 11:00 |  | 2020-02-17 08:00 | 2020-02-25 11:00 | 6.38d | 0d |  |  |  | 51h | 1,611 | 1,623.5 |
| 40 | 5.1 | Communicate Information Updates |  | 3h | 2020-03-04 08:00 | 2020-03-04 11:00 | 38 | 2020-02-17 08:00 | 2020-02-17 11:00 | 3h | 0d |  |  | Ron Sova | 3h | 75 | 75 |
| 41 | 5.2 | Communicate "Go Live" Date | inactive | 0.5h | 2020-03-04 11:00 | 2020-03-04 11:30 | 40 | 2020-02-17 11:00 | 2020-02-17 11:30 | 0.5h | 0d |  |  | Ron Sova | 0.5h | 12.5 | 12.5 |
| 42 | 5.3 | Train Management |  | 3d | 2020-03-04 11:00 | 2020-03-09 11:00 | 41SS | 2020-02-17 11:00 | 2020-02-20 11:00 | 3d | 0d |  |  | Juan Silva | 24h | 768 | 768 |
| 43 | 5.4 | Train Users |  | 3d | 2020-03-09 11:00 | 2020-03-12 11:00 | 42 | 2020-02-20 11:00 | 2020-02-25 11:00 | 3d | 0d |  |  | Juan Silva | 24h | 768 | 768 |
| 44 | 5.5 | Traning and Communication Phase Complete | milestone | 0d | 2020-03-12 11:00 | 2020-03-12 11:00 | 43 | 2020-02-25 11:00 | 2020-02-25 11:00 | 0d | 0d |  |  |  |  |  |  |
| 45 | 6 | **Evaluation and Close Out Phase** |  | 4.88d | 2020-03-12 11:00 | 2020-03-19 10:00 |  | 2020-02-25 11:00 | 2020-03-03 10:00 | 4.88d | 0d |  |  |  | 41h | 1,195.73 | 1,195.73 |
| 46 | 6.1 | Assess Project Success |  | 4d | 2020-03-12 11:00 | 2020-03-18 11:00 | 44 | 2020-02-25 11:00 | 2020-03-02 11:00 | 4d | 0d |  |  | Charlie Mejia | 32h | 876.92 | 876.92 |
| 47 | 6.2 | Establish Maintenance Schedule |  | 5h | 2020-03-18 11:00 | 2020-03-18 17:00 | 46 | 2020-03-02 11:00 | 2020-03-02 17:00 | 5h | 0d |  |  | Maintenance | 5h | 200 | 200 |
| 48 | 6.3 | Review Meeting - Successes and Improvements Needed |  | 2h | 2020-03-19 08:00 | 2020-03-19 10:00 | 47 | 2020-03-03 08:00 | 2020-03-03 10:00 | 2h | 0d |  |  | Charlie Mejia; Dorothy Windle | 4h | 118.81 | 118.81 |
| 49 | 6.4 | Evaluation and Closeout Phase Complete | milestone | 0d | 2020-03-19 10:00 | 2020-03-19 10:00 | 48 | 2020-03-03 10:00 | 2020-03-03 10:00 | 0d | 0d |  |  |  |  |  |  |
| 50 | 7 | JT Network Upgrades Complete | milestone | 0d | 2020-03-19 10:00 | 2020-03-19 10:00 | 49 | 2020-03-02 17:00 | 2020-03-02 17:00 | 0d | 0d |  | finish no later than 2020-03-20 08:00 |  |  |  |  |
