# JT Corporate Move

Schedule from MS Project, 2019-07-02 to 2019-12-03, costs in $, A marks actual dates.
Refurbish New Offices and Move
Java Tucana

## Calendars

- Java Tucana Admin: Mon-Fri 08:00-12:00, 13:00-17:00; Sat-Sun off. Exceptions (off unless hours are given): 2017-07-04 to 2022-07-04 (Jul 4th Holiday, recurring).

## Resources

| Resource | Group | Rate |
| --- | --- | --- |
| Charlie Mejia | Admin | 27.4 |
| Ann Chung | IT | 26.92 |
| Ron Sova | Marketing | 25 |
| Rick Herrera | Projects | 25.48 |
| Dorothy Windle | Call Center | 32 |
| Call Center Day Analysts | Call Center | 15 |
| Juan Silva | Internet Sales Center | 32 |
| Internet Sales Day Operators | Internet Sales Center | 15 |
| Maintenance | Maintenance | 40 |
| Network Heroes | Contract |  |
| Extreme Designs | Contract |  |
| Laura Lynn | Admin | 22.6 |
| Administration Services | Admin |  |
| Informations Technology Systems | IT |  |

## Schedule

| ID | WBS | Task | Type | Duration | Start | Finish | Predecessors | Complete | Baseline start | Baseline finish | Baseline duration | Total slack | Free slack | Constraint | Resources | Work | Actual work | Cost | Baseline cost | Actual cost |
| --- | --- | --- | --- | --- | --- | --- | --- | --- | --- | --- | --- | --- | --- | --- | --- | --- | --- | --- | --- | --- |
| 1 | 1 | **JT Move Status Meetings** |  | 10.12d | 2019-07-05 | 2019-07-19 |  |  | 2019-07-05 | 2019-07-19 | 10.12d | 97.38d |  |  |  |  |  |  |  |  |
| 2 | 1.1 | JT Move Status Meetings 1 |  | 1h | 2019-07-05 | 2019-07-05 |  |  | 2019-07-05 | 2019-07-05 | 1h | 107.38d |  | start no earlier than 2019-07-05 |  |  |  |  |  |  |
| 3 | 1.2 | JT Move Status Meetings 2 |  | 1h | 2019-07-12 | 2019-07-12 |  |  | 2019-07-12 | 2019-07-12 | 1h | 102.38d |  | start no earlier than 2019-07-12 |  |  |  |  |  |  |
| 4 | 1.3 | JT Move Status Meetings 3 |  | 1h | 2019-07-19 | 2019-07-19 |  |  | 2019-07-19 | 2019-07-19 | 1h | 97.38d |  | start no earlier than 2019-07-19 |  |  |  |  |  |  |
| 5 | 2 | **Planning the Move** |  | 49.38d | 2019-07-02 A | 2019-09-10 A |  | 100% | 2019-07-02 | 2019-09-10 | 49.38d |  |  |  |  | 796h | 796h | 12,957.08 | 12,957.08 | 12,957.08 |
| 6 | 2.1 | Identify Move Team Members |  | 2d | 2019-07-02 A | 2019-07-03 A |  | 100% | 2019-07-02 | 2019-07-03 | 2d |  |  |  | Laura Lynn | 16h | 16h | 361.54 | 361.54 | 361.54 |
| 7 | 2.2 | Plan Infastructure Upgrades |  | 2w | 2019-07-05 A | 2019-07-18 A | 6 | 100% | 2019-07-05 | 2019-07-18 | 2w |  |  |  | Juan Silva | 80h | 80h | 2,560 | 2,560 | 2,560 |
| 8 | 2.3 | Plan IT Move |  | 2w | 2019-07-19 A | 2019-08-01 A | 7 | 100% | 2019-07-19 | 2019-08-01 | 2w |  |  |  | Charlie Mejia; Rick Herrera | 160h | 160h | 4,230.77 | 4,230.77 | 4,230.77 |
| 9 | 2.4 | Plan Physical Move |  | 2w | 2019-07-23 A | 2019-08-06 A | 8FS-7.5% | 100% | 2019-07-23 | 2019-08-06 | 2w |  |  |  | Charlie Mejia; Rick Herrera | 160h | 160h | 4,230.77 | 4,230.77 | 4,230.77 |
| 10 | 2.5 | Plan for Continous Operations During the Move |  | 4d | 2019-08-06 A | 2019-08-12 A | 9 | 100% | 2019-08-06 | 2019-08-12 | 4d |  |  |  | Dorothy Windle [50%]; Juan Silva [50%] | 32h | 32h | 1,024 | 1,024 | 1,024 |
| 11 | 2.6 | Obtain Estimates from Moving Services |  | 1w | 2019-08-12 A | 2019-08-16 A | 10 | 100% | 2019-08-12 | 2019-08-16 | 1w |  |  |  | Administration Services [200%] | 80h | 80h |  |  |  |
| 12 | 2.7 | Interview and Select Movers |  | 1w | 2019-08-19 A | 2019-08-23 A | 11 | 100% | 2019-08-19 | 2019-08-23 | 1w |  |  |  | Administration Services [200%] | 80h | 80h |  |  |  |
| 13 | 2.8 | Obtain Estimates from IT Installation Companies |  | 1w | 2019-08-19 A | 2019-08-23 A | 11 | 100% | 2019-08-19 | 2019-08-23 | 1w |  |  |  | Administration Services [200%] | 80h | 80h |  |  |  |
| 14 | 2.9 | Interview and Select IT Installation Company |  | 1w | 2019-08-26 A | 2019-08-30 A | 13, 12 | 100% | 2019-08-26 | 2019-08-30 | 1w |  |  |  | Administration Services [200%] | 80h | 80h |  |  |  |
| 15 | 2.10 | Order Boxes and Materials needed for the Move |  | 3h | 2019-09-02 A | 2019-09-02 A | 14 | 100% | 2019-09-02 | 2019-09-02 | 3h |  |  |  | Administration Services [200%] | 6h | 6h |  |  |  |
| 16 | 2.11 | Planning the Move Complete | milestone | 0d | 2019-09-02 A | 2019-09-02 A | 15 | 100% | 2019-09-02 | 2019-09-02 | 0d |  |  |  |  |  |  |  |  |  |
| 17 | 2.12 | **Communications** |  | 6.38d | 2019-09-02 A | 2019-09-10 A |  | 100% | 2019-09-02 | 2019-09-10 | 6.38d |  |  |  |  | 22h | 22h | 550 | 550 | 550 |
| 18 | 2.12.1 | Communicate Move Plan to Employees |  | 3d | 2019-09-02 A | 2019-09-04 A | 16 | 100% | 2019-09-02 | 2019-09-04 | 3d |  |  |  | Ron Sova [50%] | 12h | 12h | 300 | 300 | 300 |
| 19 | 2.12.2 | Gather Feedback From Employees |  | 2d | 2019-09-05 A | 2019-09-09 A | 18 | 100% | 2019-09-05 | 2019-09-09 | 2d |  |  |  | Ron Sova [50%] | 8h | 8h | 200 | 200 | 200 |
| 20 | 2.12.3 | Communicate Move Information to Suppliers |  | 2h | 2019-09-09 A | 2019-09-09 A | 19 | 100% | 2019-09-09 | 2019-09-09 | 2h |  |  |  | Ron Sova [50%] | 1h | 1h | 25 | 25 | 25 |
| 21 | 2.12.4 | Communicate Move Information to Customers |  | 2h | 2019-09-10 A | 2019-09-10 A | 20 | 100% | 2019-09-10 | 2019-09-10 | 2h |  |  |  | Ron Sova [50%] | 1h | 1h | 25 | 25 | 25 |
| 22 | 2.12.5 | Communications Complete | milestone | 0d | 2019-09-10 A | 2019-09-10 A | 21 | 100% | 2019-09-10 | 2019-09-10 | 0d |  |  |  |  |  |  |  |  |  |
| 23 | 3 | **JT Corporate Center Preparation** |  | 24d | 2019-09-10 | 2019-10-14 |  |  | 2019-09-10 | 2019-10-14 | 24d | 1.62d |  |  |  | 528h |  |  |  |  |
| 24 | 3.1 | **JT Call Center Refurbishing New Location** |  | 22d | 2019-09-10 | 2019-10-10 |  |  | 2019-09-10 | 2019-10-10 | 22d | 1.62d |  |  |  | 176h |  |  |  |  |
| 25 | 3.1.1 | Install Network Cables |  | 3d | 2019-09-10 | 2019-09-13 | 22 |  | 2019-09-10 | 2019-09-13 | 3d | 1.62d | 0d |  | Network Heroes | 24h |  |  |  |  |
| 26 | 3.1.2 | Install TeleCommunication Lines |  | 1w | 2019-09-13 | 2019-09-20 | 25 |  | 2019-09-13 | 2019-09-20 | 1w | 3.62d | 0d |  | Network Heroes | 40h |  |  |  |  |
| 27 | 3.1.3 | Paint the walls |  | 2d | 2019-09-20 | 2019-09-24 | 26 |  | 2019-09-20 | 2019-09-24 | 2d | 3.62d | 0d |  | Extreme Designs | 16h |  |  |  |  |
| 28 | 3.1.4 | Lay Carpet |  | 2d | 2019-09-25 | 2019-09-27 | 27FS+1ed |  | 2019-09-25 | 2019-09-27 | 2d | 3.62d | 0d |  | Extreme Designs | 16h |  |  |  |  |
| 29 | 3.1.5 | Install Partitions |  | 1d | 2019-09-27 | 2019-09-30 | 28 |  | 2019-09-27 | 2019-09-30 | 1d | 3.62d | 0d |  | Extreme Designs | 8h |  |  |  |  |
| 30 | 3.1.6 | Prepare Offices |  | 5d | 2019-09-30 | 2019-10-07 | 29 |  | 2019-09-30 | 2019-10-07 | 5d | 3.62d | 0d |  | Extreme Designs | 40h |  |  |  |  |
| 31 | 3.1.7 | Assemble Furniture |  | 2d | 2019-10-07 | 2019-10-09 | 30 |  | 2019-10-07 | 2019-10-09 | 2d | 3.62d | 0d |  | Extreme Designs | 16h |  |  |  |  |
| 32 | 3.1.8 | Hook up Computers |  | 1d | 2019-10-09 | 2019-10-10 | 31 |  | 2019-10-09 | 2019-10-10 | 1d | 3.62d | 0d |  | Network Heroes | 8h |  |  |  |  |
| 33 | 3.1.9 | Hook up Phones |  | 1d | 2019-10-09 | 2019-10-10 | 32FF |  | 2019-10-09 | 2019-10-10 | 1d | 3.62d | 0d |  | Network Heroes | 8h |  |  |  |  |
| 34 | 3.1.10 | JT Call Center Complete | milestone | 0d | 2019-10-10 | 2019-10-10 | 33 |  | 2019-10-10 | 2019-10-10 | 0d | 3.62d | 2d |  |  |  |  |  |  |  |

| ID | WBS | Task | Type | Duration | Start | Finish | Predecessors | Baseline start | Baseline finish | Baseline duration | Total slack | Free slack | Resources | Work |
| --- | --- | --- | --- | --- | --- | --- | --- | --- | --- | --- | --- | --- | --- | --- |
| 35 | 3.2 | **JT Internet Sales Center Refurbishing New Location** |  | 24d | 2019-09-10 | 2019-10-14 |  | 2019-09-10 | 2019-10-14 | 24d | 1.62d |  |  | 176h |
| 36 | 3.2.1 | Install Network Cables |  | 3d | 2019-09-10 | 2019-09-13 | 25SS | 2019-09-10 | 2019-09-13 | 3d | 1.62d | 0d | Network Heroes | 24h |
| 37 | 3.2.2 | Install TeleCommunication Lines |  | 1w | 2019-09-13 | 2019-09-20 | 36 | 2019-09-13 | 2019-09-20 | 1w | 1.62d | 0d | Network Heroes | 40h |
| 38 | 3.2.3 | Paint the walls |  | 2d | 2019-09-20 | 2019-09-24 | 37 | 2019-09-20 | 2019-09-24 | 2d | 1.62d | 0d | Extreme Designs | 16h |
| 39 | 3.2.4 | Lay Carpet |  | 2d | 2019-09-25 | 2019-09-27 | 38FS+1ed | 2019-09-25 | 2019-09-27 | 2d | 1.62d | 0d | Extreme Designs | 16h |
| 40 | 3.2.5 | Install Partitions |  | 1d | 2019-09-27 | 2019-09-30 | 39 | 2019-09-27 | 2019-09-30 | 1d | 1.62d | 0d | Extreme Designs | 8h |
| 41 | 3.2.6 | Prepare Offices |  | 5d | 2019-09-30 | 2019-10-07 | 40 | 2019-09-30 | 2019-10-07 | 5d | 1.62d | 0d | Extreme Designs | 40h |
| 42 | 3.2.7 | Assemble Furniture |  | 2d | 2019-10-07 | 2019-10-09 | 41 | 2019-10-07 | 2019-10-09 | 2d | 1.62d | 0d | Extreme Designs | 16h |
| 43 | 3.2.8 | Hook up Computers |  | 1d | 2019-10-09 | 2019-10-10 | 42 | 2019-10-09 | 2019-10-10 | 1d | 1.62d | 0d | Network Heroes | 8h |
| 44 | 3.2.9 | Hook up Phones |  | 1d | 2019-10-09 | 2019-10-10 | 43FF | 2019-10-09 | 2019-10-10 | 1d | 1.62d | 0d | Network Heroes | 8h |
| 45 | 3.2.10 | Move in Belongings |  | 2d | 2019-10-10 | 2019-10-14 | 44 | 2019-10-10 | 2019-10-14 | 2d | 1.62d | 0d |  |  |
| 46 | 3.2.11 | JT Internet Sales Center Complete | milestone | 0d | 2019-10-14 | 2019-10-14 | 45 | 2019-10-14 | 2019-10-14 | 0d | 1.62d | 0d |  |  |
| 47 | 3.3 | **JT Administration Offices Refurbishing New Location** |  | 24d | 2019-09-10 | 2019-10-14 |  | 2019-09-10 | 2019-10-14 | 24d | 1.62d |  |  | 176h |
| 48 | 3.3.1 | Install Network Cables |  | 3d | 2019-09-10 | 2019-09-13 | 36SS | 2019-09-10 | 2019-09-13 | 3d | 1.62d | 0d | Network Heroes | 24h |
| 49 | 3.3.2 | Install TeleCommunication Lines |  | 1w | 2019-09-13 | 2019-09-20 | 48 | 2019-09-13 | 2019-09-20 | 1w | 1.62d | 0d | Network Heroes | 40h |
| 50 | 3.3.3 | Paint the walls |  | 2d | 2019-09-20 | 2019-09-24 | 49 | 2019-09-20 | 2019-09-24 | 2d | 1.62d | 0d | Extreme Designs | 16h |
| 51 | 3.3.4 | Lay Carpet |  | 2d | 2019-09-25 | 2019-09-27 | 50FS+1ed | 2019-09-25 | 2019-09-27 | 2d | 1.62d | 0d | Extreme Designs | 16h |
| 52 | 3.3.5 | Install Partitions |  | 1d | 2019-09-27 | 2019-09-30 | 51 | 2019-09-27 | 2019-09-30 | 1d | 1.62d | 0d | Extreme Designs | 8h |
| 53 | 3.3.6 | Prepare Offices |  | 5d | 2019-09-30 | 2019-10-07 | 52 | 2019-09-30 | 2019-10-07 | 5d | 1.62d | 0d | Extreme Designs | 40h |
| 54 | 3.3.7 | Assemble Furniture |  | 2d | 2019-10-07 | 2019-10-09 | 53 | 2019-10-07 | 2019-10-09 | 2d | 1.62d | 0d | Extreme Designs | 16h |
| 55 | 3.3.8 | Hook up Computers |  | 1d | 2019-10-09 | 2019-10-10 | 54 | 2019-10-09 | 2019-10-10 | 1d | 1.62d | 0d | Network Heroes | 8h |
| 56 | 3.3.9 | Hook up Phones |  | 1d | 2019-10-09 | 2019-10-10 | 55FF | 2019-10-09 | 2019-10-10 | 1d | 1.62d | 0d | Network Heroes | 8h |
| 57 | 3.3.10 | Move in Belongings |  | 2d | 2019-10-10 | 2019-10-14 | 56 | 2019-10-10 | 2019-10-14 | 2d | 1.62d | 0d |  |  |
| 58 | 3.3.11 | JT Administrative Offices Complete | milestone | 0d | 2019-10-14 | 2019-10-14 | 57 | 2019-10-14 | 2019-10-14 | 0d | 1.62d | 0d |  |  |
| 59 | 3.3.12 | JT Offices Refurbishing Complete | milestone | 0d | 2019-10-14 | 2019-10-14 | 34, 46, 58 | 2019-10-14 | 2019-10-14 | 0d | 1.62d |  |  |  |

| ID | WBS | Task | Type | Duration | Start | Finish | Predecessors | Baseline start | Baseline finish | Baseline duration | Total slack | Constraint | Resources | Work | Cost | Baseline cost |
| --- | --- | --- | --- | --- | --- | --- | --- | --- | --- | --- | --- | --- | --- | --- | --- | --- |
| 60 | 4 | **Moving** |  | 32.25d | 2019-10-16 | 2019-11-29 |  | 2019-10-16 | 2019-11-29 | 32.25d | 0d |  |  | 1390h | 19,477.21 | 19,477.21 |
| 61 | 4.1 | **Packing** |  | 25.25d | 2019-10-16 | 2019-11-20 |  | 2019-10-16 | 2019-11-20 | 25.25d | 0d |  |  | 1318h | 16,917.21 | 16,917.21 |
| 62 | 4.1.1 | Distribute Boxes to Employees |  | 3d | 2019-10-16 | 2019-10-18 | 59 | 2019-10-16 | 2019-10-18 | 3d | 0d | start no earlier than 2019-10-16 | Maintenance | 24h | 960 | 960 |
| 63 | 4.1.2 | Communicate Timetable and Packing Requirements to Employees |  | 1d | 2019-10-21 | 2019-10-21 | 62 | 2019-10-21 | 2019-10-21 | 1d | 0d |  | Ron Sova | 8h | 200 | 200 |
| 64 | 4.1.3 | Tag Furniture and Equipment to Identify New Area Staging |  | 2w | 2019-10-22 | 2019-11-04 | 63 | 2019-10-22 | 2019-11-04 | 2w | 0d |  | Internet Sales Day Operators [700%]; Call Center Day Analysts [600%] | 1040h | 15,600 | 15,600 |
| 65 | 4.1.4 | Tag Computer Equipment to Identify New Are Staging |  | 2w | 2019-11-05 | 2019-11-18 | 64 | 2019-11-05 | 2019-11-18 | 2w | 0d |  | Informations Technology Systems [300%] | 240h |  |  |
| 66 | 4.1.5 | Packing Complete | milestone | 0d | 2019-11-18 | 2019-11-18 | 65 | 2019-11-18 | 2019-11-18 | 0d | 0d |  |  |  |  |  |
| 67 | 4.1.6 | **Final Moving Preperations** |  | 1.25d | 2019-11-19 | 2019-11-20 |  | 2019-11-19 | 2019-11-20 | 1.25d | 0d |  |  | 6h | 157.21 | 157.21 |
| 68 | 4.1.6.1 | Communicate Rotation Schedule to Insure Continous Operations |  | 3h | 2019-11-19 | 2019-11-19 | 66 | 2019-11-19 | 2019-11-19 | 3h | 0d |  | Ron Sova | 3h | 75 | 75 |
| 69 | 4.1.6.2 | Walk-through to Double Chjeck Tagging of All Furniture and Equipment |  | 2h | 2019-11-19 | 2019-11-19 | 68 | 2019-11-19 | 2019-11-19 | 2h | 0d |  | Charlie Mejia | 2h | 54.81 | 54.81 |
| 70 | 4.1.6.3 | Review Move Schedule with Team Leaders |  | 3h | 2019-11-19 | 2019-11-19 | 69 | 2019-11-19 | 2019-11-19 | 3h | 0d |  | Charlie Mejia [20%] | 0.6h | 16.44 | 16.44 |
| 71 | 4.1.6.4 | Review Move Schedule with Movers |  | 2h | 2019-11-20 | 2019-11-20 | 70 | 2019-11-20 | 2019-11-20 | 2h | 0d |  | Charlie Mejia [20%] | 0.4h | 10.96 | 10.96 |
| 72 | 4.1.6.5 | Final Moving Preperations Complete | milestone | 0d | 2019-11-20 | 2019-11-20 | 71 | 2019-11-20 | 2019-11-20 | 0d | 0d |  |  |  |  |  |
| 73 | 4.2 | **Move Furniture and Equipment** |  | 7d | 2019-11-20 | 2019-11-29 |  | 2019-11-20 | 2019-11-29 | 7d | 0d |  |  | 72h | 2,560 | 2,560 |
| 74 | 4.2.1 | Move JT Administrative Offices |  | 2d | 2019-11-20 | 2019-11-22 | 72 | 2019-11-20 | 2019-11-22 | 2d | 0d |  | Maintenance [200%] | 32h | 1,280 | 1,280 |
| 75 | 4.2.2 | Move First Wave JT Call Center |  | 1d | 2019-11-22 | 2019-11-25 | 74 | 2019-11-22 | 2019-11-25 | 1d | 0d |  | Maintenance [200%] | 16h | 640 | 640 |
| 76 | 4.2.3 | Move First Wave JT Internet Sales Center |  | 1d | 2019-11-25 | 2019-11-26 | 75 | 2019-11-25 | 2019-11-26 | 1d | 0d |  | Maintenance [200%] | 16h | 640 | 640 |
| 77 | 4.2.4 | Setup New JT Call Center for Operations |  | 0.5d | 2019-11-26 | 2019-11-26 | 76 | 2019-11-26 | 2019-11-26 | 0.5d | 0d |  | Network Heroes | 4h |  |  |
| 78 | 4.2.5 | Setup New JT Internet Sales Center for Operations |  | 0.5d | 2019-11-26 | 2019-11-27 | 77 | 2019-11-26 | 2019-11-27 | 0.5d | 0d |  | Network Heroes | 4h |  |  |
| 79 | 4.2.6 | New JT Call Center Operational | milestone | 0d | 2019-11-27 | 2019-11-27 | 78 | 2019-11-27 | 2019-11-27 | 0d | 0d |  |  |  |  |  |
| 80 | 4.2.7 | New JT Internet Sales Center Operational | milestone | 0d | 2019-11-27 | 2019-11-27 | 79 | 2019-11-27 | 2019-11-27 | 0d | 0d |  |  |  |  |  |
| 81 | 4.2.8 | Move Final Group JT Call Center |  | 1d | 2019-11-27 | 2019-11-28 | 80 | 2019-11-27 | 2019-11-28 | 1d | 0d |  |  |  |  |  |
| 82 | 4.2.9 | Move Final Group JT Internet Sales Center |  | 1d | 2019-11-28 | 2019-11-29 | 81 | 2019-11-28 | 2019-11-29 | 1d | 0d |  |  |  |  |  |
| 83 | 4.2.10 | Move Furniture and Equipment Complete | milestone | 0d | 2019-11-29 | 2019-11-29 | 82 | 2019-11-29 | 2019-11-29 | 0d | 0d |  |  |  |  |  |
| 84 | 4.3 | Move Complete | milestone | 0d | 2019-11-29 | 2019-11-29 | 83 | 2019-11-29 | 2019-11-29 | 0d | 0d |  |  |  |  |  |

| ID | WBS | Task | Type | Duration | Start | Finish | Predecessors | Baseline start | Baseline finish | Baseline duration | Total slack | Free slack | Constraint |
| --- | --- | --- | --- | --- | --- | --- | --- | --- | --- | --- | --- | --- | --- |
| 85 | 5 | **JT Corporate Move Closeout** |  | 2.25d | 2019-11-29 | 2019-12-03 |  | 2019-11-29 | 2019-12-03 | 2.25d | 0d |  |  |
| 86 | 5.1 | Unpacking all areas |  | 2d | 2019-11-29 | 2019-12-03 | 84 | 2019-11-29 | 2019-12-03 | 2d | 0d |  |  |
| 87 | 5.2 | Company-Wide Meeting |  | 2h | 2019-12-03 | 2019-12-03 | 86 | 2019-12-03 | 2019-12-03 | 2h | 0d |  |  |
| 88 | 5.3 | Move Evaluation |  | 0.5d | 2019-12-02 | 2019-12-03 | 87SF | 2019-12-02 | 2019-12-03 | 0.5d | 0.12d | 0d |  |
| 89 | 5.4 | Pay Movers |  | 1h | 2019-12-03 | 2019-12-03 | 88 | 2019-12-03 | 2019-12-03 | 1h | 0.12d | 0d |  |
| 90 | 5.5 | JT Corporate Move Closeout Complete | milestone | 0d | 2019-12-03 | 2019-12-03 | 89 | 2019-12-03 | 2019-12-03 | 0d | 0.12d | 0d |  |
| 91 | 6 | JT Corporate Move Complete | milestone | 0d | 2019-12-03 | 2019-12-03 | 90 | 2019-12-03 | 2019-12-03 | 0d | 0.12d |  | finish no later than 2019-12-05 |
