# Finish New Office Workspace.mpp

Schedule from MS Project, 2019-07-02 to 2019-07-30, A marks actual dates.
Refurbish New Office
Java Tucana

## Calendars

- Java Tucana Admin: Mon-Fri 08:00-12:00, 13:00-17:00; Sat-Sun off. Exceptions (off unless hours are given): 2017-07-04 to 2022-07-04 (Jul 4th Holiday, recurring).

## Resources

| Resource |
| --- |
| Maintainence |
| Painter 1 |
| Painter 2 |
| Technician |

## Schedule

| ID | WBS | Task | Type | Duration | Start | Finish | Predecessors | Complete | Remaining | Baseline start | Baseline finish | Baseline duration | Total slack | Free slack | Resources | Work | Actual work |
| --- | --- | --- | --- | --- | --- | --- | --- | --- | --- | --- | --- | --- | --- | --- | --- | --- | --- |
| 1 | 1 | **Office Number 101** |  | 18d | 2019-07-02 A | 2019-07-26 |  | 13% | 15.75d | 2018-07-02 | 2018-07-25 | 17d | 2d |  |  | 192h | 50h |
| 2 | 1.1 | Paint the walls |  | 2d | 2019-07-02 A | 2019-07-03 A |  | 100% |  | 2018-07-02 | 2018-07-03 | 2d |  |  | Painter 1; Painter 2 | 48h | 48h |
| 3 | 1.2 | Install Partitions |  | 1d | 2019-07-05 A | 2019-07-05 | 2 | 25% | 0.75d | 2018-07-04 | 2018-07-04 | 1d | 2d | 0d | Maintainence | 8h | 2h |
| 4 | 1.3 | Install Network Cables |  | 3d | 2019-07-08 | 2019-07-10 | 3 |  |  | 2018-07-05 | 2018-07-09 | 3d | 2d | 0d | Technician | 24h |  |
| 5 | 1.4 | Lay Carpet |  | 2d | 2019-07-11 | 2019-07-12 | 4 |  |  | 2018-07-10 | 2018-07-11 | 2d | 2d | 0d | Maintainence [200%] | 32h |  |
| 6 | 1.5 | Prepare Offices |  | 5d | 2019-07-15 | 2019-07-19 | 5 |  |  | 2018-07-12 | 2018-07-18 | 5d | 2d | 0d | Maintainence | 40h |  |
| 7 | 1.6 | Assemble Furniture |  | 2d | 2019-07-22 | 2019-07-23 | 6 |  |  | 2018-07-19 | 2018-07-20 | 2d | 2d | 0d | Maintainence | 16h |  |
| 8 | 1.7 | Hook up Computers |  | 1d | 2019-07-24 | 2019-07-24 | 7 |  |  | 2018-07-23 | 2018-07-23 | 1d | 2d | 0d | Technician | 8h |  |
| 9 | 1.8 | Move in Belongings |  | 2d | 2019-07-25 | 2019-07-26 | 8 |  |  | 2018-07-24 | 2018-07-25 | 2d | 2d | 0d | Maintainence | 16h |  |
| 10 | 1.9 | Office 101 Complete | milestone | 0d | 2019-07-26 | 2019-07-26 | 9 |  |  | 2018-07-25 | 2018-07-25 | 0d | 2d |  |  |  |  |
| 11 | 2 | **Office Number 102** |  | 18d | 2019-07-03 | 2019-07-30 |  |  |  | 2018-07-05 | 2018-08-01 | 20d | 0d |  |  |  |  |
| 12 | 2.1 | Paint the walls | milestone | 0d | 2019-07-03 | 2019-07-03 | 2 |  |  | 2018-07-05 | 2018-07-06 | 2d | 0d |  |  |  |  |
| 13 | 2.2 | Install Partitions |  | 1d | 2019-07-05 | 2019-07-05 | 12 |  |  | 2018-07-09 | 2018-07-09 | 1d | 2d | 0d |  |  |  |
| 14 | 2.3 | Install Network Cables |  | 3d | 2019-07-08 | 2019-07-10 | 13 |  |  | 2018-07-10 | 2018-07-12 | 3d | 2d | 0d |  |  |  |
| 15 | 2.4 | Lay Carpet |  | 2d | 2019-07-11 | 2019-07-12 | 14 |  |  | 2018-07-13 | 2018-07-16 | 2d | 2d | 0d |  |  |  |
| 16 | 2.5 | Prepare Offices |  | 5d | 2019-07-15 | 2019-07-19 | 15 |  |  | 2018-07-17 | 2018-07-23 | 5d | 2d | 0d |  |  |  |
| 17 | 2.6 | Assemble Furniture |  | 2d | 2019-07-22 | 2019-07-23 | 16 |  |  | 2018-07-24 | 2018-07-25 | 2d | 2d | 0d |  |  |  |
| 18 | 2.7 | Hook up Computers |  | 1d | 2019-07-24 | 2019-07-24 | 17 |  |  | 2018-07-26 | 2018-07-26 | 1d | 2d | 0d |  |  |  |
| 19 | 2.8 | Move in Belongings |  | 2d | 2019-07-25 | 2019-07-26 | 18 |  |  | 2018-07-27 | 2018-07-30 | 2d | 2d | 0d |  |  |  |
| 20 | 2.9 | Office 102 Complete | milestone | 0d | 2019-07-26 | 2019-07-26 | 19 |  |  | 2018-07-30 | 2018-07-30 | 0d | 2d |  |  |  |  |
| 21 | 2.10 | **Office Number 103** |  | 18d | 2019-07-05 | 2019-07-30 |  |  |  | 2018-07-09 | 2018-08-01 | 18d | 0d |  |  |  |  |
| 22 | 2.10.1 | Paint the walls |  | 2d | 2019-07-05 | 2019-07-08 | 12 |  |  | 2018-07-09 | 2018-07-10 | 2d | 0d |  |  |  |  |
| 23 | 2.10.2 | Install Partitions |  | 1d | 2019-07-09 | 2019-07-09 | 22 |  |  | 2018-07-11 | 2018-07-11 | 1d | 0d |  |  |  |  |
| 24 | 2.10.3 | Install Network Cables |  | 3d | 2019-07-10 | 2019-07-12 | 23 |  |  | 2018-07-12 | 2018-07-16 | 3d | 0d |  |  |  |  |
| 25 | 2.10.4 | Lay Carpet |  | 2d | 2019-07-15 | 2019-07-16 | 24 |  |  | 2018-07-17 | 2018-07-18 | 2d | 0d |  |  |  |  |
| 26 | 2.10.5 | Prepare Offices |  | 5d | 2019-07-17 | 2019-07-23 | 25 |  |  | 2018-07-19 | 2018-07-25 | 5d | 0d |  |  |  |  |
| 27 | 2.10.6 | Assemble Furniture |  | 2d | 2019-07-24 | 2019-07-25 | 26 |  |  | 2018-07-26 | 2018-07-27 | 2d | 0d |  |  |  |  |
| 28 | 2.10.7 | Hook up Computers |  | 1d | 2019-07-26 | 2019-07-26 | 27 |  |  | 2018-07-30 | 2018-07-30 | 1d | 0d |  |  |  |  |
| 29 | 2.10.8 | Move in Belongings |  | 2d | 2019-07-29 | 2019-07-30 | 28 |  |  | 2018-07-31 | 2018-08-01 | 2d | 0d |  |  |  |  |
| 30 | 2.10.9 | Office 103 Complete | milestone | 0d | 2019-07-30 | 2019-07-30 | 29 |  |  | 2018-08-01 | 2018-08-01 | 0d | 0d |  |  |  |  |
| 31 | 2.10.10 | Finsih New Office Worspace Complete | milestone | 0d | 2019-07-30 | 2019-07-30 | 30, 10, 20 |  |  | 2018-08-01 | 2018-08-01 | 0d | 0d |  |  |  |  |
