# Finish New Office Workspace.mpp

Schedule from MS Project, 2019-07-01 to 2019-07-26, A marks actual dates.
Refurbish New Office
Java Tucana

## Calendars

- Java Tucana Admin: Mon-Fri 08:00-12:00, 13:00-17:00; Sat-Sun off. Exceptions (off unless hours are given): 2017-07-04 to 2022-07-04 (Jul 4th Holiday, recurring).

## Resources

| Resource |
| --- |
| Maintainence |
| Painter 1 |
| Painter 2 |
| Technician |

## Schedule

| ID | WBS | Task | Type | Duration | Start | Finish | Predecessors | Complete | Remaining | Baseline start | Baseline finish | Baseline duration | Total slack | Resources | Work | Actual work |
| --- | --- | --- | --- | --- | --- | --- | --- | --- | --- | --- | --- | --- | --- | --- | --- | --- |
| 1 | 1 | **Office Number 101** |  | 18d | 2019-07-02 A | 2019-07-26 |  | 13% | 15.75d | 2018-07-02 | 2018-07-25 | 17d | 0d |  | 192h | 50h |
| 2 | 1.1 | Paint the walls |  | 2d | 2019-07-02 A | 2019-07-03 A |  | 100% |  | 2018-07-02 | 2018-07-03 | 2d |  | Painter 1; Painter 2 | 48h | 48h |
| 3 | 1.2 | Install Partitions |  | 1d | 2019-07-05 A | 2019-07-05 | 2 | 25% | 0.75d | 2018-07-04 | 2018-07-04 | 1d | 0d | Maintainence | 8h | 2h |
| 4 | 1.3 | Install Network Cables |  | 3d | 2019-07-08 | 2019-07-10 | 3 |  |  | 2018-07-05 | 2018-07-09 | 3d | 0d | Technician | 24h |  |
| 5 | 1.4 | Lay Carpet |  | 2d | 2019-07-11 | 2019-07-12 | 4 |  |  | 2018-07-10 | 2018-07-11 | 2d | 0d | Maintainence [200%] | 32h |  |
| 6 | 1.5 | Prepare Offices |  | 5d | 2019-07-15 | 2019-07-19 | 5 |  |  | 2018-07-12 | 2018-07-18 | 5d | 0d | Maintainence | 40h |  |
| 7 | 1.6 | Assemble Furniture |  | 2d | 2019-07-22 | 2019-07-23 | 6 |  |  | 2018-07-19 | 2018-07-20 | 2d | 0d | Maintainence | 16h |  |
| 8 | 1.7 | Hook up Computers |  | 1d | 2019-07-24 | 2019-07-24 | 7 |  |  | 2018-07-23 | 2018-07-23 | 1d | 0d | Technician | 8h |  |
| 9 | 1.8 | Move in Belongings |  | 2d | 2019-07-25 | 2019-07-26 | 8 |  |  | 2018-07-24 | 2018-07-25 | 2d | 0d | Maintainence | 16h |  |
| 10 | 1.9 | Office 101 Complete | milestone | 0d | 2019-07-26 | 2019-07-26 | 9 |  |  | 2018-07-25 | 2018-07-25 | 0d | 0d |  |  |  |
| 11 | 2 | **Office Number 102** |  | 5d | 2019-07-01 | 2019-07-08 |  |  |  |  |  |  | 14d |  |  |  |
| 12 | 2.1 | Paint the walls |  | 2d | 2019-07-01 | 2019-07-02 |  |  |  |  |  |  | 17d |  |  |  |
| 13 | 2.2 | Install Partitions |  | 1d | 2019-07-01 | 2019-07-01 |  |  |  |  |  |  | 18d |  |  |  |
| 14 | 2.3 | Install Network Cables |  | 3d | 2019-07-01 | 2019-07-03 |  |  |  |  |  |  | 16d |  |  |  |
| 15 | 2.4 | Lay Carpet |  | 2d | 2019-07-01 | 2019-07-02 |  |  |  |  |  |  | 17d |  |  |  |
| 16 | 2.5 | Prepare Offices |  | 5d | 2019-07-01 | 2019-07-08 |  |  |  |  |  |  | 14d |  |  |  |
| 17 | 2.6 | Assemble Furniture |  | 2d | 2019-07-01 | 2019-07-02 |  |  |  |  |  |  | 17d |  |  |  |
| 18 | 2.7 | Hook up Computers |  | 1d | 2019-07-01 | 2019-07-01 |  |  |  |  |  |  | 18d |  |  |  |
| 19 | 2.8 | Move in Belongings |  | 2d | 2019-07-01 | 2019-07-02 |  |  |  |  |  |  | 17d |  |  |  |
