# Asbestos Abatement Encapsulation JT Processing Facilities

Schedule from MS Project, 2018-11-01 to 2019-07-25, costs in $.
Java Tucana

## Calendars

- Java Tucana Admin: Mon-Fri 08:00-12:00, 13:00-17:00; Sat-Sun off. Exceptions (off unless hours are given): 2017-07-04 to 2022-07-04 (Jul 4th Holiday, recurring).

## Resources

| Resource | Group | Rate |
| --- | --- | --- |
| Charlie Mejia | Admin | 27.4 |
| Ann Chung | IT | 26.92 |
| Ron Sova | Marketing | 25 |
| Rick Herrera | Projects | 25.48 |
| Dorothy Windle | Call Center | 32 |
| Call Center Day Analysts | Call Center | 15 |
| Juan Silva | Internet Sales Center | 32 |
| Internet Sales Day Operators | Internet Sales Center | 15 |
| Maintenance | Maintenance | 40 |
| Network Heroes | Contract |  |
| Extreme Designs | Contract |  |
| Environmental Wizards | Contract |  |

## Schedule

| ID | WBS | Task | Type | Duration | Start | Finish | Predecessors | Total slack | Free slack | Cost | Text1 | Text2 |
| --- | --- | --- | --- | --- | --- | --- | --- | --- | --- | --- | --- | --- |
| 1 | 1 | Notice to Proceed from JT CEO, JT CFO |  | 5d | 2018-11-01 | 2018-11-07 |  | 179d | 0d |  | Z1010.01 | 01.01.01 |
| 2 | 2 | Project Award to High (best) Bid Contractor | milestone | 0d | 2018-11-07 | 2018-11-07 | 1 | 179d | 0d |  | Z1010.01 | 01.01.01 |
| 3 | 3 | **General Requirements (Start-up)** |  | 63d | 2018-11-01 | 2019-01-28 |  | 0d |  | 6,000 |  |  |
| 4 | 3.1 | General Requirements (Start-up) Insurance & Bonds |  | 1d | 2018-11-08 | 2018-11-08 | 2 | 179d | 0d |  | Z1050.02, .03 | 01.01.01 |
| 5 | 2.1 | Post Award Site Survey |  | 5d | 2018-11-09 | 2018-11-15 | 4 | 179d | 19d | 4,000 |  |  |
| 6 | 2.2 | DRAFT Work Plan |  | 30d | 2018-11-01 | 2018-12-12 | 5FF | 160d |  |  |  |  |
| 7 | 2.4 | EPA Review |  | 14d | 2018-11-01 | 2018-11-20 |  | 0d |  |  |  |  |
| 8 | 2.5 | Finalize Final Work Plan |  | 14d | 2018-11-16 | 2018-12-05 | 7FS-3d | 0d |  |  |  |  |
| 9 | 2.6 | Submit Final Work Plan |  | 1d | 2018-12-06 | 2018-12-06 | 8 | 0d |  |  |  |  |
| 10 | 2.7 | EPA Approval |  | 10d | 2018-12-07 | 2018-12-20 | 9 | 0d |  |  |  |  |
| 11 | 2.12 | Local Government Review/Approval of Local Submittals |  | 10d | 2018-12-21 | 2019-01-03 | 10 | 0d |  |  |  |  |
| 12 | 3 | Procure/Fabrication/Transportation/Arrival of Local Equipment |  | 10d | 2019-01-04 | 2019-01-17 | 11 | 0d |  |  |  |  |
| 13 | 3.10 | General Requirements (Start-up) Administration Complete | milestone | 0d | 2019-01-17 | 2019-01-17 | 12 | 0d |  |  |  | 01.02.02 |
| 14 | 3.11 | **General Requirements (Start-up) Temporary Facilities & Mobilization** |  | 7d | 2019-01-18 | 2019-01-28 |  | 0d |  | 2,000 |  | 01.01.02 |
| 15 | 3.11.1 | Temporary Staging Facilities/Laydown Yard |  | 4d | 2019-01-18 | 2019-01-23 | 13 | 0d |  | 2,000 | Z1030.02 | 01.01.02 |
| 16 | 3.11.2 | Temporary Site Access & Parking |  | 2d | 2019-01-18 | 2019-01-21 | 15SS | 0d |  |  | Z1030.04 | 01.01.02 |
| 17 | 3.11.3 | General Requirements (Start-up) Permits |  | 7d | 2019-01-18 | 2019-01-28 | 16SS | 0d |  |  | Z1050.01 | 01.01.02 |
| 18 | 3.11.4 | General Requirements (Start-up) Temporary Facilities & Mobilization Complete | milestone | 0d | 2019-01-28 | 2019-01-28 | 17 | 0d |  |  |  | 01.01.02 |
| 19 | 3.12 | General Requirements (Start-up) Complete | milestone | 0d | 2019-01-28 | 2019-01-28 | 18 | 0d |  |  |  |  |
| 20 | 4 | Field Project Management & Supervision |  | 124d | 2019-01-24 | 2019-07-17 | 15 | 6d |  |  | Z1010.02 | 01.01.03 |
| 21 | 5 | **Field Work- Asbestos Inspection, Abatement and Encapsulation** |  | 85d | 2019-01-29 | 2019-05-27 |  | 0d |  |  |  |  |
| 22 | 5.1 | Abate and Encapsulate Processing Facility 1 |  | 30d | 2019-01-29 | 2019-03-11 | 19 | 0d |  |  |  |  |
| 23 | 5.2 | Mobilization to Processing Facility 2 |  | 5d | 2019-03-12 | 2019-03-18 | 22 | 0d |  |  |  |  |
| 24 | 5.3 | Abate and Encapsulate Processing Facility 2 |  | 50d | 2019-03-19 | 2019-05-27 | 23 | 0d |  |  |  |  |
| 25 | 5.4 | Field Work- Asbestos Inspection, Abatement and Encapsulation Complete | milestone | 0d | 2019-05-27 | 2019-05-27 | 24 | 0d |  |  |  |  |

| ID | WBS | Task | Type | Duration | Start | Finish | Predecessors | Total slack | Cost |
| --- | --- | --- | --- | --- | --- | --- | --- | --- | --- |
| 26 | 6 | **Project Closeout** |  | 42d | 2019-05-28 | 2019-07-25 |  | 0d | 6,500 |
| 27 | 6.1 | Demobilization/Cleanup/Restoration |  | 2d | 2019-05-28 | 2019-05-29 | 25 | 0d | 6,500 |
| 28 | 6.2 | Post Fieldwork Inspection / Documentation |  | 10d | 2019-05-30 | 2019-06-12 | 27 | 0d |  |
| 29 | 6.3 | Final Report |  | 30d | 2019-06-13 | 2019-07-25 | 28 | 0d |  |
| 30 | 6.4 | Closeout Complete | milestone | 0d | 2019-07-25 | 2019-07-25 | 29 | 0d |  |
| 31 | 6.5 | Asbestos Abatement Encapsulation JT Processing Facilities Complete | milestone | 0d | 2019-07-25 | 2019-07-25 | 30, 20 | 0d |  |
