# JT Coffee Roasters Gas Fired Drum Roasters Maintenance

Schedule from MS Project, 2019-10-04 to 2019-10-06.
JaVA tUCANA

## Calendars

- JT 24 Hours: Mon-Sun 00:00-24:00.

## Schedule

| ID | WBS | Task | Type | Duration | Start | Finish | Predecessors | Total slack |
| --- | --- | --- | --- | --- | --- | --- | --- | --- |
| 1 | 1 | **Stage 1 Maintenance** |  | 0.12d | 2019-10-04 08:00 | 2019-10-04 08:57 |  | 0d |
| 2 | 1.1 | Check oil level of gear box on back of roaster |  | 0.25h | 2019-10-04 08:00 | 2019-10-04 08:15 |  | 0d |
| 3 | 1.2 | Clean out bean chips from bottom of cooling tray |  | 0.25h | 2019-10-04 08:15 | 2019-10-04 08:30 | 2 | 0d |
| 4 | 1.3 | Clean ash tray |  | 0.15h | 2019-10-04 08:15 | 2019-10-04 08:24 | 3SS | 0d |
| 5 | 1.4 | Clean out destoner boot |  | 0.15h | 2019-10-04 08:15 | 2019-10-04 08:24 | 4SS | 0d |
| 6 | 1.5 | Clean magnetic slide |  | 0.15h | 2019-10-04 08:15 | 2019-10-04 08:24 | 5SS | 0d |
| 7 | 1.6 | Clean cooling screen top side |  | 0.25h | 2019-10-04 08:24 | 2019-10-04 08:39 | 6 | 0d |
| 8 | 1.7 | Clean under side of cooling screen |  | 0.15h | 2019-10-04 08:39 | 2019-10-04 08:48 | 7 | 0d |
| 9 | 1.8 | Drain condensation from compressor tank |  | 0.15h | 2019-10-04 08:48 | 2019-10-04 08:57 | 8 | 0d |
| 10 | 1.9 | Stage 1 Maintenance Complete | milestone | 0d | 2019-10-04 08:57 | 2019-10-04 08:57 | 9 | 0d |
| 11 | 2 | **Stage 2 Maintenance** |  | 0.27d | 2019-10-04 08:57 | 2019-10-04 11:06 |  | 0d |
| 12 | 2.1 | Check for coffee breakage from destoner |  | 0.5h | 2019-10-04 08:57 | 2019-10-04 09:27 | 10 | 0d |
| 13 | 2.2 | Clean exhaust temperature probe |  | 0.15h | 2019-10-04 09:27 | 2019-10-04 09:36 | 12 | 0d |
| 14 | 2.3 | Check roaster grease cups |  | 0.15h | 2019-10-04 09:36 | 2019-10-04 09:45 | 13 | 0d |
| 15 | 2.4 | Check grease fittings and add grease as needed to drum motor, exhaust motor, stirring arm motor, cooling motor, destoner motor, compressor motor, and roaster burner combustion blower motor |  | 0.25h | 2019-10-04 09:36 | 2019-10-04 09:51 | 14SS | 0d |
| 16 | 2.5 | Check smoke suppression system time and volume with measuring device |  | 0.15h | 2019-10-04 09:36 | 2019-10-04 09:45 | 15SS | 0d |
| 17 | 2.6 | Check automatic pneumatic oilier |  | 0.15h | 2019-10-04 09:36 | 2019-10-04 09:45 | 16SS | 0d |
| 18 | 2.7 | Check and drain water trap |  | 0.1h | 2019-10-04 09:36 | 2019-10-04 09:42 | 17SS | 0d |
| 19 | 2.8 | Check oil level on compressor |  | 0.05h | 2019-10-04 09:36 | 2019-10-04 09:39 | 18SS | 0d |
| 20 | 2.9 | Change oil on compressor |  | 0.05h | 2019-10-04 09:39 | 2019-10-04 09:42 | 19 | 0d |
| 21 | 2.10 | Clean cooling pipe |  | 0.25h | 2019-10-04 09:42 | 2019-10-04 09:57 | 20 | 0d |
| 22 | 2.11 | Clean exhaust pipe |  | 0.25h | 2019-10-04 09:57 | 2019-10-04 10:12 | 21 | 0d |
| 23 | 2.12 | Clean transition above chaff collector |  | 0.15h | 2019-10-04 10:12 | 2019-10-04 10:21 | 22 | 0d |
| 24 | 2.13 | Clean exhaust valve box |  | 0.15h | 2019-10-04 10:21 | 2019-10-04 10:30 | 23 | 0d |
| 25 | 2.14 | Clean cooling fan |  | 0.25h | 2019-10-04 10:30 | 2019-10-04 10:45 | 24 | 0d |
| 26 | 2.15 | Clean exhaust fan |  | 0.25h | 2019-10-04 10:45 | 2019-10-04 11:00 | 25 | 0d |
| 27 | 2.16 | Inspect destoner pipe |  | 0.1h | 2019-10-04 11:00 | 2019-10-04 11:06 | 26 | 0d |
| 28 | 2.17 | Inspect destoner fan |  | 0.1h | 2019-10-04 11:00 | 2019-10-04 11:06 | 27SS | 0d |
| 29 | 2.18 | Inspect destoner target for tears |  | 0.1h | 2019-10-04 11:00 | 2019-10-04 11:06 | 28SS | 0d |
| 30 | 2.19 | Stage 2 Maintenance Complete | milestone | 0d | 2019-10-04 11:06 | 2019-10-04 11:06 | 29 | 0d |

| ID | WBS | Task | Type | Duration | Start | Finish | Predecessors | Total slack |
| --- | --- | --- | --- | --- | --- | --- | --- | --- |
| 31 | 3 | **Stage 3 Maintenance** |  | 2.28d | 2019-10-04 11:06 | 2019-10-05 05:21 |  | 0d |
| 32 | 3.1 | Check and clean 4’ fluorescent lights |  | 0.5h | 2019-10-04 11:06 | 2019-10-04 11:36 | 30 | 0d |
| 33 | 3.2 | Make a visual inspection for loose bolts and nuts or any abnormal conditions of machine |  | 0.25h | 2019-10-04 11:36 | 2019-10-04 11:51 | 32 | 0d |
| 34 | 3.3 | Check belts on cooling fan |  | 0.25h | 2019-10-04 11:51 | 2019-10-04 12:06 | 33 | 0d |
| 35 | 3.4 | Check belts on exhaust fan |  | 0.25h | 2019-10-04 12:06 | 2019-10-04 12:21 | 34 | 0d |
| 36 | 3.5 | Replace control panel bulbs |  | 0.25h | 2019-10-04 12:21 | 2019-10-04 12:36 | 35 | 0d |
| 37 | 3.6 | Wipe or blow off outside of roaster |  | 0.25h | 2019-10-04 12:36 | 2019-10-04 12:51 | 36 | 0d |
| 38 | 3.7 | Wipe down all piping for exhaust, cooling, destoner, and conveying equipment |  | 0.5h | 2019-10-04 12:51 | 2019-10-04 13:21 | 37 | 0d |
| 39 | 3.8 | Clean green elevator pit |  | 0.5d | 2019-10-04 13:21 | 2019-10-04 17:21 | 38 | 0d |
| 40 | 3.9 | Check grease fittings and add grease as needed to top and bottom elevator bearings and motor |  | 0.5h | 2019-10-04 17:21 | 2019-10-04 17:51 | 39 | 0d |
| 41 | 3.10 | Check green elevator bucket and belt for tightness |  | 0.5h | 2019-10-04 17:21 | 2019-10-04 17:51 | 40SS | 0d |
| 42 | 3.11 | Clean green elevator hopper |  | 0.5d | 2019-10-04 17:21 | 2019-10-04 21:21 | 41SS | 0d |
| 43 | 3.12 | Clean combustion blower for roaster |  | 0.5d | 2019-10-04 21:21 | 2019-10-05 01:21 | 42 | 0d |
| 44 | 3.13 | Clean combustion blower for afterburner |  | 0.5d | 2019-10-04 21:21 | 2019-10-05 01:21 | 43SS | 0d |
| 45 | 3.14 | Wipe or blow off outside of afterburner |  | 0.15h | 2019-10-05 01:21 | 2019-10-05 01:30 | 44 | 0d |
| 46 | 3.15 | Clean chaff from chaff collector |  | 0.5d | 2019-10-05 01:21 | 2019-10-05 05:21 | 45SS | 0d |
| 47 | 3.16 | Clean top of chaff collector of residue build-up |  | 0.5d | 2019-10-05 01:21 | 2019-10-05 05:21 | 46SS | 0d |
| 48 | 3.17 | Stage 3 Maintenance Complete | milestone | 0d | 2019-10-05 05:21 | 2019-10-05 05:21 | 47 | 0d |
| 49 | 4 | **Stage 4 Maintenance** |  | 2.5d | 2019-10-05 05:21 | 2019-10-06 01:21 |  | 0d |
| 50 | 4.1 | Technician checks check roaster safety valves and limits to be functionally correct |  | 0.5d | 2019-10-05 05:21 | 2019-10-05 09:21 | 48 | 0d |
| 51 | 4.2 | Technician checks check afterburner safety valves and limits to be functionally correct |  | 0.5d | 2019-10-05 09:21 | 2019-10-05 13:21 | 50 | 0d |
| 52 | 4.3 | Technician checks check roaster burner igniter plug and flame safety guard to be functionally correct |  | 0.5d | 2019-10-05 13:21 | 2019-10-05 17:21 | 51 | 0d |
| 53 | 4.4 | Technician checks check afterburner burner igniter plug and flame safety guard to be functionally correct |  | 0.5d | 2019-10-05 17:21 | 2019-10-05 21:21 | 52 | 0d |
| 54 | 4.5 | Technician removes, cleans, inspects, and repacks main drum bearing |  | 0.5d | 2019-10-05 21:21 | 2019-10-06 01:21 | 53 | 0d |
| 55 | 4.6 | Stage 4 Maintenance Complete | milestone | 0d | 2019-10-06 01:21 | 2019-10-06 01:21 | 54 | 0d |
| 56 | 5 | JT Coffee Roasters Gas Fired Drum Roasters Maintenance Complete | milestone | 0d | 2019-10-06 01:21 | 2019-10-06 01:21 | 55 | 0d |
