# Asbestos Abatement Encapsulation JT Processing Facilities

Schedule from MS Project, 2019-06-03 to 2019-10-29, status date 2018-12-18, costs in $.
Java Tucana

## Calendars

- Java Tucana Admin: Mon-Fri 08:00-12:00, 13:00-17:00; Sat-Sun off. Exceptions (off unless hours are given): 2017-07-04 to 2022-07-04 (Jul 4th Holiday, recurring).

## Resources

| Resource | Group | Unit | Rate |
| --- | --- | --- | --- |
| Charlie Mejia | Admin |  | 27.4 |
| Ann Chung | IT |  | 26.92 |
| Ron Sova | Marketing |  | 25 |
| Rick Herrera | Projects |  | 25.48 |
| Dorothy Windle | Call Center |  | 32 |
| Call Center Day Analysts | Call Center |  | 15 |
| Juan Silva | Internet Sales Center |  | 32 |
| Internet Sales Day Operators | Internet Sales Center |  | 15 |
| Maintenance | Maintenance |  | 40 |
| Network Heroes | Contract |  |  |
| Extreme Designs | Contract |  |  |
| Environmental Wizards | Contract |  |  |
| Asbestos Abatement Budget Cost | Cost |  |  |
| Asbestos Abatement Budget Work | Cost |  |  |
| Asbestos Abatement Plastic Sheeting | Cost | Per Yard |  |

## Schedule

| ID | WBS | Task | Type | Duration | Start | Finish | Predecessors | Baseline start | Baseline finish | Baseline duration | Baseline 1 start | Baseline 1 finish | Total slack | Free slack | Resources | Work | Cost | Baseline cost | Text1 | Text2 |
| --- | --- | --- | --- | --- | --- | --- | --- | --- | --- | --- | --- | --- | --- | --- | --- | --- | --- | --- | --- | --- |
| 1 | 1 | Notice to Proceed from JT CEO, JT CFO |  | 5d | 2019-06-03 | 2019-06-07 |  | 2018-11-01 | 2018-11-07 | 5d | 2018-11-01 | 2018-11-07 | 95d | 0d | Charlie Mejia | 40h | 1,096.15 | 1,096.15 | Z1010.01 | 01.01.01 |
| 2 | 2 | Project Award to High (best) Bid Contractor | milestone | 0d | 2019-06-07 | 2019-06-07 | 1 | 2018-11-07 | 2018-11-07 | 0d | 2018-11-07 | 2018-11-07 | 95d | 0d | Charlie Mejia |  |  |  | Z1010.01 | 01.01.01 |
| 3 | 3 | **General Requirements (Start-up)** |  | 64d | 2019-06-03 | 2019-08-30 |  | 2018-11-01 | 2019-01-28 | 63d | 2018-11-01 | 2019-01-28 | 0d |  |  | 1160h | 38,540 | 43,187.69 |  |  |
| 4 | 3.1 | General Requirements (Start-up) Insurance & Bonds |  | 1d | 2019-06-10 | 2019-06-10 | 2 | 2018-11-08 | 2018-11-08 | 1d | 2018-11-08 | 2018-11-08 | 95d | 0d | Ann Chung; Charlie Mejia | 16h | 434.62 | 434.62 | Z1050.02, .03 | 01.01.01 |
| 5 | 2.1 | Post Award Site Survey |  | 5d | 2019-06-11 | 2019-06-17 | 4 | 2018-11-09 | 2018-11-15 | 5d | 2018-11-09 | 2018-11-15 | 95d | 24d | Dorothy Windle; Charlie Mejia | 80h | 6,376.15 | 6,376.15 |  |  |
| 6 | 2.2 | DRAFT Work Plan |  | 35d | 2019-06-03 | 2019-07-22 | 5FF | 2018-11-01 | 2018-12-12 | 30d | 2018-11-01 | 2018-12-12 | 71d |  | Juan Silva; Dorothy Windle | 480h | 15,360 | 15,360 |  |  |
| 7 | 2.4 | EPA Review |  | 14d | 2019-06-03 | 2019-06-20 |  | 2018-11-01 | 2018-11-20 | 14d | 2018-11-01 | 2018-11-20 | 0d |  | Rick Herrera | 112h | 2,853.85 | 2,853.85 |  |  |
| 8 | 2.5 | Finalize Final Work Plan |  | 17d | 2019-06-18 | 2019-07-11 | 7FS-3d | 2018-11-16 | 2018-12-05 | 16d | 2018-11-16 | 2018-12-05 | 0d |  | Charlie Mejia; Rick Herrera | 224h | 5,923.08 | 5,923.08 |  |  |
| 9 | 2.6 | Submit Final Work Plan |  | 1d | 2019-07-12 | 2019-07-12 | 8 | 2018-12-06 | 2018-12-06 | 1d | 2018-12-06 | 2018-12-06 | 0d |  | Ron Sova | 8h | 200 | 200 |  |  |
| 10 | 2.7 | EPA Approval |  | 10d | 2019-07-22 | 2019-08-02 | 9 | 2018-12-07 | 2018-12-20 | 10d | 2018-12-07 | 2018-12-20 | 0d |  |  |  |  |  |  |  |
| 11 | 2.12 | Local Government Review/Approval of Local Submittals |  | 10d | 2019-08-05 | 2019-08-16 | 10 | 2018-12-21 | 2019-01-03 | 10d | 2018-12-21 | 2019-01-03 | 0d |  | Ron Sova; Charlie Mejia | 160h | 4,192.31 | 4,192.31 |  |  |
| 12 | 3 | Procure/Fabrication/Transportation/Arrival of Local Equipment |  | 10d | 2019-08-19 | 2019-08-30 | 11 | 2019-01-04 | 2019-01-17 | 10d | 2019-01-04 | 2019-01-17 | 0d |  | Maintenance | 80h | 3,200 | 3,200 |  |  |
| 13 | 3.10 | General Requirements (Start-up) Administration Complete | milestone | 0d | 2019-08-30 | 2019-08-30 | 12 | 2019-01-17 | 2019-01-17 | 0d | 2019-01-17 | 2019-01-17 | 0d |  |  |  |  |  |  | 01.02.02 |
| 14 | 4 | **Project Closeout** |  | 42d | 2019-09-02 | 2019-10-29 |  | 2019-05-28 | 2019-07-25 | 42d | 2019-05-28 | 2019-07-25 | 0d |  |  | 336h | 16,276.92 | 16,276.92 |  |  |
| 15 | 4.1 | Demobilization/Cleanup/Restoration |  | 2d | 2019-09-02 | 2019-09-03 | 13 | 2019-05-28 | 2019-05-29 | 2d | 2019-05-28 | 2019-05-29 | 0d |  | Environmental Wizards | 16h | 6,500 | 6,500 |  |  |
| 16 | 4.2 | Post Fieldwork Inspection / Documentation |  | 10d | 2019-09-04 | 2019-09-17 | 15 | 2019-05-30 | 2019-06-12 | 10d | 2019-05-30 | 2019-06-12 | 0d |  | Maintenance | 80h | 3,200 | 3,200 |  |  |
| 17 | 4.3 | Final Report |  | 30d | 2019-09-18 | 2019-10-29 | 16 | 2019-06-13 | 2019-07-25 | 30d | 2019-06-13 | 2019-07-25 | 0d |  | Charlie Mejia | 240h | 6,576.92 | 6,576.92 |  |  |
| 18 | 4.4 | Closeout Complete | milestone | 0d | 2019-10-29 | 2019-10-29 | 17 | 2019-07-25 | 2019-07-25 | 0d | 2019-07-25 | 2019-07-25 | 0d |  |  |  |  |  |  |  |
| 19 | 4.5 | Asbestos Abatement Encapsulation JT Processing Facilities Complete | milestone | 0d | 2019-10-29 | 2019-10-29 | 18 | 2019-07-25 | 2019-07-25 | 0d | 2019-07-25 | 2019-07-25 | 0d |  |  |  |  |  |  |  |
