# Asbestos Abatement Encapsulation JT Processing Facilities

Schedule from MS Project, 2018-11-01 to 2019-07-31, status date 2019-08-05.
Java Tucana

## Calendars

- Java Tucana Admin: Mon-Fri 08:00-12:00, 13:00-17:00; Sat-Sun off. Exceptions (off unless hours are given): 2017-07-04 to 2022-07-04 (Jul 4th Holiday, recurring).

## Resources

| Resource | Group | Unit |
| --- | --- | --- |
| Charlie Mejia | Admin |  |
| Ann Chung | IT |  |
| Ron Sova | Marketing |  |
| Rick Herrera | Projects |  |
| Dorothy Windle | Call Center |  |
| Call Center Day Analysts | Call Center |  |
| Juan Silva | Internet Sales Center |  |
| Internet Sales Day Operators | Internet Sales Center |  |
| Maintenance | Maintenance |  |
| Network Heroes | Contract |  |
| Extreme Designs | Contract |  |
| Environmental Wizards | Contract |  |
| Asbestos Abatement Budget Cost | Cost |  |
| Asbestos Abatement Budget Work | Cost |  |
| Asbestos Abatement Plastic Sheeting | Cost | Per Yard |

## Schedule

| ID | WBS | Task | Type | Duration | Start | Finish | Predecessors | Total slack | Free slack | Deadline | Resources | Work | Text1 | Text2 |
| --- | --- | --- | --- | --- | --- | --- | --- | --- | --- | --- | --- | --- | --- | --- |
| 1 | 1 | Notice to Proceed from JT CEO, JT CFO |  | 5d | 2018-11-01 | 2018-11-07 |  | 183d | 0d |  | Charlie Mejia | 40h | Z1010.01 | 01.01.01 |
| 2 | 2 | Project Award to High (best) Bid Contractor | milestone | 0d | 2018-11-07 | 2018-11-07 | 1 | 183d | 0d |  | Charlie Mejia |  | Z1010.01 | 01.01.01 |
| 3 | 3 | **General Requirements (Start-up)** |  | 67d | 2018-11-01 | 2019-02-01 |  | -3d | 0d |  |  | 1264h |  |  |
| 4 | 3.1 | General Requirements (Start-up) Insurance & Bonds |  | 1d | 2018-11-08 | 2018-11-08 | 2 | 183d | 0d |  | Ann Chung; Charlie Mejia | 16h | Z1050.02, .03 | 01.01.01 |
| 5 | 2.1 | Post Award Site Survey |  | 5d | 2018-11-09 | 2018-11-15 | 4 | 183d | 24d |  | Dorothy Windle; Charlie Mejia | 80h |  |  |
| 6 | 2.2 | DRAFT Work Plan |  | 35d | 2018-11-01 | 2018-12-19 | 5FF | 159d |  |  | Juan Silva; Dorothy Windle | 480h |  |  |
| 7 | 2.4 | EPA Review |  | 14d | 2018-11-01 | 2018-11-20 |  | -3d | 0d |  | Rick Herrera | 112h |  |  |
| 8 | 2.5 | Finalize Final Work Plan |  | 19d | 2018-11-16 | 2018-12-10 | 7FS-3d | -3d | 0d |  | Charlie Mejia; Rick Herrera | 224h |  |  |
| 9 | 2.6 | Submit Final Work Plan |  | 1d | 2018-12-11 | 2018-12-11 | 8 | -3d | 0d | 2018-12-06 | Ron Sova | 8h |  |  |
| 10 | 2.7 | EPA Approval |  | 11d | 2018-12-12 | 2018-12-26 | 9 | 0d |  |  |  |  |  |  |
| 11 | 2.12 | Local Government Review/Approval of Local Submittals |  | 10d | 2018-12-27 | 2019-01-09 | 10 | 0d |  |  | Ron Sova; Charlie Mejia | 160h |  |  |
| 12 | 3 | Procure/Fabrication/Transportation/Arrival of Local Equipment |  | 10d | 2019-01-10 | 2019-01-23 | 11 | 0d |  |  | Maintenance | 80h |  |  |
| 13 | 3.10 | General Requirements (Start-up) Administration Complete | milestone | 0d | 2019-01-23 | 2019-01-23 | 12 | 0d |  |  |  |  |  | 01.02.02 |
| 14 | 3.11 | **General Requirements (Start-up) Temporary Facilities & Mobilization** |  | 7d | 2019-01-24 | 2019-02-01 |  | 0d |  |  |  | 104h |  | 01.01.02 |
| 15 | 3.11.1 | Temporary Staging Facilities/Laydown Yard |  | 4d | 2019-01-24 | 2019-01-29 | 13 | 0d |  |  | Environmental Wizards | 32h | Z1030.02 | 01.01.02 |
| 16 | 3.11.2 | Temporary Site Access & Parking |  | 2d | 2019-01-24 | 2019-01-25 | 15SS | 0d |  |  | Rick Herrera | 16h | Z1030.04 | 01.01.02 |
| 17 | 3.11.3 | General Requirements (Start-up) Permits |  | 7d | 2019-01-24 | 2019-02-01 | 16SS | 0d |  |  | Maintenance | 56h | Z1050.01 | 01.01.02 |
| 18 | 3.11.4 | General Requirements (Start-up) Temporary Facilities & Mobilization Complete | milestone | 0d | 2019-02-01 | 2019-02-01 | 17 | 0d |  |  |  |  |  | 01.01.02 |
| 19 | 3.12 | General Requirements (Start-up) Complete | milestone | 0d | 2019-02-01 | 2019-02-01 | 18 | 0d |  |  |  |  |  |  |
| 20 | 4 | Field Project Management & Supervision |  | 124d | 2019-01-30 | 2019-07-23 | 15 | 6d |  |  |  |  | Z1010.02 | 01.01.03 |
| 21 | 5 | **Field Work- Asbestos Inspection, Abatement and Encapsulation** |  | 85d | 2019-02-04 | 2019-05-31 |  | 0d |  |  |  | 680h |  |  |
| 22 | 5.1 | Abate and Encapsulate Processing Facility 1 |  | 30d | 2019-02-04 | 2019-03-15 | 19 | 0d |  |  | Environmental Wizards | 240h |  |  |
| 23 | 5.2 | Mobilization to Processing Facility 2 |  | 5d | 2019-03-18 | 2019-03-22 | 22 | 0d |  |  | Environmental Wizards | 40h |  |  |
| 24 | 5.3 | Abate and Encapsulate Processing Facility 2 |  | 50d | 2019-03-25 | 2019-05-31 | 23 | 0d |  |  | Environmental Wizards | 400h |  |  |
| 25 | 5.4 | Field Work- Asbestos Inspection, Abatement and Encapsulation Complete | milestone | 0d | 2019-05-31 | 2019-05-31 | 24 | 0d |  |  |  |  |  |  |

Notes:
- 10: Took longer than planned due to holidays. Make sure to schedule more time in future project schedules if task is near major holidays.

| ID | WBS | Task | Type | Duration | Start | Finish | Predecessors | Total slack | Resources | Work |
| --- | --- | --- | --- | --- | --- | --- | --- | --- | --- | --- |
| 26 | 6 | **Project Closeout** |  | 42d | 2019-06-03 | 2019-07-31 |  | 0d |  | 336h |
| 27 | 6.1 | Demobilization/Cleanup/Restoration |  | 2d | 2019-06-03 | 2019-06-04 | 25 | 0d | Environmental Wizards | 16h |
| 28 | 6.2 | Post Fieldwork Inspection / Documentation |  | 10d | 2019-06-05 | 2019-06-18 | 27 | 0d | Maintenance | 80h |
| 29 | 6.3 | Final Report |  | 30d | 2019-06-19 | 2019-07-31 | 28 | 0d | Charlie Mejia | 240h |
| 30 | 6.4 | Closeout Complete | milestone | 0d | 2019-07-31 | 2019-07-31 | 29 | 0d |  |  |
| 31 | 6.5 | Asbestos Abatement Encapsulation JT Processing Facilities Complete | milestone | 0d | 2019-07-31 | 2019-07-31 | 30, 20 | 0d |  |  |
