# JT Network Upgrades

Schedule from MS Project, 2019-11-15 to 2020-03-02, costs in $.
Java Tucana

## Calendars

- Java Tucana Admin: Mon-Fri 08:00-12:00, 13:00-17:00; Sat-Sun off. Exceptions (off unless hours are given): 2017-07-04 to 2022-07-04 (Jul 4th Holiday, recurring).

## Resources

| Resource | Group | Rate |
| --- | --- | --- |
| Charlie Mejia | Admin | 27.4 |
| Ann Chung | IT | 26.92 |
| Ron Sova | Marketing | 25 |
| Rick Herrera | Projects | 25.48 |
| Dorothy Windle | Call Center | 32 |
| Call Center Day Analysts | Call Center | 15 |
| Juan Silva | Internet Sales Center | 32 |
| Internet Sales Day Operators | Internet Sales Center | 15 |
| Maintenance | Maintenance | 40 |
| Network Heroes | Contract |  |
| Extreme Designs | Contract |  |
| Laura Lynn | Admin | 22.6 |
| Administration Services | Admin |  |
| Informations Technology Systems | IT |  |

## Schedule

| ID | WBS | Task | Type | Duration | Start | Finish | Predecessors | Baseline start | Baseline finish | Baseline duration | Total slack | Free slack | Constraint | Resources | Work | Cost | Baseline cost |
| --- | --- | --- | --- | --- | --- | --- | --- | --- | --- | --- | --- | --- | --- | --- | --- | --- | --- |
| 1 | 1 | **Project Status Meetings** |  | 75.12d | 2019-11-18 08:00 | 2020-03-02 09:00 |  | 2019-11-18 08:00 | 2020-03-02 09:00 | 75.12d | 0d |  |  |  |  |  |  |
| 2 | 1.1 | Project Status Meetings 1 |  | 1h | 2019-11-18 08:00 | 2019-11-18 09:00 |  | 2019-11-18 08:00 | 2019-11-18 09:00 | 1h | 75d |  | start no earlier than 2019-11-18 08:00 |  |  |  |  |
| 3 | 1.2 | Project Status Meetings 2 |  | 1h | 2019-11-25 08:00 | 2019-11-25 09:00 |  | 2019-11-25 08:00 | 2019-11-25 09:00 | 1h | 70d |  | start no earlier than 2019-11-25 08:00 |  |  |  |  |
| 4 | 1.3 | Project Status Meetings 3 |  | 1h | 2019-12-02 08:00 | 2019-12-02 09:00 |  | 2019-12-02 08:00 | 2019-12-02 09:00 | 1h | 65d |  | start no earlier than 2019-12-02 08:00 |  |  |  |  |
| 5 | 1.4 | Project Status Meetings 4 |  | 1h | 2019-12-09 08:00 | 2019-12-09 09:00 |  | 2019-12-09 08:00 | 2019-12-09 09:00 | 1h | 60d |  | start no earlier than 2019-12-09 08:00 |  |  |  |  |
| 6 | 1.5 | Project Status Meetings 5 |  | 1h | 2019-12-16 08:00 | 2019-12-16 09:00 |  | 2019-12-16 08:00 | 2019-12-16 09:00 | 1h | 55d |  | start no earlier than 2019-12-16 08:00 |  |  |  |  |
| 7 | 1.6 | Project Status Meetings 6 |  | 1h | 2019-12-23 08:00 | 2019-12-23 09:00 |  | 2019-12-23 08:00 | 2019-12-23 09:00 | 1h | 50d |  | start no earlier than 2019-12-23 08:00 |  |  |  |  |
| 8 | 1.7 | Project Status Meetings 7 |  | 1h | 2019-12-30 08:00 | 2019-12-30 09:00 |  | 2019-12-30 08:00 | 2019-12-30 09:00 | 1h | 45d |  | start no earlier than 2019-12-30 08:00 |  |  |  |  |
| 9 | 1.8 | Project Status Meetings 8 |  | 1h | 2020-01-06 08:00 | 2020-01-06 09:00 |  | 2020-01-06 08:00 | 2020-01-06 09:00 | 1h | 40d |  | start no earlier than 2020-01-06 08:00 |  |  |  |  |
| 10 | 1.9 | Project Status Meetings 9 |  | 1h | 2020-01-13 08:00 | 2020-01-13 09:00 |  | 2020-01-13 08:00 | 2020-01-13 09:00 | 1h | 35d |  | start no earlier than 2020-01-13 08:00 |  |  |  |  |
| 11 | 1.10 | Project Status Meetings 10 |  | 1h | 2020-01-20 08:00 | 2020-01-20 09:00 |  | 2020-01-20 08:00 | 2020-01-20 09:00 | 1h | 30d |  | start no earlier than 2020-01-20 08:00 |  |  |  |  |
| 12 | 1.11 | Project Status Meetings 11 |  | 1h | 2020-01-27 08:00 | 2020-01-27 09:00 |  | 2020-01-27 08:00 | 2020-01-27 09:00 | 1h | 25d |  | start no earlier than 2020-01-27 08:00 |  |  |  |  |
| 13 | 1.12 | Project Status Meetings 12 |  | 1h | 2020-02-03 08:00 | 2020-02-03 09:00 |  | 2020-02-03 08:00 | 2020-02-03 09:00 | 1h | 20d |  | start no earlier than 2020-02-03 08:00 |  |  |  |  |
| 14 | 1.13 | Project Status Meetings 13 |  | 1h | 2020-02-10 08:00 | 2020-02-10 09:00 |  | 2020-02-10 08:00 | 2020-02-10 09:00 | 1h | 15d |  | start no earlier than 2020-02-10 08:00 |  |  |  |  |
| 15 | 1.14 | Project Status Meetings 14 |  | 1h | 2020-02-17 08:00 | 2020-02-17 09:00 |  | 2020-02-17 08:00 | 2020-02-17 09:00 | 1h | 10d |  | start no earlier than 2020-02-17 08:00 |  |  |  |  |
| 16 | 1.15 | Project Status Meetings 15 |  | 1h | 2020-02-24 08:00 | 2020-02-24 09:00 |  | 2020-02-24 08:00 | 2020-02-24 09:00 | 1h | 5d |  | start no earlier than 2020-02-24 08:00 |  |  |  |  |
| 17 | 1.16 | Project Status Meetings 16 |  | 1h | 2020-03-02 08:00 | 2020-03-02 09:00 |  | 2020-03-02 08:00 | 2020-03-02 09:00 | 1h | 0d |  | start no earlier than 2020-03-02 08:00 |  |  |  |  |
| 18 | 2 | **Planning Phase** |  | 36.5d | 2019-11-15 08:00 | 2020-01-06 12:00 |  | 2019-11-15 08:00 | 2020-01-06 12:00 | 36.5d | 10.31d |  |  |  | 372h | 10,352.31 | 10,352.31 |
| 19 | 2.1 | Document Current Environment |  | 4d | 2019-11-15 08:00 | 2019-11-20 17:00 |  | 2019-11-15 08:00 | 2019-11-20 17:00 | 4d | 10.31d | 0d |  | Ann Chung | 32h | 861.54 | 861.54 |
| 20 | 2.2 | Conduct Needs Analysis |  | 2w | 2019-11-21 08:00 | 2019-12-04 17:00 | 19 | 2019-11-21 08:00 | 2019-12-04 17:00 | 2w | 10.31d | 0d |  | Ron Sova; Charlie Mejia | 160h | 4,192.31 | 4,192.31 |
| 21 | 2.3 | Identify Hardware, Software,Equipment, and Supplies Required |  | 4h | 2019-12-05 08:00 | 2019-12-05 12:00 | 20 | 2019-12-05 08:00 | 2019-12-05 12:00 | 4h | 10.31d | 0d |  | Ann Chung | 4h | 107.69 | 107.69 |
| 22 | 2.4 | Create Request for Proposal and Timeline |  | 4d | 2019-12-05 13:00 | 2019-12-11 12:00 | 21 | 2019-12-05 13:00 | 2019-12-11 12:00 | 4d | 10.31d | 0d |  | Charlie Mejia | 32h | 876.92 | 876.92 |
| 23 | 2.5 | Gather Vendor Bids |  | 2w | 2019-12-11 13:00 | 2019-12-25 12:00 | 22 | 2019-12-11 13:00 | 2019-12-25 12:00 | 2w | 10.31d | 0d |  | Dorothy Windle | 80h | 2,560 | 2,560 |
| 24 | 2.6 | Choose Vendors |  | 1w | 2019-12-25 13:00 | 2020-01-01 12:00 | 23 | 2019-12-25 13:00 | 2020-01-01 12:00 | 1w | 10.31d | 0d |  | Charlie Mejia | 40h | 1,096.15 | 1,096.15 |
| 25 | 2.7 | Sign Contracts |  | 3d | 2020-01-01 13:00 | 2020-01-06 12:00 | 24 | 2020-01-01 13:00 | 2020-01-06 12:00 | 3d | 10.31d | 0d |  | Charlie Mejia | 24h | 657.69 | 657.69 |
| 26 | 2.8 | Planning Phase Complete | milestone | 0d | 2020-01-06 12:00 | 2020-01-06 12:00 | 25 | 2020-01-06 12:00 | 2020-01-06 12:00 | 0d | 10.31d | 0d |  |  |  |  |  |

| ID | WBS | Task | Type | Duration | Start | Finish | Predecessors | Baseline start | Baseline finish | Baseline duration | Total slack | Free slack | Resources | Work | Cost | Baseline cost |
| --- | --- | --- | --- | --- | --- | --- | --- | --- | --- | --- | --- | --- | --- | --- | --- | --- |
| 27 | 3 | **Procurement Phase** |  | 8d | 2020-01-06 13:00 | 2020-01-16 12:00 |  | 2020-01-06 13:00 | 2020-01-16 12:00 | 8d | 10.31d |  |  | 64h | 2,048 | 2,048 |
| 28 | 3.1 | Order Hardware Components |  | 3d | 2020-01-06 13:00 | 2020-01-09 12:00 | 26 | 2020-01-06 13:00 | 2020-01-09 12:00 | 3d | 10.31d | 0d | Juan Silva | 24h | 768 | 768 |
| 29 | 3.2 | Order Infustructure Components |  | 3d | 2020-01-09 13:00 | 2020-01-14 12:00 | 28 | 2020-01-09 13:00 | 2020-01-14 12:00 | 3d | 10.31d | 0d | Juan Silva | 24h | 768 | 768 |
| 30 | 3.3 | Purchase Software Licenses |  | 1d | 2020-01-14 13:00 | 2020-01-15 12:00 | 29 | 2020-01-14 13:00 | 2020-01-15 12:00 | 1d | 10.31d | 0d | Juan Silva | 8h | 256 | 256 |
| 31 | 3.4 | Identify Additional Needed Components and Order |  | 1d | 2020-01-15 13:00 | 2020-01-16 12:00 | 30 | 2020-01-15 13:00 | 2020-01-16 12:00 | 1d | 10.31d | 0d | Juan Silva | 8h | 256 | 256 |
| 32 | 3.5 | Procurement Phase Complete | milestone | 0d | 2020-01-16 12:00 | 2020-01-16 12:00 | 31 | 2020-01-16 12:00 | 2020-01-16 12:00 | 0d | 10.31d | 0d |  |  |  |  |
| 33 | 4 | **Installation and Testing Phase** |  | 10d | 2020-01-16 13:00 | 2020-01-30 12:00 |  | 2020-01-16 13:00 | 2020-01-30 12:00 | 10d | 10.31d |  |  | 160h |  |  |
| 34 | 4.1 | Install Cabling |  | 2w | 2020-01-16 13:00 | 2020-01-30 12:00 | 32 | 2020-01-16 13:00 | 2020-01-30 12:00 | 2w | 10.31d | 0d | Network Heroes | 80h |  |  |
| 35 | 4.2 | Install Hardware |  | 1w | 2020-01-16 13:00 | 2020-01-23 12:00 | 34SS | 2020-01-16 13:00 | 2020-01-23 12:00 | 1w | 10.31d | 0d | Network Heroes | 40h |  |  |
| 36 | 4.3 | Install Software |  | 3d | 2020-01-23 13:00 | 2020-01-28 12:00 | 35 | 2020-01-23 13:00 | 2020-01-28 12:00 | 3d | 10.31d | 0d | Network Heroes | 24h |  |  |
| 37 | 4.4 | Test Network |  | 2d | 2020-01-28 13:00 | 2020-01-30 12:00 | 36 | 2020-01-28 13:00 | 2020-01-30 12:00 | 2d | 10.31d | 0d | Network Heroes | 16h |  |  |
| 38 | 4.5 | Installation and Testing Phase Complete | milestone | 0d | 2020-01-30 12:00 | 2020-01-30 12:00 | 37 | 2020-01-30 12:00 | 2020-01-30 12:00 | 0d | 10.31d | 0d |  |  |  |  |
| 39 | 5 | **Training and Communication Phase** |  | 6.44d | 2020-01-30 13:00 | 2020-02-07 16:30 |  | 2020-01-30 13:00 | 2020-02-07 16:30 | 6.44d | 10.31d |  |  | 51.5h | 95.67 | 95.67 |
| 40 | 5.1 | Communicate Information Updates |  | 3h | 2020-01-30 13:00 | 2020-01-30 16:00 | 38 | 2020-01-30 13:00 | 2020-01-30 16:00 | 3h | 10.31d | 0d | Charlie Mejia | 3h | 82.21 | 82.21 |
| 41 | 5.2 | Communicate "Go Live" Date |  | 0.5h | 2020-01-30 16:00 | 2020-01-30 16:30 | 40 | 2020-01-30 16:00 | 2020-01-30 16:30 | 0.5h | 10.31d | 0d | Ann Chung | 0.5h | 13.46 | 13.46 |
| 42 | 5.3 | Train Management |  | 3d | 2020-01-30 16:30 | 2020-02-04 16:30 | 41 | 2020-01-30 16:30 | 2020-02-04 16:30 | 3d | 10.31d | 0d | Informations Technology Systems | 24h |  |  |
| 43 | 5.4 | Train Users |  | 3d | 2020-02-04 16:30 | 2020-02-07 16:30 | 42 | 2020-02-04 16:30 | 2020-02-07 16:30 | 3d | 10.31d | 0d | Informations Technology Systems | 24h |  |  |
| 44 | 5.5 | Traning and Communication Phase Complete | milestone | 0d | 2020-02-07 16:30 | 2020-02-07 16:30 | 43 | 2020-02-07 16:30 | 2020-02-07 16:30 | 0d | 10.31d | 0d |  |  |  |  |
| 45 | 6 | **Evaluation and Close Out Phase** |  | 4.88d | 2020-02-07 16:30 | 2020-02-14 15:30 |  | 2020-02-07 16:30 | 2020-02-14 15:30 | 4.88d | 10.31d |  |  | 75h | 2,047.12 | 2,047.12 |
| 46 | 6.1 | Assess Project Success |  | 4d | 2020-02-07 16:30 | 2020-02-13 16:30 | 44 | 2020-02-07 16:30 | 2020-02-13 16:30 | 4d | 10.31d | 0d | Charlie Mejia; Ann Chung | 64h | 1,738.46 | 1,738.46 |
| 47 | 6.2 | Establish Maintenance Schedule |  | 5h | 2020-02-13 16:30 | 2020-02-14 13:30 | 46 | 2020-02-13 16:30 | 2020-02-14 13:30 | 5h | 10.31d | 0d | Maintenance | 5h | 200 | 200 |
| 48 | 6.3 | Review Meeting - Successes and Improvements Needed |  | 2h | 2020-02-14 13:30 | 2020-02-14 15:30 | 47 | 2020-02-14 13:30 | 2020-02-14 15:30 | 2h | 10.31d | 0d | Ann Chung; Charlie Mejia; Informations Technology Systems | 6h | 108.65 | 108.65 |
| 49 | 6.4 | Evaluation and Closeout Phase Complete | milestone | 0d | 2020-02-14 15:30 | 2020-02-14 15:30 | 48 | 2020-02-14 15:30 | 2020-02-14 15:30 | 0d | 10.31d | 0d |  |  |  |  |
| 50 | 7 | JT Network Upgrades Complete | milestone | 0d | 2020-02-14 15:30 | 2020-02-14 15:30 | 49 | 2020-02-14 15:30 | 2020-02-14 15:30 | 0d | 10.31d |  |  |  |  |  |
