# JT Network Upgrades

Schedule from MS Project, 2019-11-15 to 2020-03-04.
Java Tucana

## Calendars

- Java Tucana Admin: Mon-Fri 08:00-12:00, 13:00-17:00; Sat-Sun off. Exceptions (off unless hours are given): 2017-07-04 to 2022-07-04 (Jul 4th Holiday, recurring).

## Resources

| Resource | Group |
| --- | --- |
| Charlie Mejia | Admin |
| Ann Chung | IT |
| Ron Sova | Marketing |
| Rick Herrera | Projects |
| Dorothy Windle | Call Center |
| Call Center Day Analysts | Call Center |
| Juan Silva | Internet Sales Center |
| Internet Sales Day Operators | Internet Sales Center |
| Maintenance | Maintenance |
| Network Heroes | Contract |
| Extreme Designs | Contract |
| Laura Lynn | Admin |
| Administration Services | Admin |
| Informations Technology Systems | IT |

## Schedule

| ID | WBS | Task | Type | Duration | Start | Finish | Predecessors | Total slack | Constraint | Resources | Work |
| --- | --- | --- | --- | --- | --- | --- | --- | --- | --- | --- | --- |
| 1 | 1 | **Project Status Meetings** |  | 75.12d | 2019-11-18 08:00 | 2020-03-02 09:00 |  | 2.19d |  |  |  |
| 2 | 1.1 | Project Status Meetings 1 |  | 1h | 2019-11-18 08:00 | 2019-11-18 09:00 |  | 77.19d | start no earlier than 2019-11-18 08:00 |  |  |
| 3 | 1.2 | Project Status Meetings 2 |  | 1h | 2019-11-25 08:00 | 2019-11-25 09:00 |  | 72.19d | start no earlier than 2019-11-25 08:00 |  |  |
| 4 | 1.3 | Project Status Meetings 3 |  | 1h | 2019-12-02 08:00 | 2019-12-02 09:00 |  | 67.19d | start no earlier than 2019-12-02 08:00 |  |  |
| 5 | 1.4 | Project Status Meetings 4 |  | 1h | 2019-12-09 08:00 | 2019-12-09 09:00 |  | 62.19d | start no earlier than 2019-12-09 08:00 |  |  |
| 6 | 1.5 | Project Status Meetings 5 |  | 1h | 2019-12-16 08:00 | 2019-12-16 09:00 |  | 57.19d | start no earlier than 2019-12-16 08:00 |  |  |
| 7 | 1.6 | Project Status Meetings 6 |  | 1h | 2019-12-23 08:00 | 2019-12-23 09:00 |  | 52.19d | start no earlier than 2019-12-23 08:00 |  |  |
| 8 | 1.7 | Project Status Meetings 7 |  | 1h | 2019-12-30 08:00 | 2019-12-30 09:00 |  | 47.19d | start no earlier than 2019-12-30 08:00 |  |  |
| 9 | 1.8 | Project Status Meetings 8 |  | 1h | 2020-01-06 08:00 | 2020-01-06 09:00 |  | 42.19d | start no earlier than 2020-01-06 08:00 |  |  |
| 10 | 1.9 | Project Status Meetings 9 |  | 1h | 2020-01-13 08:00 | 2020-01-13 09:00 |  | 37.19d | start no earlier than 2020-01-13 08:00 |  |  |
| 11 | 1.10 | Project Status Meetings 10 |  | 1h | 2020-01-20 08:00 | 2020-01-20 09:00 |  | 32.19d | start no earlier than 2020-01-20 08:00 |  |  |
| 12 | 1.11 | Project Status Meetings 11 |  | 1h | 2020-01-27 08:00 | 2020-01-27 09:00 |  | 27.19d | start no earlier than 2020-01-27 08:00 |  |  |
| 13 | 1.12 | Project Status Meetings 12 |  | 1h | 2020-02-03 08:00 | 2020-02-03 09:00 |  | 22.19d | start no earlier than 2020-02-03 08:00 |  |  |
| 14 | 1.13 | Project Status Meetings 13 |  | 1h | 2020-02-10 08:00 | 2020-02-10 09:00 |  | 17.19d | start no earlier than 2020-02-10 08:00 |  |  |
| 15 | 1.14 | Project Status Meetings 14 |  | 1h | 2020-02-17 08:00 | 2020-02-17 09:00 |  | 12.19d | start no earlier than 2020-02-17 08:00 |  |  |
| 16 | 1.15 | Project Status Meetings 15 |  | 1h | 2020-02-24 08:00 | 2020-02-24 09:00 |  | 7.19d | start no earlier than 2020-02-24 08:00 |  |  |
| 17 | 1.16 | Project Status Meetings 16 |  | 1h | 2020-03-02 08:00 | 2020-03-02 09:00 |  | 2.19d | start no earlier than 2020-03-02 08:00 |  |  |
| 18 | 2 | **Planning Phase** |  | 36.5d | 2019-11-15 08:00 | 2020-01-06 12:00 |  | 0d |  |  | 372h |
| 19 | 2.1 | Document Current Environment |  | 4d | 2019-11-15 08:00 | 2019-11-20 17:00 |  | 0d |  | Ann Chung | 32h |
| 20 | 2.2 | Conduct Needs Analysis |  | 2w | 2019-11-21 08:00 | 2019-12-04 17:00 | 19 | 0d |  | Ron Sova; Charlie Mejia | 160h |
| 21 | 2.3 | Identify Hardware, Software,Equipment, and Supplies Required |  | 4h | 2019-12-05 08:00 | 2019-12-05 12:00 | 20 | 0d |  | Ann Chung | 4h |
| 22 | 2.4 | Create Request for Proposal and Timeline |  | 4d | 2019-12-05 13:00 | 2019-12-11 12:00 | 21 | 0d |  | Charlie Mejia | 32h |
| 23 | 2.5 | Gather Vendor Bids |  | 2w | 2019-12-11 13:00 | 2019-12-25 12:00 | 22 | 0d |  | Dorothy Windle | 80h |
| 24 | 2.6 | Choose Vendors |  | 1w | 2019-12-25 13:00 | 2020-01-01 12:00 | 23 | 0d |  | Charlie Mejia | 40h |
| 25 | 2.7 | Sign Contracts |  | 3d | 2020-01-01 13:00 | 2020-01-06 12:00 | 24 | 0d |  | Charlie Mejia | 24h |
| 26 | 2.8 | Planning Phase Complete | milestone | 0d | 2020-01-06 12:00 | 2020-01-06 12:00 | 25 | 0d |  |  |  |

| ID | WBS | Task | Type | Duration | Start | Finish | Predecessors | Total slack | Resources | Work |
| --- | --- | --- | --- | --- | --- | --- | --- | --- | --- | --- |
| 27 | 3 | **Procurement Phase** |  | 20.5d | 2020-01-06 13:00 | 2020-02-03 17:00 |  | 0d |  | 164h |
| 28 | 3.1 | Order Hardware Components |  | 7.5d | 2020-01-06 13:00 | 2020-01-15 17:00 | 26 | 0d | Juan Silva | 60h |
| 29 | 3.2 | Order Infustructure Components |  | 11d | 2020-01-16 08:00 | 2020-01-30 17:00 | 28 | 0d | Juan Silva | 88h |
| 30 | 3.3 | Purchase Software Licenses |  | 1d | 2020-01-31 08:00 | 2020-01-31 17:00 | 29 | 0d | Juan Silva | 8h |
| 31 | 3.4 | Identify Additional Needed Components and Order |  | 1d | 2020-02-03 08:00 | 2020-02-03 17:00 | 30 | 0d | Juan Silva | 8h |
| 32 | 3.5 | Procurement Phase Complete | milestone | 0d | 2020-02-03 17:00 | 2020-02-03 17:00 | 31 | 0d |  |  |
| 33 | 4 | **Installation and Testing Phase** |  | 10d | 2020-02-04 08:00 | 2020-02-17 17:00 |  | 0d |  | 160h |
| 34 | 4.1 | Install Cabling |  | 2w | 2020-02-04 08:00 | 2020-02-17 17:00 | 32 | 0d | Network Heroes | 80h |
| 35 | 4.2 | Install Hardware |  | 1w | 2020-02-04 08:00 | 2020-02-10 17:00 | 34SS | 0d | Network Heroes | 40h |
| 36 | 4.3 | Install Software |  | 3d | 2020-02-11 08:00 | 2020-02-13 17:00 | 35 | 0d | Network Heroes | 24h |
| 37 | 4.4 | Test Network |  | 2d | 2020-02-14 08:00 | 2020-02-17 17:00 | 36 | 0d | Network Heroes | 16h |
| 38 | 4.5 | Installation and Testing Phase Complete | milestone | 0d | 2020-02-17 17:00 | 2020-02-17 17:00 | 37 | 0d |  |  |
| 39 | 5 | **Training and Communication Phase** |  | 6.44d | 2020-02-18 08:00 | 2020-02-26 11:30 |  | 0d |  | 51.5h |
| 40 | 5.1 | Communicate Information Updates |  | 3h | 2020-02-18 08:00 | 2020-02-18 11:00 | 38 | 0d | Charlie Mejia | 3h |
| 41 | 5.2 | Communicate "Go Live" Date |  | 0.5h | 2020-02-18 11:00 | 2020-02-18 11:30 | 40 | 0d | Ann Chung | 0.5h |
| 42 | 5.3 | Train Management |  | 3d | 2020-02-18 11:30 | 2020-02-21 11:30 | 41 | 0d | Informations Technology Systems | 24h |
| 43 | 5.4 | Train Users |  | 3d | 2020-02-21 11:30 | 2020-02-26 11:30 | 42 | 0d | Informations Technology Systems | 24h |
| 44 | 5.5 | Traning and Communication Phase Complete | milestone | 0d | 2020-02-26 11:30 | 2020-02-26 11:30 | 43 | 0d |  |  |
| 45 | 6 | **Evaluation and Close Out Phase** |  | 4.88d | 2020-02-26 11:30 | 2020-03-04 10:30 |  | 0d |  | 75h |
| 46 | 6.1 | Assess Project Success |  | 4d | 2020-02-26 11:30 | 2020-03-03 11:30 | 44 | 0d | Charlie Mejia; Ann Chung | 64h |
| 47 | 6.2 | Establish Maintenance Schedule |  | 5h | 2020-03-03 11:30 | 2020-03-04 08:30 | 46 | 0d | Maintenance | 5h |
| 48 | 6.3 | Review Meeting - Successes and Improvements Needed |  | 2h | 2020-03-04 08:30 | 2020-03-04 10:30 | 47 | 0d | Ann Chung; Charlie Mejia; Informations Technology Systems | 6h |
| 49 | 6.4 | Evaluation and Closeout Phase Complete | milestone | 0d | 2020-03-04 10:30 | 2020-03-04 10:30 | 48 | 0d |  |  |
| 50 | 7 | JT Network Upgrades Complete | milestone | 0d | 2020-03-04 10:30 | 2020-03-04 10:30 | 49 | 0d |  |  |
