# Asbestos Abatement Encapsulation JT Processing Facilities

Schedule from MS Project, 2018-11-01 to 2019-08-05, status date 2018-12-18, costs in $, A marks actual dates.
Java Tucana

## Calendars

- Java Tucana Admin: Mon-Fri 08:00-12:00, 13:00-17:00; Sat-Sun off. Exceptions (off unless hours are given): 2017-07-04 to 2022-07-04 (Jul 4th Holiday, recurring).

## Resources

| Resource | Group | Unit | Rate |
| --- | --- | --- | --- |
| Charlie Mejia | Admin |  | 27.4 |
| Ann Chung | IT |  | 26.92 |
| Ron Sova | Marketing |  | 25 |
| Rick Herrera | Projects |  | 25.48 |
| Dorothy Windle | Call Center |  | 32 |
| Call Center Day Analysts | Call Center |  | 15 |
| Juan Silva | Internet Sales Center |  | 32 |
| Internet Sales Day Operators | Internet Sales Center |  | 15 |
| Maintenance | Maintenance |  | 40 |
| Network Heroes | Contract |  |  |
| Extreme Designs | Contract |  |  |
| Environmental Wizards | Contract |  |  |
| Asbestos Abatement Budget Cost | Cost |  |  |
| Asbestos Abatement Budget Work | Cost |  |  |
| Asbestos Abatement Plastic Sheeting | Cost | Per Yard |  |

## Schedule

| ID | WBS | Task | Type | Duration | Start | Finish | Predecessors | Complete | Baseline start | Baseline finish | Baseline duration | Baseline 1 start | Baseline 1 finish | Deadline | Resources | Work | Actual work | Cost | Baseline cost | Actual cost | Text1 | Text2 |
| --- | --- | --- | --- | --- | --- | --- | --- | --- | --- | --- | --- | --- | --- | --- | --- | --- | --- | --- | --- | --- | --- | --- |
| 1 | 1 | Notice to Proceed from JT CEO, JT CFO |  | 5d | 2018-11-01 A | 2018-11-07 A |  | 100% | 2018-11-01 | 2018-11-07 | 5d | 2018-11-01 | 2018-11-07 |  | Charlie Mejia | 40h | 40h | 1,096.15 | 1,096.15 | 1,096.15 | Z1010.01 | 01.01.01 |
| 2 | 2 | Project Award to High (best) Bid Contractor | milestone | 0d | 2018-11-07 A | 2018-11-07 A | 1 | 100% | 2018-11-07 | 2018-11-07 | 0d | 2018-11-07 | 2018-11-07 |  | Charlie Mejia |  |  |  |  |  | Z1010.01 | 01.01.01 |
| 3 | 3 | **General Requirements (Start-up)** |  | 70d | 2018-11-01 A | 2019-02-06 A |  | 100% | 2018-11-01 | 2019-01-28 | 63d | 2018-11-01 | 2019-01-28 |  |  | 1264h | 1264h | 43,187.69 | 43,187.69 | 43,187.69 |  |  |
| 4 | 3.1 | General Requirements (Start-up) Insurance & Bonds |  | 1d | 2018-11-08 A | 2018-11-08 A | 2 | 100% | 2018-11-08 | 2018-11-08 | 1d | 2018-11-08 | 2018-11-08 |  | Ann Chung; Charlie Mejia | 16h | 16h | 434.62 | 434.62 | 434.62 | Z1050.02, .03 | 01.01.01 |
| 5 | 2.1 | Post Award Site Survey |  | 5d | 2018-11-09 A | 2018-11-15 A | 4 | 100% | 2018-11-09 | 2018-11-15 | 5d | 2018-11-09 | 2018-11-15 |  | Dorothy Windle; Charlie Mejia | 80h | 80h | 6,376.15 | 6,376.15 | 6,376.15 |  |  |
| 6 | 2.2 | DRAFT Work Plan |  | 35d | 2018-11-01 A | 2018-12-19 A | 5FF | 100% | 2018-11-01 | 2018-12-12 | 30d | 2018-11-01 | 2018-12-12 |  | Juan Silva; Dorothy Windle | 480h | 480h | 15,360 | 15,360 | 15,360 |  |  |
| 7 | 2.4 | EPA Review |  | 14d | 2018-11-01 A | 2018-11-20 A |  | 100% | 2018-11-01 | 2018-11-20 | 14d | 2018-11-01 | 2018-11-20 |  | Rick Herrera | 112h | 112h | 2,853.85 | 2,853.85 | 2,853.85 |  |  |
| 8 | 2.5 | Finalize Final Work Plan |  | 19d | 2018-11-16 A | 2018-12-10 A | 7FS-3d | 100% | 2018-11-16 | 2018-12-05 | 16d | 2018-11-16 | 2018-12-05 |  | Charlie Mejia; Rick Herrera | 224h | 224h | 5,923.08 | 5,923.08 | 5,923.08 |  |  |
| 9 | 2.6 | Submit Final Work Plan |  | 1d | 2018-12-11 A | 2018-12-11 A | 8 | 100% | 2018-12-06 | 2018-12-06 | 1d | 2018-12-06 | 2018-12-06 | 2018-12-06 | Ron Sova | 8h | 8h | 200 | 200 | 200 |  |  |
| 10 | 2.7 | EPA Approval |  | 11d | 2018-12-17 A | 2018-12-31 A | 9 | 100% | 2018-12-07 | 2018-12-20 | 10d | 2018-12-07 | 2018-12-20 |  |  |  |  |  |  |  |  |  |
| 11 | 2.12 | Local Government Review/Approval of Local Submittals |  | 10d | 2019-01-01 A | 2019-01-14 A | 10 | 100% | 2018-12-21 | 2019-01-03 | 10d | 2018-12-21 | 2019-01-03 |  | Ron Sova; Charlie Mejia | 160h | 160h | 4,192.31 | 4,192.31 | 4,192.31 |  |  |
| 12 | 3 | Procure/Fabrication/Transportation/Arrival of Local Equipment |  | 10d | 2019-01-15 A | 2019-01-28 A | 11 | 100% | 2019-01-04 | 2019-01-17 | 10d | 2019-01-04 | 2019-01-17 |  | Maintenance | 80h | 80h | 3,200 | 3,200 | 3,200 |  |  |
| 13 | 3.10 | General Requirements (Start-up) Administration Complete | milestone | 0d | 2019-01-28 A | 2019-01-28 A | 12 | 100% | 2019-01-17 | 2019-01-17 | 0d | 2019-01-17 | 2019-01-17 |  |  |  |  |  |  |  |  | 01.02.02 |
| 14 | 3.11 | **General Requirements (Start-up) Temporary Facilities & Mobilization** |  | 7d | 2019-01-29 A | 2019-02-06 A |  | 100% | 2019-01-18 | 2019-01-28 | 7d | 2019-01-18 | 2019-01-28 |  |  | 104h | 104h | 4,647.69 | 4,647.69 | 4,647.69 |  | 01.01.02 |
| 15 | 3.11.1 | Temporary Staging Facilities/Laydown Yard |  | 4d | 2019-01-29 A | 2019-02-01 A | 13 | 100% | 2019-01-18 | 2019-01-23 | 4d | 2019-01-18 | 2019-01-23 |  | Environmental Wizards | 32h | 32h | 2,000 | 2,000 | 2,000 | Z1030.02 | 01.01.02 |
| 16 | 3.11.2 | Temporary Site Access & Parking |  | 2d | 2019-01-29 A | 2019-01-30 A | 15SS | 100% | 2019-01-18 | 2019-01-21 | 2d | 2019-01-18 | 2019-01-21 |  | Rick Herrera | 16h | 16h | 407.69 | 407.69 | 407.69 | Z1030.04 | 01.01.02 |
| 17 | 3.11.3 | General Requirements (Start-up) Permits |  | 7d | 2019-01-29 A | 2019-02-06 A | 16SS | 100% | 2019-01-18 | 2019-01-28 | 7d | 2019-01-18 | 2019-01-28 |  | Maintenance | 56h | 56h | 2,240 | 2,240 | 2,240 | Z1050.01 | 01.01.02 |
| 18 | 3.11.4 | General Requirements (Start-up) Temporary Facilities & Mobilization Complete | milestone | 0d | 2019-02-06 A | 2019-02-06 A | 17 | 100% | 2019-01-28 | 2019-01-28 | 0d | 2019-01-28 | 2019-01-28 |  |  |  |  |  |  |  |  | 01.01.02 |
| 19 | 3.12 | General Requirements (Start-up) Complete | milestone | 0d | 2019-02-06 A | 2019-02-06 A | 18 | 100% | 2019-01-28 | 2019-01-28 | 0d | 2019-01-28 | 2019-01-28 |  |  |  |  |  |  |  |  |  |
| 20 | 4 | Field Project Management & Supervision |  | 124d | 2019-02-04 A | 2019-07-26 A | 15 | 100% | 2019-01-24 | 2019-07-17 | 124d | 2019-01-24 | 2019-07-17 |  |  |  |  |  |  |  | Z1010.02 | 01.01.03 |
| 21 | 5 | **Field Work- Asbestos Inspection, Abatement and Encapsulation** |  | 85d | 2019-02-07 A | 2019-06-05 A |  | 100% | 2019-01-29 | 2019-05-27 | 85d | 2019-01-29 | 2019-05-27 |  |  | 680h | 680h | 27,000 | 27,000 | 27,000 |  |  |
| 22 | 5.1 | Abate and Encapsulate Processing Facility 1 |  | 30d | 2019-02-07 A | 2019-03-20 A | 19 | 100% | 2019-01-29 | 2019-03-11 | 30d | 2019-01-29 | 2019-03-11 |  | Environmental Wizards | 240h | 240h | 27,000 | 27,000 | 27,000 |  |  |
| 23 | 5.2 | Mobilization to Processing Facility 2 |  | 5d | 2019-03-21 A | 2019-03-27 A | 22 | 100% | 2019-03-12 | 2019-03-18 | 5d | 2019-03-12 | 2019-03-18 |  | Environmental Wizards | 40h | 40h |  |  |  |  |  |
| 24 | 5.3 | Abate and Encapsulate Processing Facility 2 |  | 50d | 2019-03-28 A | 2019-06-05 A | 23 | 100% | 2019-03-19 | 2019-05-27 | 50d | 2019-03-19 | 2019-05-27 |  | Environmental Wizards | 400h | 400h |  |  |  |  |  |
| 25 | 5.4 | Field Work- Asbestos Inspection, Abatement and Encapsulation Complete | milestone | 0d | 2019-06-05 A | 2019-06-05 A | 24 | 100% | 2019-05-27 | 2019-05-27 | 0d | 2019-05-27 | 2019-05-27 |  |  |  |  |  |  |  |  |  |

Notes:
- 10: Took longer than planned due to holidays. Make sure to schedule more time in future project schedules if task is near major holidays.

| ID | WBS | Task | Type | Duration | Start | Finish | Predecessors | Complete | Baseline start | Baseline finish | Baseline duration | Baseline 1 start | Baseline 1 finish | Resources | Work | Actual work | Cost | Baseline cost | Actual cost |
| --- | --- | --- | --- | --- | --- | --- | --- | --- | --- | --- | --- | --- | --- | --- | --- | --- | --- | --- | --- |
| 26 | 6 | **Project Closeout** |  | 42d | 2019-06-06 A | 2019-08-05 A |  | 100% | 2019-05-28 | 2019-07-25 | 42d | 2019-05-28 | 2019-07-25 |  | 336h | 336h | 16,276.92 | 16,276.92 | 16,276.92 |
| 27 | 6.1 | Demobilization/Cleanup/Restoration |  | 2d | 2019-06-06 A | 2019-06-07 A | 25 | 100% | 2019-05-28 | 2019-05-29 | 2d | 2019-05-28 | 2019-05-29 | Environmental Wizards | 16h | 16h | 6,500 | 6,500 | 6,500 |
| 28 | 6.2 | Post Fieldwork Inspection / Documentation |  | 10d | 2019-06-10 A | 2019-06-21 A | 27 | 100% | 2019-05-30 | 2019-06-12 | 10d | 2019-05-30 | 2019-06-12 | Maintenance | 80h | 80h | 3,200 | 3,200 | 3,200 |
| 29 | 6.3 | Final Report |  | 30d | 2019-06-24 A | 2019-08-05 A | 28 | 100% | 2019-06-13 | 2019-07-25 | 30d | 2019-06-13 | 2019-07-25 | Charlie Mejia | 240h | 240h | 6,576.92 | 6,576.92 | 6,576.92 |
| 30 | 6.4 | Closeout Complete | milestone | 0d | 2019-08-05 A | 2019-08-05 A | 29 | 100% | 2019-07-25 | 2019-07-25 | 0d | 2019-07-25 | 2019-07-25 |  |  |  |  |  |  |
| 31 | 6.5 | Asbestos Abatement Encapsulation JT Processing Facilities Complete | milestone | 0d | 2019-08-05 A | 2019-08-05 A | 30, 20 | 100% | 2019-07-25 | 2019-07-25 | 0d | 2019-07-25 | 2019-07-25 |  |  |  |  |  |  |
