# JT Network Upgrades

Schedule from MS Project, 2019-12-02 to 2020-03-19.
Java Tucana

## Calendars

- Java Tucana Admin: Mon-Fri 08:00-12:00, 13:00-17:00; Sat-Sun off. Exceptions (off unless hours are given): 2017-07-04 to 2022-07-04 (Jul 4th Holiday, recurring), 2017-11-23 to 2021-11-25 (Thanksgiving, recurring), 2017-12-25 to 2021-12-25 (Christmas, recurring), 2018-01-01 to 2022-01-01 (New Year's Day, recurring).

## Schedule

| ID | WBS | Task | Type | Duration | Start | Finish | Predecessors | Total slack | Free slack | Constraint |
| --- | --- | --- | --- | --- | --- | --- | --- | --- | --- | --- |
| 1 | 1 | **Project Status Meetings** |  | 73.12d | 2019-12-05 08:00 | 2020-03-19 09:00 |  | 0d |  |  |
| 2 | 1.1 | Project Status Meetings 1 |  | 1h | 2019-12-05 08:00 | 2019-12-05 09:00 |  | 73d |  | start no earlier than 2019-12-05 08:00 |
| 3 | 1.2 | Project Status Meetings 2 |  | 1h | 2019-12-12 08:00 | 2019-12-12 09:00 |  | 68d |  | start no earlier than 2019-12-12 08:00 |
| 4 | 1.3 | Project Status Meetings 3 |  | 1h | 2019-12-19 08:00 | 2019-12-19 09:00 |  | 63d |  | start no earlier than 2019-12-19 08:00 |
| 5 | 1.4 | Project Status Meetings 4 |  | 1h | 2019-12-26 08:00 | 2019-12-26 09:00 |  | 59d |  | start no earlier than 2019-12-26 08:00 |
| 6 | 1.5 | Project Status Meetings 5 |  | 1h | 2020-01-02 08:00 | 2020-01-02 09:00 |  | 55d |  | start no earlier than 2020-01-02 08:00 |
| 7 | 1.6 | Project Status Meetings 6 |  | 1h | 2020-01-09 08:00 | 2020-01-09 09:00 |  | 50d |  | start no earlier than 2020-01-09 08:00 |
| 8 | 1.7 | Project Status Meetings 7 |  | 1h | 2020-01-16 08:00 | 2020-01-16 09:00 |  | 45d |  | start no earlier than 2020-01-16 08:00 |
| 9 | 1.8 | Project Status Meetings 8 |  | 1h | 2020-01-23 08:00 | 2020-01-23 09:00 |  | 40d |  | start no earlier than 2020-01-23 08:00 |
| 10 | 1.9 | Project Status Meetings 9 |  | 1h | 2020-01-30 08:00 | 2020-01-30 09:00 |  | 35d |  | start no earlier than 2020-01-30 08:00 |
| 11 | 1.10 | Project Status Meetings 10 |  | 1h | 2020-02-06 08:00 | 2020-02-06 09:00 |  | 30d |  | start no earlier than 2020-02-06 08:00 |
| 12 | 1.11 | Project Status Meetings 11 |  | 1h | 2020-02-13 08:00 | 2020-02-13 09:00 |  | 25d |  | start no earlier than 2020-02-13 08:00 |
| 13 | 1.12 | Project Status Meetings 12 |  | 1h | 2020-02-20 08:00 | 2020-02-20 09:00 |  | 20d |  | start no earlier than 2020-02-20 08:00 |
| 14 | 1.13 | Project Status Meetings 13 |  | 1h | 2020-02-27 08:00 | 2020-02-27 09:00 |  | 15d |  | start no earlier than 2020-02-27 08:00 |
| 15 | 1.14 | Project Status Meetings 14 |  | 1h | 2020-03-05 08:00 | 2020-03-05 09:00 |  | 10d |  | start no earlier than 2020-03-05 08:00 |
| 16 | 1.15 | Project Status Meetings 15 |  | 1h | 2020-03-12 08:00 | 2020-03-12 09:00 |  | 5d |  | start no earlier than 2020-03-12 08:00 |
| 17 | 1.16 | Project Status Meetings 16 |  | 1h | 2020-03-19 08:00 | 2020-03-19 09:00 |  | 0d |  | start no earlier than 2020-03-19 08:00 |
| 18 | 2 | **Planning Phase** |  | 36.5d | 2019-12-02 08:00 | 2020-01-23 12:00 |  | 6.5d |  |  |
| 19 | 2.1 | Document Current Environment |  | 4d | 2019-12-02 08:00 | 2019-12-05 17:00 |  | 6.5d | 0d |  |
| 20 | 2.2 | Conduct Needs Analysis |  | 2w | 2019-12-06 08:00 | 2019-12-19 17:00 | 19 | 6.5d | 0d |  |
| 21 | 2.3 | Identify Hardware, Software,Equipment, and Supplies Required |  | 4h | 2019-12-20 08:00 | 2019-12-20 12:00 | 20 | 6.5d | 0d |  |
| 22 | 2.4 | Create Request for Proposal and Timeline |  | 4d | 2019-12-20 13:00 | 2019-12-27 12:00 | 21 | 6.5d | 0d |  |
| 23 | 2.5 | Gather Vendor Bids |  | 2w | 2019-12-27 13:00 | 2020-01-13 12:00 | 22 | 6.5d | 0d |  |
| 24 | 2.6 | Choose Vendors |  | 1w | 2020-01-13 13:00 | 2020-01-20 12:00 | 23 | 6.5d | 0d |  |
| 25 | 2.7 | Sign Contracts |  | 3d | 2020-01-20 13:00 | 2020-01-23 12:00 | 24 | 6.5d | 0d |  |
| 26 | 2.8 | Planning Phase Complete | milestone | 0d | 2020-01-23 12:00 | 2020-01-23 12:00 | 25 | 6.5d | 0d |  |

| ID | WBS | Task | Type | Duration | Start | Finish | Predecessors | Total slack | Free slack | Constraint |
| --- | --- | --- | --- | --- | --- | --- | --- | --- | --- | --- |
| 27 | 3 | **Procurement Phase** |  | 8d | 2020-01-23 13:00 | 2020-02-04 12:00 |  | 6.5d |  |  |
| 28 | 3.1 | Order Hardware Components |  | 3d | 2020-01-23 13:00 | 2020-01-28 12:00 | 26 | 6.5d | 0d |  |
| 29 | 3.2 | Order Infustructure Components |  | 3d | 2020-01-28 13:00 | 2020-01-31 12:00 | 28 | 6.5d | 0d |  |
| 30 | 3.3 | Purchase Software Licenses |  | 1d | 2020-01-31 13:00 | 2020-02-03 12:00 | 29 | 6.5d | 0d |  |
| 31 | 3.4 | Identify Additional Needed Components and Order |  | 1d | 2020-02-03 13:00 | 2020-02-04 12:00 | 30 | 6.5d | 0d |  |
| 32 | 3.5 | Procurement Phase Complete | milestone | 0d | 2020-02-04 12:00 | 2020-02-04 12:00 | 31 | 6.5d | 0.5d |  |
| 33 | 4 | **Installation and Testing Phase** |  | 14d | 2020-02-10 08:00 | 2020-02-27 17:00 |  | 2.81d |  |  |
| 34 | 4.1 | Install Cabling |  | 2w | 2020-02-10 08:00 | 2020-02-21 17:00 | 32FS+5ed | 6d | 5d |  |
| 35 | 4.2 | Install Hardware |  | 1w | 2020-02-17 08:00 | 2020-02-21 17:00 | 34SS+5e% | 2.44d | 0d | start no earlier than 2020-02-15 08:00 |
| 36 | 4.3 | Install Software |  | 3d | 2020-02-21 08:00 | 2020-02-25 17:00 | 35FS-5e% | 2.81d | 0d |  |
| 37 | 4.4 | Test Network |  | 2d | 2020-02-26 08:00 | 2020-02-27 17:00 | 36 | 2.81d | 0d |  |
| 38 | 4.5 | Installation and Testing Phase Complete | milestone | 0d | 2020-02-27 17:00 | 2020-02-27 17:00 | 37 | 2.81d | 0d |  |
| 39 | 5 | **Training and Communication Phase** |  | 6.44d | 2020-02-28 08:00 | 2020-03-09 11:30 |  | 2.81d |  |  |
| 40 | 5.1 | Communicate Information Updates |  | 3h | 2020-02-28 08:00 | 2020-02-28 11:00 | 38 | 2.81d | 0d |  |
| 41 | 5.2 | Communicate "Go Live" Date |  | 0.5h | 2020-02-28 11:00 | 2020-02-28 11:30 | 40 | 2.81d | 0d |  |
| 42 | 5.3 | Train Management |  | 3d | 2020-02-28 11:30 | 2020-03-04 11:30 | 41 | 2.81d | 0d |  |
| 43 | 5.4 | Train Users |  | 3d | 2020-03-04 11:30 | 2020-03-09 11:30 | 42 | 2.81d | 0d |  |
| 44 | 5.5 | Traning and Communication Phase Complete | milestone | 0d | 2020-03-09 11:30 | 2020-03-09 11:30 | 43 | 2.81d | 0d |  |
| 45 | 6 | **Evaluation and Close Out Phase** |  | 4.88d | 2020-03-09 11:30 | 2020-03-16 10:30 |  | 2.81d |  |  |
| 46 | 6.1 | Assess Project Success |  | 4d | 2020-03-09 11:30 | 2020-03-13 11:30 | 44 | 2.81d | 0d |  |
| 47 | 6.2 | Establish Maintenance Schedule |  | 5h | 2020-03-13 11:30 | 2020-03-16 08:30 | 46 | 2.81d | 0d |  |
| 48 | 6.3 | Review Meeting - Successes and Improvements Needed |  | 2h | 2020-03-16 08:30 | 2020-03-16 10:30 | 47 | 2.81d | 0d |  |
| 49 | 6.4 | Evaluation and Closeout Phase Complete | milestone | 0d | 2020-03-16 10:30 | 2020-03-16 10:30 | 48 | 2.81d | 0d |  |
| 50 | 7 | JT Network Upgrades Complete | milestone | 0d | 2020-03-16 10:30 | 2020-03-16 10:30 | 49 | 2.81d |  | finish no later than 2020-03-21 14:30 |
