# JT Corporate Move

Schedule from MS Project, 2019-07-01 to 2019-12-03, costs in $.
Refurbish New Offices and Move
Java Tucana

## Calendars

- Java Tucana Admin: Mon-Fri 08:00-12:00, 13:00-17:00; Sat-Sun off. Exceptions (off unless hours are given): 2017-07-04 to 2022-07-04 (Jul 4th Holiday, recurring).

## Resources

| Resource | Group | Rate |
| --- | --- | --- |
| Charlie Mejia | Admin | 27.4 |
| Ann Chung | IT | 26.92 |
| Ron Sova | Marketing | 25 |
| Rick Herrera | Projects | 25.48 |
| Dorothy Windle | Call Center | 32 |
| Call Center Day Analysts | Call Center | 15 |
| Juan Silva | Internet Sales Center | 32 |
| Internet Sales Day Operators | Internet Sales Center | 15 |
| Maintenance | Maintenance | 40 |
| Network Heroes | Contract |  |
| Extreme Designs | Contract |  |
| Laura Lynn | Admin | 22.6 |
| Administration Services | Admin |  |
| Informations Technology Systems | IT |  |

## Schedule

| ID | WBS | Task | Type | Duration | Start | Finish | Predecessors | Total slack | Free slack | Constraint | Resources | Work | Cost |
| --- | --- | --- | --- | --- | --- | --- | --- | --- | --- | --- | --- | --- | --- |
| 1 | 1 | **JT Move Status Meetings** |  | 10.12d | 2019-07-05 | 2019-07-19 |  | 97.38d |  |  |  |  |  |
| 2 | 1.1 | JT Move Status Meetings 1 |  | 1h | 2019-07-05 | 2019-07-05 |  | 107.38d |  | start no earlier than 2019-07-05 |  |  |  |
| 3 | 1.2 | JT Move Status Meetings 2 |  | 1h | 2019-07-12 | 2019-07-12 |  | 102.38d |  | start no earlier than 2019-07-12 |  |  |  |
| 4 | 1.3 | JT Move Status Meetings 3 |  | 1h | 2019-07-19 | 2019-07-19 |  | 97.38d |  | start no earlier than 2019-07-19 |  |  |  |
| 5 | 2 | **Planning the Move** |  | 49.38d | 2019-07-01 | 2019-09-09 |  | 2.62d |  |  |  | 796h | 12,957.08 |
| 6 | 2.1 | Identify Move Team Members |  | 2d | 2019-07-01 | 2019-07-02 |  | 2.62d | 0d |  | Laura Lynn | 16h | 361.54 |
| 7 | 2.2 | Plan Infastructure Upgrades |  | 2w | 2019-07-03 | 2019-07-17 | 6 | 2.62d | 0d |  | Juan Silva | 80h | 2,560 |
| 8 | 2.3 | Plan IT Move |  | 2w | 2019-07-18 | 2019-07-31 | 7 | 2.62d | 0d |  | Charlie Mejia; Rick Herrera | 160h | 4,230.77 |
| 9 | 2.4 | Plan Physical Move |  | 2w | 2019-07-22 | 2019-08-05 | 8FS-7.5% | 2.62d | 0d |  | Charlie Mejia; Rick Herrera | 160h | 4,230.77 |
| 10 | 2.5 | Plan for Continous Operations During the Move |  | 4d | 2019-08-05 | 2019-08-09 | 9 | 2.62d | 0d |  | Dorothy Windle [50%]; Juan Silva [50%] | 32h | 1,024 |
| 11 | 2.6 | Obtain Estimates from Moving Services |  | 1w | 2019-08-09 | 2019-08-16 | 10 | 2.62d | 0d |  | Administration Services [200%] | 80h |  |
| 12 | 2.7 | Interview and Select Movers |  | 1w | 2019-08-16 | 2019-08-23 | 11 | 2.62d | 0d |  | Administration Services [200%] | 80h |  |
| 13 | 2.8 | Obtain Estimates from IT Installation Companies |  | 1w | 2019-08-16 | 2019-08-23 | 11 | 2.62d | 0d |  | Administration Services [200%] | 80h |  |
| 14 | 2.9 | Interview and Select IT Installation Company |  | 1w | 2019-08-23 | 2019-08-30 | 13, 12 | 2.62d | 0d |  | Administration Services [200%] | 80h |  |
| 15 | 2.10 | Order Boxes and Materials needed for the Move |  | 3h | 2019-08-30 | 2019-08-30 | 14 | 2.62d | 0d |  | Administration Services [200%] | 6h |  |
| 16 | 2.11 | Planning the Move Complete | milestone | 0d | 2019-08-30 | 2019-08-30 | 15 | 2.62d | 0d |  |  |  |  |
| 17 | 2.12 | **Communications** |  | 5.5d | 2019-08-30 | 2019-09-09 |  | 2.62d |  |  |  | 22h | 550 |
| 18 | 2.12.1 | Communicate Move Plan to Employees |  | 3d | 2019-08-30 | 2019-09-04 | 16 | 2.62d | 0d |  | Ron Sova [50%] | 12h | 300 |
| 19 | 2.12.2 | Gather Feedback From Employees |  | 2d | 2019-09-04 | 2019-09-06 | 18 | 2.62d | 0d |  | Ron Sova [50%] | 8h | 200 |
| 20 | 2.12.3 | Communicate Move Information to Suppliers |  | 2h | 2019-09-06 | 2019-09-09 | 19 | 2.62d | 0d |  | Ron Sova [50%] | 1h | 25 |
| 21 | 2.12.4 | Communicate Move Information to Customers |  | 2h | 2019-09-09 | 2019-09-09 | 20 | 2.62d | 0d |  | Ron Sova [50%] | 1h | 25 |
| 22 | 2.12.5 | Communications Complete | milestone | 0d | 2019-09-09 | 2019-09-09 | 21 | 2.62d | 0d |  |  |  |  |
| 23 | 3 | **JT Corporate Center Preparation** |  | 24d | 2019-09-09 | 2019-10-11 |  | 2.62d |  |  |  | 528h |  |
| 24 | 3.1 | **JT Call Center Refurbishing New Location** |  | 22d | 2019-09-09 | 2019-10-09 |  | 2.62d |  |  |  | 176h |  |
| 25 | 3.1.1 | Install Network Cables |  | 3d | 2019-09-09 | 2019-09-12 | 22 | 2.62d | 0d |  | Network Heroes | 24h |  |
| 26 | 3.1.2 | Install TeleCommunication Lines |  | 1w | 2019-09-12 | 2019-09-19 | 25 | 4.62d | 0d |  | Network Heroes | 40h |  |
| 27 | 3.1.3 | Paint the walls |  | 2d | 2019-09-19 | 2019-09-23 | 26 | 4.62d | 0d |  | Extreme Designs | 16h |  |
| 28 | 3.1.4 | Lay Carpet |  | 2d | 2019-09-24 | 2019-09-26 | 27FS+1ed | 4.62d | 0d |  | Extreme Designs | 16h |  |
| 29 | 3.1.5 | Install Partitions |  | 1d | 2019-09-26 | 2019-09-27 | 28 | 4.62d | 0d |  | Extreme Designs | 8h |  |
| 30 | 3.1.6 | Prepare Offices |  | 5d | 2019-09-27 | 2019-10-04 | 29 | 4.62d | 0d |  | Extreme Designs | 40h |  |
| 31 | 3.1.7 | Assemble Furniture |  | 2d | 2019-10-04 | 2019-10-08 | 30 | 4.62d | 0d |  | Extreme Designs | 16h |  |
| 32 | 3.1.8 | Hook up Computers |  | 1d | 2019-10-08 | 2019-10-09 | 31 | 4.62d | 0d |  | Network Heroes | 8h |  |
| 33 | 3.1.9 | Hook up Phones |  | 1d | 2019-10-08 | 2019-10-09 | 32FF | 4.62d | 0d |  | Network Heroes | 8h |  |
| 34 | 3.1.10 | JT Call Center Complete | milestone | 0d | 2019-10-09 | 2019-10-09 | 33 | 4.62d | 2d |  |  |  |  |

| ID | WBS | Task | Type | Duration | Start | Finish | Predecessors | Total slack | Free slack | Resources | Work |
| --- | --- | --- | --- | --- | --- | --- | --- | --- | --- | --- | --- |
| 35 | 3.2 | **JT Internet Sales Center Refurbishing New Location** |  | 24d | 2019-09-09 | 2019-10-11 |  | 2.62d |  |  | 176h |
| 36 | 3.2.1 | Install Network Cables |  | 3d | 2019-09-09 | 2019-09-12 | 25SS | 2.62d | 0d | Network Heroes | 24h |
| 37 | 3.2.2 | Install TeleCommunication Lines |  | 1w | 2019-09-12 | 2019-09-19 | 36 | 2.62d | 0d | Network Heroes | 40h |
| 38 | 3.2.3 | Paint the walls |  | 2d | 2019-09-19 | 2019-09-23 | 37 | 2.62d | 0d | Extreme Designs | 16h |
| 39 | 3.2.4 | Lay Carpet |  | 2d | 2019-09-24 | 2019-09-26 | 38FS+1ed | 2.62d | 0d | Extreme Designs | 16h |
| 40 | 3.2.5 | Install Partitions |  | 1d | 2019-09-26 | 2019-09-27 | 39 | 2.62d | 0d | Extreme Designs | 8h |
| 41 | 3.2.6 | Prepare Offices |  | 5d | 2019-09-27 | 2019-10-04 | 40 | 2.62d | 0d | Extreme Designs | 40h |
| 42 | 3.2.7 | Assemble Furniture |  | 2d | 2019-10-04 | 2019-10-08 | 41 | 2.62d | 0d | Extreme Designs | 16h |
| 43 | 3.2.8 | Hook up Computers |  | 1d | 2019-10-08 | 2019-10-09 | 42 | 2.62d | 0d | Network Heroes | 8h |
| 44 | 3.2.9 | Hook up Phones |  | 1d | 2019-10-08 | 2019-10-09 | 43FF | 2.62d | 0d | Network Heroes | 8h |
| 45 | 3.2.10 | Move in Belongings |  | 2d | 2019-10-09 | 2019-10-11 | 44 | 2.62d | 0d |  |  |
| 46 | 3.2.11 | JT Internet Sales Center Complete | milestone | 0d | 2019-10-11 | 2019-10-11 | 45 | 2.62d | 0d |  |  |
| 47 | 3.3 | **JT Administration Offices Refurbishing New Location** |  | 24d | 2019-09-09 | 2019-10-11 |  | 2.62d |  |  | 176h |
| 48 | 3.3.1 | Install Network Cables |  | 3d | 2019-09-09 | 2019-09-12 | 36SS | 2.62d | 0d | Network Heroes | 24h |
| 49 | 3.3.2 | Install TeleCommunication Lines |  | 1w | 2019-09-12 | 2019-09-19 | 48 | 2.62d | 0d | Network Heroes | 40h |
| 50 | 3.3.3 | Paint the walls |  | 2d | 2019-09-19 | 2019-09-23 | 49 | 2.62d | 0d | Extreme Designs | 16h |
| 51 | 3.3.4 | Lay Carpet |  | 2d | 2019-09-24 | 2019-09-26 | 50FS+1ed | 2.62d | 0d | Extreme Designs | 16h |
| 52 | 3.3.5 | Install Partitions |  | 1d | 2019-09-26 | 2019-09-27 | 51 | 2.62d | 0d | Extreme Designs | 8h |
| 53 | 3.3.6 | Prepare Offices |  | 5d | 2019-09-27 | 2019-10-04 | 52 | 2.62d | 0d | Extreme Designs | 40h |
| 54 | 3.3.7 | Assemble Furniture |  | 2d | 2019-10-04 | 2019-10-08 | 53 | 2.62d | 0d | Extreme Designs | 16h |
| 55 | 3.3.8 | Hook up Computers |  | 1d | 2019-10-08 | 2019-10-09 | 54 | 2.62d | 0d | Network Heroes | 8h |
| 56 | 3.3.9 | Hook up Phones |  | 1d | 2019-10-08 | 2019-10-09 | 55FF | 2.62d | 0d | Network Heroes | 8h |
| 57 | 3.3.10 | Move in Belongings |  | 2d | 2019-10-09 | 2019-10-11 | 56 | 2.62d | 0d |  |  |
| 58 | 3.3.11 | JT Administrative Offices Complete | milestone | 0d | 2019-10-11 | 2019-10-11 | 57 | 2.62d | 0d |  |  |
| 59 | 3.3.12 | JT Offices Refurbishing Complete | milestone | 0d | 2019-10-11 | 2019-10-11 | 34, 46, 58 | 2.62d |  |  |  |

| ID | WBS | Task | Type | Duration | Start | Finish | Predecessors | Total slack | Constraint | Resources | Work | Cost |
| --- | --- | --- | --- | --- | --- | --- | --- | --- | --- | --- | --- | --- |
| 60 | 4 | **Moving** |  | 32.25d | 2019-10-16 | 2019-11-29 |  | 0d |  |  | 1390h | 19,477.21 |
| 61 | 4.1 | **Packing** |  | 25.25d | 2019-10-16 | 2019-11-20 |  | 0d |  |  | 1318h | 16,917.21 |
| 62 | 4.1.1 | Distribute Boxes to Employees |  | 3d | 2019-10-16 | 2019-10-18 | 59 | 0d | start no earlier than 2019-10-16 | Maintenance | 24h | 960 |
| 63 | 4.1.2 | Communicate Timetable and Packing Requirements to Employees |  | 1d | 2019-10-21 | 2019-10-21 | 62 | 0d |  | Ron Sova | 8h | 200 |
| 64 | 4.1.3 | Tag Furniture and Equipment to Identify New Area Staging |  | 2w | 2019-10-22 | 2019-11-04 | 63 | 0d |  | Internet Sales Day Operators [700%]; Call Center Day Analysts [600%] | 1040h | 15,600 |
| 65 | 4.1.4 | Tag Computer Equipment to Identify New Are Staging |  | 2w | 2019-11-05 | 2019-11-18 | 64 | 0d |  | Informations Technology Systems [300%] | 240h |  |
| 66 | 4.1.5 | Packing Complete | milestone | 0d | 2019-11-18 | 2019-11-18 | 65 | 0d |  |  |  |  |
| 67 | 4.1.6 | **Final Moving Preperations** |  | 1.25d | 2019-11-19 | 2019-11-20 |  | 0d |  |  | 6h | 157.21 |
| 68 | 4.1.6.1 | Communicate Rotation Schedule to Insure Continous Operations |  | 3h | 2019-11-19 | 2019-11-19 | 66 | 0d |  | Ron Sova | 3h | 75 |
| 69 | 4.1.6.2 | Walk-through to Double Chjeck Tagging of All Furniture and Equipment |  | 2h | 2019-11-19 | 2019-11-19 | 68 | 0d |  | Charlie Mejia | 2h | 54.81 |
| 70 | 4.1.6.3 | Review Move Schedule with Team Leaders |  | 3h | 2019-11-19 | 2019-11-19 | 69 | 0d |  | Charlie Mejia [20%] | 0.6h | 16.44 |
| 71 | 4.1.6.4 | Review Move Schedule with Movers |  | 2h | 2019-11-20 | 2019-11-20 | 70 | 0d |  | Charlie Mejia [20%] | 0.4h | 10.96 |
| 72 | 4.1.6.5 | Final Moving Preperations Complete | milestone | 0d | 2019-11-20 | 2019-11-20 | 71 | 0d |  |  |  |  |
| 73 | 4.2 | **Move Furniture and Equipment** |  | 7d | 2019-11-20 | 2019-11-29 |  | 0d |  |  | 72h | 2,560 |
| 74 | 4.2.1 | Move JT Administrative Offices |  | 2d | 2019-11-20 | 2019-11-22 | 72 | 0d |  | Maintenance [200%] | 32h | 1,280 |
| 75 | 4.2.2 | Move First Wave JT Call Center |  | 1d | 2019-11-22 | 2019-11-25 | 74 | 0d |  | Maintenance [200%] | 16h | 640 |
| 76 | 4.2.3 | Move First Wave JT Internet Sales Center |  | 1d | 2019-11-25 | 2019-11-26 | 75 | 0d |  | Maintenance [200%] | 16h | 640 |
| 77 | 4.2.4 | Setup New JT Call Center for Operations |  | 0.5d | 2019-11-26 | 2019-11-26 | 76 | 0d |  | Network Heroes | 4h |  |
| 78 | 4.2.5 | Setup New JT Internet Sales Center for Operations |  | 0.5d | 2019-11-26 | 2019-11-27 | 77 | 0d |  | Network Heroes | 4h |  |
| 79 | 4.2.6 | New JT Call Center Operational | milestone | 0d | 2019-11-27 | 2019-11-27 | 78 | 0d |  |  |  |  |
| 80 | 4.2.7 | New JT Internet Sales Center Operational | milestone | 0d | 2019-11-27 | 2019-11-27 | 79 | 0d |  |  |  |  |
| 81 | 4.2.8 | Move Final Group JT Call Center |  | 1d | 2019-11-27 | 2019-11-28 | 80 | 0d |  |  |  |  |
| 82 | 4.2.9 | Move Final Group JT Internet Sales Center |  | 1d | 2019-11-28 | 2019-11-29 | 81 | 0d |  |  |  |  |
| 83 | 4.2.10 | Move Furniture and Equipment Complete | milestone | 0d | 2019-11-29 | 2019-11-29 | 82 | 0d |  |  |  |  |
| 84 | 4.3 | Move Complete | milestone | 0d | 2019-11-29 | 2019-11-29 | 83 | 0d |  |  |  |  |

| ID | WBS | Task | Type | Duration | Start | Finish | Predecessors | Total slack | Free slack | Constraint |
| --- | --- | --- | --- | --- | --- | --- | --- | --- | --- | --- |
| 85 | 5 | **JT Corporate Move Closeout** |  | 2.25d | 2019-11-29 | 2019-12-03 |  | 0d |  |  |
| 86 | 5.1 | Unpacking all areas |  | 2d | 2019-11-29 | 2019-12-03 | 84 | 0d |  |  |
| 87 | 5.2 | Company-Wide Meeting |  | 2h | 2019-12-03 | 2019-12-03 | 86 | 0d |  |  |
| 88 | 5.3 | Move Evaluation |  | 0.5d | 2019-12-02 | 2019-12-03 | 87SF | 0.12d | 0d |  |
| 89 | 5.4 | Pay Movers |  | 1h | 2019-12-03 | 2019-12-03 | 88 | 0.12d | 0d |  |
| 90 | 5.5 | JT Corporate Move Closeout Complete | milestone | 0d | 2019-12-03 | 2019-12-03 | 89 | 0.12d | 0d |  |
| 91 | 6 | JT Corporate Move Complete | milestone | 0d | 2019-12-03 | 2019-12-03 | 90 | 0.12d |  | finish no later than 2019-12-05 |
